# Medical IS Vendor Estimate

Schedule from MS Project, 2015-05-04 to 2016-06-29, costs in $, A marks actual dates.

## Calendars

- Standard: Mon-Fri 08:00-12:00, 13:00-17:00; Sat-Sun off.

## Resources

| Resource | Rate |
| --- | --- |
| Business Analyst | 50 |
| ETL Dev 1 | 75 |
| ETL Dev 2 | 75 |
| Report Dev 1 | 90 |
| Project Manager | 80 |
| Architect | 75 |
| QA | 50 |
| Report Dev 2 | 90 |
| Project Manager | 75 |
| SME | 60 |
| IS Manager | 95 |
| Business Owner | 100 |
| All stakeholders |  |
| DBA1 | 90 |
| Developer | 90 |
| Technical Support | 55 |
| Developre |  |

## Schedule

| ID | WBS | Task | Type | Duration | Start | Finish | Predecessors | Complete | Remaining | Total slack | Free slack | Constraint | Resources | Work | Actual work | Cost | Actual cost |
| --- | --- | --- | --- | --- | --- | --- | --- | --- | --- | --- | --- | --- | --- | --- | --- | --- | --- |
| 1 | 1 | **Medical IS Vendor Project** |  | 288d | 2015-05-04 A | 2016-06-08 |  | 26% | 212.46d | 15d |  |  |  | 3198.8h | 840.8h | 230,892 | 68,628 |
| 2 | 1.1 | **Initiation** |  | 24d | 2015-05-04 A | 2015-06-04 |  | 89% | 2.64d | 279d |  |  |  | 80h | 71.2h | 7,680 | 6,824 |
| 3 | 1.1.1 | Budget dollar service request |  | 5d | 2015-05-04 A | 2015-05-08 A |  | 100% |  |  |  |  | IS Manager | 40h | 40h | 3,800 | 3,800 |
| 4 | 1.1.2 | Project Charter |  | 2d | 2015-06-03 A | 2015-06-04 |  | 75% | 0.5d | 279d |  | finish no earlier than 2015-06-03 | Business Owner | 16h | 12h | 1,600 | 1,200 |
| 5 | 1.1.3 | Obtain Approvals | milestone | 3d | 2015-06-02 A | 2015-06-04 |  | 80% | 0.6d | 279d |  | start no earlier than 2015-04-23 | IS Manager | 24h | 19.2h | 2,280 | 1,824 |
| 6 | 1.2 | **Planning** |  | 39d | 2015-06-11 A | 2015-08-04 |  | 86% | 5.57d | 236d |  |  |  | 128h | 102h | 9,360 | 7,560 |
| 7 | 1.2.1 | Project Plan |  | 8d | 2015-07-15 A | 2015-08-04 |  | 94% | 0.5d | 236d |  | finish no earlier than 2015-08-04 | Project Manager | 64h | 60h | 4,800 | 4,500 |
| 8 | 1.2.2 | Resource allocation approvals |  | 3d | 2015-06-11 A | 2015-06-16 A | 7 | 100% |  |  |  | finish no earlier than 2015-06-16 | Project Manager | 24h | 24h | 1,800 | 1,800 |
| 9 | 1.2.3 | **Communication** |  | 4d | 2015-07-29 A | 2015-08-03 |  | 50% | 2d | 237d |  |  |  | 40h | 18h | 2,760 | 1,260 |
| 10 | 1.2.3.1 | Develop Communication Plan |  | 1d | 2015-07-29 A | 2015-07-29 |  | 75% | 0.25d | 238.75d | 1d | start no earlier than 2015-07-29 | Project Manager | 8h | 6h | 600 | 450 |
| 11 | 1.2.3.2 | Review/Approve Communication Plan | milestone | 2d | 2015-07-31 A | 2015-08-03 | 10 | 38% | 1.25d | 237d |  | start no earlier than 2015-07-31 | Project Manager; SME | 32h | 12h | 2,160 | 810 |
| 12 | 1.3 | Project Kickoff | milestone | 1d | 2015-08-05 A | 2015-08-05 A |  | 100% |  |  |  |  | All stakeholders | 8h | 8h |  |  |
| 13 | 1.4 | **Execution** |  | 116d | 2015-07-13 A | 2015-12-21 |  | 40% | 70.13d | 137d |  |  |  | 2779.6h | 659.6h | 197,764 | 54,244 |
| 14 | 1.4.1 | **Vendor Medical IS DB Tables** |  | 54d | 2015-08-10 A | 2015-10-22 |  | 98% | 1d | 179d |  |  |  | 432h | 424h | 36,320 | 35,920 |
| 15 | 1.4.1.1 | **Create Tables** |  | 47d | 2015-08-10 A | 2015-10-13 A |  | 100% |  |  |  |  |  | 376h | 376h | 33,200 | 33,200 |
| 16 | 1.4.1.1.1 | Create/Modify vendor database tables |  | 40d | 2015-08-10 A | 2015-10-02 A |  | 100% |  |  |  | finish no earlier than 2015-07-20 | DBA1 | 320h | 320h | 28,800 | 28,800 |
| 17 | 1.4.1.1.2 | Promote tables to QA |  | 2d | 2015-10-12 A | 2015-10-13 A | 16 | 100% |  |  |  | finish no earlier than 2015-07-24 | DBA1 | 16h | 16h | 1,440 | 1,440 |
| 18 | 1.4.1.1.3 | Validate tables |  | 3d | 2015-10-05 A | 2015-10-07 A | 17 | 100% |  |  |  | finish no earlier than 2015-07-17 | DBA1 | 24h | 24h | 2,160 | 2,160 |
| 19 | 1.4.1.1.4 | UAT |  | 2d | 2015-10-05 A | 2015-10-06 A | 18 | 100% |  |  |  | start no earlier than 2015-09-03 | Business Analyst | 16h | 16h | 800 | 800 |
| 20 | 1.4.1.2 | **Promote Tables to Production** |  | 27d | 2015-09-16 A | 2015-10-22 |  | 86% | 3.86d | 179d |  |  |  | 56h | 48h | 3,120 | 2,720 |
| 21 | 1.4.1.2.1 | Create production ticket SR# |  | 3d | 2015-09-16 A | 2015-09-18 A |  | 100% |  |  |  | start no earlier than 2015-09-16 | Business Analyst | 24h | 24h | 1,200 | 1,200 |
| 22 | 1.4.1.2.2 | Deploy Tables |  | 1d | 2015-10-19 A | 2015-10-19 A |  | 100% |  |  |  | start no earlier than 2015-09-17 | DBA1 | 8h | 8h | 720 | 720 |
| 23 | 1.4.1.2.3 | Validate Tables |  | 3d | 2015-10-20 A | 2015-10-22 | 22 | 67% | 1d | 179d |  | finish no earlier than 2015-10-22 | Business Analyst | 24h | 16h | 1,200 | 800 |
| 24 | 1.4.2 | **Final Code Review-Module 1** |  | 30d | 2015-09-07 A | 2015-10-16 A |  | 100% |  |  |  |  |  | 120h | 120h | 9,200 | 9,200 |
| 25 | 1.4.2.1 | Module 1 code review |  | 21d | 2015-09-07 A | 2015-10-05 A |  | 100% |  |  |  | finish no earlier than 2015-10-05 | Developer | 80h | 80h | 7,200 | 7,200 |
| 26 | 1.4.2.2 | Validate data accuracy |  | 5d | 2015-10-09 A | 2015-10-16 A |  | 100% |  |  |  | finish no earlier than 2015-10-16 | Business Analyst | 40h | 40h | 2,000 | 2,000 |

| ID | WBS | Task | Duration | Start | Finish | Predecessors | Complete | Total slack | Free slack | Constraint | Resources | Work | Actual work | Cost | Actual cost |
| --- | --- | --- | --- | --- | --- | --- | --- | --- | --- | --- | --- | --- | --- | --- | --- |
| 27 | 1.4.3 | **Final Code Review-Module 2** | 30d | 2015-09-07 A | 2015-10-16 A |  | 100% |  |  |  |  | 115.6h | 115.6h | 9,124 | 9,124 |
| 28 | 1.4.3.1 | Module 2 code review | 21d | 2015-09-07 A | 2015-10-05 A |  | 100% |  |  | finish no earlier than 2015-10-05 | Developer | 83.6h | 83.6h | 7,524 | 7,524 |
| 29 | 1.4.3.2 | Validate data accuracy | 4d | 2015-10-09 A | 2015-10-16 A | 28 | 100% |  |  | finish no earlier than 2015-10-16 | Business Analyst | 32h | 32h | 1,600 | 1,600 |
| 30 | 1.4.4 | **Final Code Review-Module 3** | 16d | 2015-10-05 | 2015-10-26 |  |  | 177d |  |  |  | 128h |  | 1,600 |  |
| 31 | 1.4.4.1 | Module 3 code review | 12d | 2015-10-05 | 2015-10-20 |  |  | 177d | 0d | start no earlier than 2015-10-05 | All stakeholders | 96h |  |  |  |
| 32 | 1.4.4.2 | Validate data accuracy | 4d | 2015-10-21 | 2015-10-26 | 31 |  | 177d |  |  | Business Analyst | 32h |  | 1,600 |  |
| 33 | 1.4.5 | **Medical IS Vendor Reporting** | 116d | 2015-07-13 | 2015-12-21 |  |  | 137d |  |  |  | 1984h |  | 141,520 |  |
| 34 | 1.4.5.1 | **Requirements** | 79d | 2015-07-13 | 2015-10-29 |  |  | 174d |  |  |  | 640h |  | 41,600 |  |
| 35 | 1.4.5.1.1 | Define Business Rules | 16d | 2015-07-13 | 2015-08-03 |  |  | 237d |  | start no earlier than 2015-07-13 | Business Analyst; Project Manager | 256h |  | 16,640 |  |
| 36 | 1.4.5.1.2 | Data Mapping | 11d | 2015-09-28 | 2015-10-12 |  |  | 137d | 0d | start no earlier than 2015-09-28 | Business Analyst; Project Manager | 176h |  | 11,440 |  |
| 37 | 1.4.5.1.3 | Report mockups | 4d | 2015-10-13 | 2015-10-16 | 36 |  | 158d | 0d |  | Business Analyst; Project Manager | 64h |  | 4,160 |  |
| 38 | 1.4.5.1.4 | Documentation and Current Mockup Layouts | 9d | 2015-10-19 | 2015-10-29 | 37 |  | 158d | 0d |  | Business Analyst; Project Manager | 144h |  | 9,360 |  |
| 39 | 1.4.5.2 | Requirements Approved | 2d | 2015-09-02 | 2015-09-03 |  |  | 214d |  | start no earlier than 2015-09-02 |  |  |  |  |  |
| 40 | 1.4.5.3 | **Report Development** | 50d | 2015-10-13 | 2015-12-21 |  |  | 137d |  |  |  | 1344h |  | 99,920 |  |
| 41 | 1.4.5.3.1 | Report file layout data mapping | 16d | 2015-10-30 | 2015-11-20 | 38 |  | 158d |  |  | Report Dev 1 | 128h |  | 11,520 |  |
| 42 | 1.4.5.3.2 | Report UAT | 8d | 2015-11-18 | 2015-11-27 |  |  | 153d |  | start no earlier than 2015-11-18 | Report Dev 1 | 64h |  | 5,760 |  |
| 43 | 1.4.5.3.3 | Reports Approved by Business Owner/Vendor | 2d | 2015-12-04 | 2015-12-07 |  |  | 147d |  | start no earlier than 2015-12-04 | IS Manager; Business Owner | 32h |  | 3,120 |  |
| 44 | 1.4.5.3.4 | **QA** | 50d | 2015-10-13 | 2015-12-21 |  |  | 137d |  |  |  | 1120h |  | 79,520 |  |
| 45 | 1.4.5.3.4.1 | Test Case Creation | 22d | 2015-10-13 | 2015-11-11 | 36 |  | 137d | 0d |  | QA | 176h |  | 8,800 |  |
| 46 | 1.4.5.3.4.2 | Test Case Execution | 28d | 2015-11-12 | 2015-12-21 | 45 |  | 137d |  |  | QA | 224h |  | 11,200 |  |
| 47 | 1.4.5.3.4.3 | Deploy Reports to Production | 2d | 2015-11-10 | 2015-11-11 |  |  | 165d |  | start no earlier than 2015-11-10 | Developer | 16h |  | 1,440 |  |
| 48 | 1.4.5.3.4.4 | **UAT** | 22d | 2015-11-11 | 2015-12-10 |  |  | 144d |  |  |  | 704h |  | 58,080 |  |
| 49 | 1.4.5.3.4.4.1 | Testing Support | 4d | 2015-11-11 | 2015-11-16 |  |  | 144d | 0d | start no earlier than 2015-11-11 | ETL Dev 1; Report Dev 1; ETL Dev 2; Report Dev 2 | 128h |  | 10,560 |  |
| 50 | 1.4.5.3.4.4.2 | Remediation | 4d | 2015-11-17 | 2015-11-20 | 49 |  | 144d | 0d |  | ETL Dev 1; Report Dev 1; ETL Dev 2; Report Dev 2 | 128h |  | 10,560 |  |
| 51 | 1.4.5.3.4.4.3 | Production Support | 14d | 2015-11-23 | 2015-12-10 | 50 |  | 144d |  | finish no earlier than 2015-11-30 | ETL Dev 1; ETL Dev 2; Report Dev 1; Report Dev 2 | 448h |  | 36,960 |  |

Notes:
- 30: Project BEHIND

| ID | WBS | Task | Type | Duration | Start | Finish | Predecessors | Total slack | Free slack | Constraint | Resources | Work | Cost |
| --- | --- | --- | --- | --- | --- | --- | --- | --- | --- | --- | --- | --- | --- |
| 52 | 1.5 | **Oversight** |  | 92d | 2015-07-13 | 2015-11-17 |  | 161d |  |  |  | 147.2h | 11,408 |
| 53 | 1.5.1 | Project Manager |  | 92d | 2015-07-13 | 2015-11-17 |  | 161d |  |  | Project Manager [10%] | 73.6h | 5,888 |
| 54 | 1.5.2 | Architect |  | 92d | 2015-07-13 | 2015-11-17 |  | 161d |  |  | Architect [10%] | 73.6h | 5,520 |
| 55 | 1.6 | **Go-Live** |  | 3d | 2016-06-06 | 2016-06-08 |  | 15d |  |  |  | 8h |  |
| 56 | 1.6.1 | Go-Live Milestone |  | 1d | 2016-06-06 | 2016-06-06 |  | 17d |  | start no earlier than 2016-06-06 |  |  |  |
| 57 | 1.6.2 | Module Reports in Production- Go live |  | 1d | 2016-06-08 | 2016-06-08 |  | 15d |  | start no earlier than 2016-06-08 |  | 8h |  |
| 58 | 1.7 | **Monitor and Control** |  | 191d | 2015-07-13 | 2016-04-04 |  | 62d |  |  |  | 48h | 4,680 |
| 59 | 1.7.1 | **Support** |  | 191d | 2015-07-13 | 2016-04-04 |  | 62d |  |  |  | 48h | 4,680 |
| 60 | 1.7.1.1 | Define Support Process |  | 3d | 2016-03-28 | 2016-03-30 |  | 62d | 0d | start no earlier than 2016-03-28 | IS Manager | 24h | 2,280 |
| 61 | 1.7.1.2 | Review Support Process |  | 3d | 2016-03-31 | 2016-04-04 | 60 | 62d |  | start no earlier than 2016-03-31 | Business Owner | 24h | 2,400 |
| 62 | 1.7.1.3 | Support Process Approved | milestone | 0d | 2015-07-13 | 2015-07-13 |  | 253d |  |  | IS Manager; Business Owner |  |  |
| 63 | 2 | **Closing** |  | 4d | 2016-06-24 | 2016-06-29 |  | 0d |  |  |  | 32h | 2,560 |
| 64 | 2.1 | Lessons Learned |  | 4d | 2016-06-24 | 2016-06-29 |  | 0d |  | start no earlier than 2016-06-24 | Project Manager | 32h | 2,560 |
