# WBS_Assignment -3

Schedule from MS Project, 2019-08-01 to 2020-03-03, costs in $.
Ironwood Pharmaceuticals, Inc.

## Calendars

- Standard: Mon-Fri 08:00-12:00, 13:00-17:00; Sat-Sun off.

## Resources

| Resource | Group | Rate |
| --- | --- | --- |
| IQL PM |  | 150 |
| IQL CS |  | 100 |
| IQL TG |  | 100 |
| IQL SA |  | 100 |
| IQL QA 1 |  | 125 |
| SP PM |  | 75 |
| SP QA |  | 75 |
| SP Tech | Contractor | 75 |
| SP BO |  |  |
| SP ITO |  | 75 |
| IQL Developer 1 | Contractor | 150 |
| IQL Trainer |  | 100 |
| IQL Maintainence Associate |  | 100 |
| Trainer Specialist |  | 75 |
| IQL On-Site Host |  | 75 |
| Scanner |  |  |
| Printer |  |  |
| SP Approvers |  |  |
| SP Trainer |  | 75 |
| SP Migration Specialist |  | 100 |
| IQL Migration Specialist |  | 100 |
| IQL Migration PM |  | 150 |
| SP Approvers 2 |  |  |
| SP Technical 2 |  | 50 |
| SP Technical 3 |  | 50 |
| IQL QA 2 |  | 125 |
| IQL Migration QA |  | 100 |
| SP Technical 4 |  | 50 |
| SP Technical 5 |  | 50 |
| SP QA 2 |  | 75 |
| Airfare Tickets |  |  |
| Servers |  |  |

## Schedule

| ID | WBS | Task | Type | Duration | Start | Finish | Predecessors | Total slack | Free slack | Constraint | Resources | Work | Cost | Deliverable |
| --- | --- | --- | --- | --- | --- | --- | --- | --- | --- | --- | --- | --- | --- | --- |
| 1 | 1 | **Intake Tool Implementation at Shire Pharmaceuticals** |  | 154d | 2019-08-01 | 2020-03-03 |  | 0d |  | start no earlier than 2019-08-01 |  | 2002h | 121,375 | No |
| 2 | 1.1 | **Project Initiating** |  | 34d | 2019-08-01 | 2019-09-17 |  | 0d |  |  |  | 85h | 600 | No |
| 3 | 1.1.1 | Working Session with SP - Scope Definition |  | 10d | 2019-08-01 | 2019-08-14 |  | 0d |  |  |  | 1h |  | No |
| 4 | 1.1.2 | Prepare Project Charter |  | 14d | 2019-08-15 | 2019-09-03 | 3 | 0d |  |  | IQL PM [3.6%] | 4h | 600 | No |
| 5 | 1.1.3 | Revision and Approval of Project Charter | milestone | 10d | 2019-09-04 | 2019-09-17 | 4 | 0d |  |  | SP Approvers | 80h |  | Yes |
| 6 | 1.2 | **Project Planning** |  | 13d | 2019-09-18 | 2019-10-04 |  | 0d |  |  |  | 102h | 5,800 | No |
| 7 | 1.2.1 | Prepare PMP |  | 3d | 2019-09-18 | 2019-09-20 | 5 | 0d |  |  | SP PM [16.7%]; IQL PM [16.7%] | 8h | 900 | No |
| 8 | 1.2.2 | Prepare PP |  | 0.5d | 2019-09-18 | 2019-09-18 | 7SS | 119.5d |  |  | IQL PM | 4h | 600 | No |
| 9 | 1.2.3 | Rev and App of PMP |  | 10d | 2019-09-23 | 2019-10-04 | 7 | 0d |  |  | SP Technical 3 | 80h | 4,000 | No |
| 10 | 1.2.4 | Rev and Approval of PP | milestone | 1d | 2019-09-23 | 2019-09-23 | 9SS | 0d |  |  | SP Approvers | 8h |  | Yes |
| 11 | 1.2.5 | Kick Off Meeting |  | 0.25d | 2019-09-26 | 2019-09-26 | 10FS+2d | 0d |  |  | IQL PM | 2h | 300 | No |
| 12 | 1.3 | **Project Execution** |  | 154d | 2019-08-01 | 2020-03-03 |  | 0d |  |  |  | 1741h | 110,250 | No |
| 13 | 1.3.1 | Project Management |  | 108d | 2019-08-01 | 2019-12-30 | 3SS | 46d |  |  |  | 64h |  | No |
| 14 | 1.3.2 | **Core Software Installation** |  | 34d | 2019-09-26 | 2019-11-13 |  | 58.75d |  |  |  | 75h | 8,100 | No |
| 15 | 1.3.2.1 | Software Parameters Gathering |  | 1d | 2019-09-26 | 2019-09-27 | 11 | 112.75d |  |  | IQL CS [12.5%] | 1h | 100 | No |
| 16 | 1.3.2.2 | Setup host at the Shire Pharmaceuticals Site |  | 20d | 2019-09-26 | 2019-10-24 | 11 | 58.75d | 0d |  | IQL CS [25%] | 40h | 4,000 | No |
| 17 | 1.3.2.3 | Shire Pharmaceuticals Env plan |  | 1d | 2019-10-24 | 2019-10-25 | 16 | 58.75d | 0d |  | IQL TG [25%] | 2h | 200 | No |
| 18 | 1.3.2.4 | Shire pharmaceuticals Sharepoint site evalutaion |  | 1d | 2019-10-25 | 2019-10-28 | 17 | 58.75d | 0d |  | IQL Developer 1 | 8h | 1,200 | No |
| 19 | 1.3.2.5 | Configuration Specification Prep |  | 2d | 2019-10-28 | 2019-10-30 | 18 | 58.75d | 0d |  | IQL CS [25%] | 4h | 400 | No |
| 20 | 1.3.2.6 | Install all Pre-Req Compopnents of Intake Tool |  | 2d | 2019-10-30 | 2019-11-01 | 19 | 58.75d | 0d |  | IQL SA [50%] | 8h | 800 | No |
| 21 | 1.3.2.7 | Install Intake Tool in all 3 environments (SB, Val and Test) | milestone | 5d | 2019-11-06 | 2019-11-13 | 18, 20FS+3d | 58.75d | 0d |  | IQL SA [20%] | 8h | 800 | No |
| 22 | 1.3.2.8 | Installation of SharePoint Server |  | 2d | 2019-11-01 | 2019-11-05 | 18, 20 | 84.75d | 57.75d |  | IQL Developer 1 [25%] | 4h | 600 | No |
| 23 | 1.3.3 | **User Requirements** |  | 30d | 2019-09-26 | 2019-11-06 |  | 0d |  |  |  | 100h | 6,275 | No |
| 24 | 1.3.3.1 | **Intake Tool Setup** |  | 30d | 2019-09-26 | 2019-11-06 |  | 0d |  |  |  | 6h | 675 | No |
| 25 | 1.3.3.1.1 | User Requirements Gathering |  | 4d | 2019-09-26 | 2019-10-01 | 11SS | 0d |  |  | IQL PM [9.4%] | 3h | 450 | No |
| 26 | 1.3.3.1.2 | URS Prep |  | 1d | 2019-10-02 | 2019-10-02 | 25 | 108d | 24d |  | SP ITO [25%] | 2h | 150 | No |
| 27 | 1.3.3.1.3 | Approve URS | milestone | 1d | 2019-11-06 | 2019-11-06 | 26, 32SS, 37SS | 84d |  |  | SP QA [12.5%] | 1h | 75 | Yes |

| ID | WBS | Task | Type | Duration | Start | Finish | Predecessors | Total slack | Free slack | Resources | Work | Cost | Deliverable |
| --- | --- | --- | --- | --- | --- | --- | --- | --- | --- | --- | --- | --- | --- |
| 28 | 1.3.3.2 | **Mail Configuration** |  | 25d | 2019-09-26 | 2019-10-30 |  | 0d |  |  | 27h | 600 | No |
| 29 | 1.3.3.2.1 | User Requirements Gathering |  | 1d | 2019-09-26 | 2019-09-26 | 25SS | 0d |  | SP ITO [50%] | 4h | 300 | No |
| 30 | 1.3.3.2.2 | URS Prep |  | 3d | 2019-09-27 | 2019-10-01 | 29 | 4d | 0d | SP ITO [16.7%] | 4h | 300 | No |
| 31 | 1.3.3.2.3 | Evaluate URS |  | 20d | 2019-10-02 | 2019-10-29 | 30 | 4d | 0d | SP BO [10%] | 16h |  | No |
| 32 | 1.3.3.2.4 | Approve URS | milestone | 1d | 2019-10-30 | 2019-10-30 | 31 | 4d | 0d | SP Approvers [37.5%] | 3h |  | Yes |
| 33 | 1.3.3.3 | **Integration to ServiceNow** |  | 30d | 2019-09-26 | 2019-11-06 |  | 0d |  |  | 67h | 5,000 | No |
| 34 | 1.3.3.3.1 | User Requirements Gathering |  | 1d | 2019-09-26 | 2019-09-26 | 29SS | 0d |  | IQL Trainer | 8h | 800 | No |
| 35 | 1.3.3.3.2 | URS Prep |  | 3d | 2019-09-27 | 2019-10-01 | 34 | 0d |  | SP Trainer [33.3%] | 8h | 600 | No |
| 36 | 1.3.3.3.3 | Evaluate URS |  | 25d | 2019-10-02 | 2019-11-05 | 35 | 0d |  | SP ITO [12%]; SP Trainer [12%] | 48h | 3,600 | No |
| 37 | 1.3.3.3.4 | Approve URS | milestone | 1d | 2019-11-06 | 2019-11-06 | 36 | 0d |  | SP Approvers [37.5%] | 3h |  | Yes |
| 38 | 1.3.4 | **Configuration** |  | 52.75d | 2019-11-13 | 2020-01-24 |  | 27d |  |  | 74h | 5,500 | No |
| 39 | 1.3.4.1 | **Core Software** |  | 1d | 2020-01-23 | 2020-01-23 |  | 0d |  |  | 8h | 500 | No |
| 40 | 1.3.4.1.1 | Set Up Section Configuration |  | 1d | 2020-01-23 | 2020-01-23 | 32, 37, 57 | 0d |  | SP BO [25%] | 2h |  | No |
| 41 | 1.3.4.1.2 | Document Section Configuration |  | 1d | 2020-01-23 | 2020-01-23 | 32, 40SS | 0d |  | SP ITO [25%] | 2h | 150 | Yes |
| 42 | 1.3.4.1.3 | Train Section Configuration |  | 1d | 2020-01-23 | 2020-01-23 | 37, 41SS | 0d |  | SP Trainer [25%] | 2h | 150 | No |
| 43 | 1.3.4.1.4 | Configuration Implementation |  | 1d | 2020-01-23 | 2020-01-23 | 42SS | 0d |  | IQL SA [25%] | 2h | 200 | Yes |
| 44 | 1.3.4.2 | **Box** |  | 1d | 2020-01-24 | 2020-01-24 |  | 27d |  |  | 2h | 200 | No |
| 45 | 1.3.4.2.1 | Configuration of Box Site |  | 1d | 2020-01-24 | 2020-01-24 | 22, 43 | 27d |  | IQL SA [25%] | 2h | 200 | No |
| 46 | 1.3.4.3 | **ServiceNow Integration** |  | 8d | 2019-11-13 | 2019-11-25 |  | 71.75d |  |  | 64h | 4,800 | Yes |
| 47 | 1.3.4.3.1 | Integration Set-up |  | 3d | 2019-11-13 | 2019-11-18 | 21 | 71.75d | 0d | SP PM | 24h | 1,800 | No |
| 48 | 1.3.4.3.2 | Testing of Integration |  | 5d | 2019-11-18 | 2019-11-25 | 47 | 71.75d |  | SP Tech | 40h | 3,000 | No |
| 49 | 1.3.5 | **Migration Activities** |  | 83d | 2019-10-31 | 2020-02-24 |  | 0d |  |  | 700h | 59,175 | No |
| 50 | 1.3.5.1 | **E-mail** |  | 83d | 2019-10-31 | 2020-02-24 |  | 0d |  |  | 700h | 59,175 | No |
| 51 | 1.3.5.1.1 | Planning |  | 1d | 2019-10-31 | 2019-10-31 | 32 | 4d |  | IQL Migration Specialist [50%] | 4h | 400 | Yes |
| 52 | 1.3.5.1.2 | Migration Preparation |  | 2d | 2019-11-07 | 2019-11-08 | 51, 37 | 0d |  | SP ITO [50%]; IQL Migration Specialist | 24h | 2,200 | No |
| 53 | 1.3.5.1.3 | Fill out Request for e-mail boxes to be migrated |  | 10d | 2019-11-11 | 2019-11-22 | 52 | 0d |  | SP Approvers; SP ITO; SP BO | 240h | 6,000 | No |
| 54 | 1.3.5.1.4 | Develop Spreadsheet |  | 1d | 2019-11-25 | 2019-11-25 | 51, 53 | 0d |  | IQL CS [50%] | 4h | 400 | No |
| 55 | 1.3.5.1.5 | Review of Spreadsheet |  | 10d | 2019-11-26 | 2019-12-09 | 54 | 0d |  | IQL Migration Specialist [20%] | 16h | 1,600 | No |
| 56 | 1.3.5.1.6 | Execution Log Preparation |  | 40d | 2019-11-26 | 2020-01-20 | 55SS | 0d |  | IQL QA 1 | 320h | 40,000 | No |
| 57 | 1.3.5.1.7 | Finalize Spreadsheet |  | 2d | 2020-01-21 | 2020-01-22 | 56 | 0d |  | IQL Migration PM [50%] | 8h | 1,200 | Yes |
| 58 | 1.3.5.1.8 | Approve Spreadsheet |  | 1d | 2020-01-23 | 2020-01-23 | 57 | 0d |  | IQL Migration Specialist [12.5%] | 1h | 100 | Yes |
| 59 | 1.3.5.1.9 | Informal Migration Testing - VAL |  | 3d | 2020-01-24 | 2020-01-28 | 58, 43, 55 | 0d |  | IQL TG [66.7%] | 16h | 1,600 | No |
| 60 | 1.3.5.1.10 | Informal Migration Testing review |  | 1d | 2020-01-29 | 2020-01-29 | 59 | 0d |  | IQL TG [12.5%] | 1h | 100 | No |
| 61 | 1.3.5.1.11 | Modifications to Spreadsheet |  | 5d | 2020-01-30 | 2020-02-05 | 60 | 0d |  | IQL Migration Specialist [60%] | 24h | 2,400 | No |
| 62 | 1.3.5.1.12 | Modify Execution Protocol |  | 1d | 2020-02-06 | 2020-02-06 | 61 | 0d |  | IQL CS [12.5%] | 1h | 100 | No |
| 63 | 1.3.5.1.13 | Migration log review | milestone | 1d | 2020-02-07 | 2020-02-07 | 62 | 0d |  | SP QA [12.5%] | 1h | 75 | No |
| 64 | 1.3.5.1.14 | Execute Migration execution in VAL |  | 3d | 2020-02-10 | 2020-02-12 | 63 | 0d |  | SP Tech [33.3%] | 8h | 600 | No |
| 65 | 1.3.5.1.15 | Final Changes review |  | 5d | 2020-02-13 | 2020-02-19 | 64 | 0d |  | SP ITO [60%] | 24h | 1,800 | No |
| 66 | 1.3.5.1.16 | Formal Execution of Migration in PROD | milestone | 3d | 2020-02-20 | 2020-02-24 | 94, 65 | 0d |  | SP Tech [33.3%] | 8h | 600 | No |

| ID | WBS | Task | Type | Duration | Start | Finish | Predecessors | Total slack | Free slack | Resources | Work | Cost | Deliverable |
| --- | --- | --- | --- | --- | --- | --- | --- | --- | --- | --- | --- | --- | --- |
| 67 | 1.3.6 | **Validation** |  | 154d | 2019-08-01 | 2020-03-03 |  | 0d |  |  | 376h | 28,800 | No |
| 68 | 1.3.6.1 | **Validation Plannning** |  | 9d | 2019-09-26 | 2019-10-09 |  | 83.75d |  |  | 22h | 1,500 | No |
| 69 | 1.3.6.1.1 | Prep Validation Plan |  | 2d | 2019-09-26 | 2019-09-30 | 11 | 83.75d | 0d | SP Tech | 16h | 1,200 | No |
| 70 | 1.3.6.1.2 | Review |  | 5d | 2019-09-30 | 2019-10-07 | 69 | 83.75d | 0d | SP ITO [10%] | 4h | 300 | No |
| 71 | 1.3.6.1.3 | Approval | milestone | 2d | 2019-10-07 | 2019-10-09 | 70 | 83.75d | 25d | SP Approvers [12.5%] | 2h |  | Yes |
| 72 | 1.3.6.2 | **Intake Tool 10.0 Core Software Validation.** |  | 21d | 2019-11-13 | 2019-12-12 |  | 58.75d |  |  | 144h | 13,600 | No |
| 73 | 1.3.6.2.1 | Prep Core Installation Qualification |  | 1d | 2019-11-13 | 2019-11-14 | 21, 71 | 58.75d | 0d | IQL TG | 8h | 800 | No |
| 74 | 1.3.6.2.2 | Review Core Installation Qualification |  | 1d | 2019-11-14 | 2019-11-15 | 73 | 58.75d | 0d | SP Approvers 2 | 8h |  | No |
| 75 | 1.3.6.2.3 | Execution of Core Software Installation IQ |  | 3d | 2019-11-15 | 2019-11-20 | 74, 21 | 58.75d | 0d | SP Technical 3 | 24h | 1,200 | No |
| 76 | 1.3.6.2.4 | Prep IQ Summary Report |  | 1d | 2019-11-20 | 2019-11-21 | 75 | 58.75d | 0d | SP Technical 2 [50%] | 4h | 200 | No |
| 77 | 1.3.6.2.5 | Revision and Approval of IQ summary Report |  | 1d | 2019-11-21 | 2019-11-22 | 76 | 72.75d |  | SP Approvers 2 [50%] | 4h |  | No |
| 78 | 1.3.6.2.6 | Monitoring plan prep and review |  | 3d | 2019-11-21 | 2019-11-26 | 76 | 58.75d | 0d | IQL TG [33.3%] | 8h | 800 | No |
| 79 | 1.3.6.2.7 | Finalize Monitoring plan |  | 10d | 2019-11-26 | 2019-12-10 | 78 | 58.75d | 0d | IQL QA 2 | 80h | 10,000 | No |
| 80 | 1.3.6.2.8 | Approve Monitoring Plan |  | 2d | 2019-12-10 | 2019-12-12 | 79 | 58.75d |  | SP Tech [50%] | 8h | 600 | Yes |
| 81 | 1.3.6.3 | **Shire Pharmaceuticals Intake Tool Validation** |  | 12d | 2019-11-13 | 2019-11-29 |  | 67.75d |  |  | 92h | 5,800 | No |
| 82 | 1.3.6.3.1 | **E-mails** |  | 12d | 2019-11-13 | 2019-11-29 |  | 67.75d |  |  | 92h | 5,800 | No |
| 83 | 1.3.6.3.1.1 | Prepare Instalation Qulaification |  | 5d | 2019-11-13 | 2019-11-20 | 73SS | 67.75d | 0d | SP Technical 4 | 40h | 2,000 | No |
| 84 | 1.3.6.3.1.2 | Review Installation Qualification | milestone | 1d | 2019-11-20 | 2019-11-21 | 83 | 67.75d | 0d | SP QA | 8h | 600 | No |
| 85 | 1.3.6.3.1.3 | Execution of Software Installation IQ |  | 1d | 2019-11-21 | 2019-11-22 | 84 | 67.75d | 0d | SP Technical 5 [50%] | 4h | 200 | No |
| 86 | 1.3.6.3.1.4 | Prep IQ Summary Report | milestone | 5d | 2019-11-22 | 2019-11-29 | 85 | 67.75d |  | SP QA 2 | 40h | 3,000 | Yes |
| 87 | 1.3.6.4 | **IOQ Summary** |  | 1d | 2020-02-24 | 2020-02-24 |  | 6d |  |  | 20h | 200 | No |
| 88 | 1.3.6.4.1 | Reports approval |  | 1d | 2020-02-24 | 2020-02-24 | 43, 104 | 6d |  | SP Technical 5 [50%]; Printer; Scanner | 20h | 200 | No |
| 89 | 1.3.6.5 | **Migration validation** |  | 154d | 2019-08-01 | 2020-03-03 |  | 0d |  |  | 98h | 7,700 | No |
| 90 | 1.3.6.5.1 | **Documents** |  | 31d | 2020-01-21 | 2020-03-03 |  | 0d |  |  | 49h | 4,050 | No |
| 91 | 1.3.6.5.1.1 | Execution of OQ Script |  | 3d | 2020-01-21 | 2020-01-23 | 56 | 12d | 0d | SP Migration Specialist [16.7%] | 4h | 400 | No |
| 92 | 1.3.6.5.1.2 | Review of exeucted OQ scripts |  | 3d | 2020-01-24 | 2020-01-28 | 91 | 12d |  | SP QA 2 [33.3%] | 8h | 600 | No |
| 93 | 1.3.6.5.1.3 | Testing in Validtaion |  | 3d | 2020-02-14 | 2020-02-18 | 64, 92, 107 | 0d |  | SP Migration Specialist [66.7%] | 16h | 1,600 | No |
| 94 | 1.3.6.5.1.4 | Deviation assessment |  | 1d | 2020-02-19 | 2020-02-19 | 93 | 0d |  | SP ITO [25%] | 2h | 150 | No |
| 95 | 1.3.6.5.1.5 | Testing in PROD |  | 3d | 2020-02-25 | 2020-02-27 | 94, 66 | 0d |  | SP ITO [66.7%] | 16h | 1,200 | No |
| 96 | 1.3.6.5.1.6 | OQ Sumamry Report Prep |  | 2d | 2020-02-28 | 2020-03-02 | 95 | 0d |  | SP Technical 5 [12.5%] | 2h | 100 | No |
| 97 | 1.3.6.5.1.7 | Review of OQ Summary Report | milestone | 1d | 2020-03-03 | 2020-03-03 | 96 | 0d |  | SP Approvers 2 [12.5%] | 1h |  | Yes |

| ID | WBS | Task | Type | Duration | Start | Finish | Predecessors | Total slack | Free slack | Resources | Work | Cost | Deliverable |
| --- | --- | --- | --- | --- | --- | --- | --- | --- | --- | --- | --- | --- | --- |
| 98 | 1.3.6.5.2 | **E-mail** |  | 148d | 2019-08-01 | 2020-02-24 |  | 6d |  |  | 49h | 3,650 | No |
| 99 | 1.3.6.5.2.1 | Execution of OQ Script |  | 3d | 2019-08-01 | 2019-08-05 |  | 143d | 0d | SP Migration Specialist [16.7%] | 4h | 400 | No |
| 100 | 1.3.6.5.2.2 | Review of exeucted OQ scripts |  | 1d | 2019-08-06 | 2019-08-06 | 99 | 143d | 137d | SP QA 2 | 8h | 600 | No |
| 101 | 1.3.6.5.2.3 | Testing in Validtaion |  | 2d | 2020-02-14 | 2020-02-17 | 100, 107 | 6d | 0d | SP Trainer | 16h | 1,200 | No |
| 102 | 1.3.6.5.2.4 | Deviation assessment |  | 1d | 2020-02-18 | 2020-02-18 | 101 | 6d | 0d | SP QA 2 [25%] | 2h | 150 | No |
| 103 | 1.3.6.5.2.5 | Testing in PROD |  | 2d | 2020-02-19 | 2020-02-20 | 102 | 6d | 0d | SP Trainer | 16h | 1,200 | Yes |
| 104 | 1.3.6.5.2.6 | OQ Sumamry Report Prep |  | 1d | 2020-02-21 | 2020-02-21 | 103 | 6d | 0d | SP Technical 5 [25%] | 2h | 100 | No |
| 105 | 1.3.6.5.2.7 | Review of OQ Summary Report | milestone | 1d | 2020-02-24 | 2020-02-24 | 104 | 6d |  | SP Approvers 2 [12.5%] | 1h |  | No |
| 106 | 1.3.7 | **Training** |  | 10d | 2020-01-31 | 2020-02-13 |  | 0d |  |  | 352h | 2,400 | No |
| 107 | 1.3.7.1 | Train-the-Trainer |  | 10d | 2020-01-31 | 2020-02-13 | 59FS+2d | 0d |  | SP Trainer [40%]; Printer; Scanner; Servers; Airfare Tickets | 352h | 2,400 | No |
| 108 | 1.4 | **Closing** |  | 8d | 2020-02-20 | 2020-03-02 |  | 1d |  |  | 74h | 4,725 | Yes |
| 109 | 1.4.1 | GO LIVE | milestone | 1d | 2020-02-20 | 2020-02-20 | 107FS+4d | 1d | 0d | IQL On-Site Host [12.5%] | 1h | 75 | No |
| 110 | 1.4.2 | Assesment Sessions with Project Team |  | 1d | 2020-02-21 | 2020-02-21 | 109 | 1d | 0d | Trainer Specialist [12.5%] | 1h | 75 | No |
| 111 | 1.4.3 | Assesment Sessions with SP |  | 2d | 2020-02-24 | 2020-02-25 | 110 | 1d | 0d | Trainer Specialist [50%] | 8h | 600 | No |
| 112 | 1.4.4 | Risks / Issues Evaluation |  | 1d | 2020-02-26 | 2020-02-26 | 111 | 1d | 0d | SP QA [12.5%]; IQL QA 1 [12.5%]; IQL QA 2 [12.5%] | 3h | 325 | No |
| 113 | 1.4.5 | Training System Owners/Super Users on Intake Tool Support Level 2 organization (Intake Tool) |  | 1d | 2020-02-27 | 2020-02-27 | 112 | 1d | 0d | SP Trainer [12.5%]; IQL Trainer [12.5%] | 2h | 175 | No |
| 114 | 1.4.6 | Transfer Operational Reponsibilities |  | 1d | 2020-02-28 | 2020-02-28 | 113 | 1d | 0d | IQL PM [12.5%] | 1h | 150 | Yes |
| 115 | 1.4.7 | Prepare Project Closure |  | 2d | 2020-02-27 | 2020-02-28 | 112 | 2d |  | IQL PM [25%] | 4h | 600 | No |
| 116 | 1.4.8 | Hold Project Closure Meeting | milestone | 1d | 2020-03-02 | 2020-03-02 | 114 | 1d | 0d | SP PM [12.5%]; IQL PM [12.5%] | 2h | 225 | Yes |
| 117 | 1.4.9 | Disband Project Team | milestone | 0d | 2020-03-02 | 2020-03-02 | 116SS | 2d |  | SP PM; IQL PM |  |  | No |
| 118 | 1.4.10 | Celebrate! |  | 1d | 2020-03-02 | 2020-03-02 | 116SS | 1d |  | Trainer Specialist [50%]; IQL On-Site Host [50%]; SP Approvers [50%]; SP Approvers 2 [50%]; SP ITO [50%]; SP PM [50%]; SP QA [50%]; SP QA 2 [50%]; SP Technical 4 [50%]; SP Technical 5 [50%]; SP Tech; Airfare Tickets | 52h | 2,500 | No |
