# Hardware Upgrade

Schedule from MS Project, 2018-11-26 to 2019-01-18, status date 2018-12-10, costs in $, A marks actual dates.

## Calendars

- Standard: Mon-Fri 08:00-12:00, 13:00-17:00; Sat-Sun off.
- VOIP: Mon-Fri 08:00-12:00, 13:00-17:00; Sat-Sun off.

## Resources

| Resource | Rate |
| --- | --- |
| Project Manager | 20 |
| Network Technician | 15 |
| System Analyst | 25 |
| Procurement Lead | 15 |
| System Admin | 20 |
| Database Manager | 18 |
| Software Tester | 13 |
| Tech Support | 10 |
| Rack PCs | 10000 |
| LAN | 15000 |
| Hardware | 5000 |
| Transport |  |
| Office lunches |  |

## Schedule

| ID | WBS | Task | Duration | Start | Finish | Predecessors | Complete | Remaining | Baseline start | Baseline finish | Baseline duration | Total slack | Free slack | Constraint | Calendar | Resources | Work | Actual work | Cost | Baseline cost | Actual cost |
| --- | --- | --- | --- | --- | --- | --- | --- | --- | --- | --- | --- | --- | --- | --- | --- | --- | --- | --- | --- | --- | --- |
| 1 | 1 | **Define Upgrade Requirements** | 3d | 2018-11-26 A | 2018-11-28 A |  | 100% |  | 2018-11-26 | 2018-11-28 | 3d |  |  |  |  |  | 24h | 24h | 480 | 480 | 480 |
| 2 | 1.1 | Define Internal business requirements | 1d | 2018-11-26 A | 2018-11-26 A |  | 100% |  | 2018-11-26 | 2018-11-26 | 1d |  |  |  |  | Project Manager | 8h | 8h | 160 | 160 | 160 |
| 3 | 1.2 | Define External business requirements | 1d | 2018-11-27 A | 2018-11-27 A | 2 | 100% |  | 2018-11-27 | 2018-11-27 | 1d |  |  |  |  | Project Manager | 8h | 8h | 160 | 160 | 160 |
| 4 | 1.3 | Define Technical requirements | 1d | 2018-11-28 A | 2018-11-28 A | 3 | 100% |  | 2018-11-28 | 2018-11-28 | 1d |  |  |  |  | Project Manager | 8h | 8h | 160 | 160 | 160 |
| 5 | 2 | **Acquisition of Upgrade Components** | 10.1d | 2018-12-10 A | 2018-12-24 |  | 26% | 7.44d | 2018-12-10 | 2018-12-14 | 5d | 19d |  |  |  |  | 88h | 23.2h | 1,560 | 960 | 428 |
| 6 | 2.1 | **Hardware components** | 10.1d | 2018-12-10 A | 2018-12-24 |  | 24% | 7.7d | 2018-12-10 | 2018-12-12 | 3d | 0d |  |  |  |  | 64h | 15.2h | 960 | 360 | 228 |
| 7 | 2.1.1 | Request for Tender | 1d | 2018-12-10 A | 2018-12-10 A | 2, 3, 4 | 100% |  | 2018-12-10 | 2018-12-10 | 1d |  |  | start no earlier than 2018-12-10 | VOIP | Procurement Lead | 8h | 8h | 120 | 120 | 120 |
| 8 | 2.1.2 | Selection of qualified supplier | 1d | 2018-12-11 A | 2018-12-14 | 7 | 90% | 0.1d | 2018-12-11 | 2018-12-11 | 1d | 0d |  |  |  | Procurement Lead | 8h | 7.2h | 120 | 120 | 108 |
| 9 | 2.1.3 | Purchase of the hardware | 6d | 2018-12-14 | 2018-12-24 | 8 |  |  | 2018-12-12 | 2018-12-12 | 1d | 0d |  | start no earlier than 2018-12-13 |  | Procurement Lead | 48h |  | 720 | 120 |  |
| 10 | 2.2 | **Software components** | 6.1d | 2018-12-11 A | 2018-12-19 |  | 33% | 4.07d | 2018-12-11 | 2018-12-14 | 4d | 22d |  |  |  |  | 24h | 8h | 600 | 600 | 200 |
| 11 | 2.2.1 | Request for proposal forms | 1d | 2018-12-11 A | 2018-12-11 A | 7 | 100% |  | 2018-12-11 | 2018-12-11 | 1d |  |  |  |  | System Analyst | 8h | 8h | 200 | 200 | 200 |
| 12 | 2.2.2 | Selection of qualified vendor | 1d | 2018-12-14 | 2018-12-17 | 8, 11 |  |  | 2018-12-12 | 2018-12-12 | 1d | 22d | 0d | start no earlier than 2018-12-13 |  | System Analyst | 8h |  | 200 | 200 |  |
| 13 | 2.2.3 | Purchase of the software | 1d | 2018-12-18 | 2018-12-19 | 12FS+1d |  |  | 2018-12-14 | 2018-12-14 | 1d | 22d |  |  |  | System Analyst | 8h |  | 200 | 200 |  |
| 14 | 3 | **Hardware installation** | 6d | 2018-12-24 | 2019-01-01 |  |  |  | 2018-12-13 | 2018-12-20 | 6d | 0d |  |  |  |  | 48h |  | 824 | 824 |  |
| 15 | 3.1 | Site preparation | 2d | 2018-12-24 | 2018-12-26 | 9 |  |  | 2018-12-13 | 2018-12-14 | 2d | 0d |  |  |  | System Admin | 16h |  | 320 | 320 |  |
| 16 | 3.2 | Rack PC allocation | 1d | 2018-12-26 | 2018-12-27 | 15 |  |  | 2018-12-17 | 2018-12-17 | 1d | 0d |  |  |  | System Admin | 8h |  | 160 | 160 |  |
| 17 | 3.3 | Local Area Network and wireless LAN installation | 2d | 2018-12-27 | 2018-12-31 | 16 |  |  | 2018-12-18 | 2018-12-19 | 2d | 0d |  |  |  | Network Technician | 16h |  | 240 | 240 |  |
| 18 | 3.4 | Hardware setup testing | 1d | 2018-12-31 | 2019-01-01 | 16, 17 |  |  | 2018-12-20 | 2018-12-20 | 1d | 0d |  |  |  | Software Tester | 8h |  | 104 | 104 |  |
| 19 | 4 | **Software Installation and Implementation** | 9d | 2019-01-01 | 2019-01-14 |  |  |  | 2018-12-21 | 2019-01-02 | 9d | 0d |  |  |  |  | 96h |  | 2,056 | 2,056 |  |
| 20 | 4.1 | Implementation plan | 2d | 2019-01-01 | 2019-01-03 | 18 |  |  | 2018-12-21 | 2018-12-24 | 2d | 0d |  |  |  | System Analyst | 16h |  | 400 | 400 |  |
| 21 | 4.2 | Window Notification Maintenance | 2d | 2019-01-03 | 2019-01-07 | 18 |  |  | 2018-12-25 | 2018-12-26 | 2d | 3d | 0d |  |  | System Analyst | 16h |  | 400 | 400 |  |
| 22 | 4.3 | Database migration | 1d | 2019-01-07 | 2019-01-08 | 21 |  |  | 2018-12-27 | 2018-12-27 | 1d | 3d |  |  |  | Database Manager | 8h |  | 144 | 144 |  |
| 23 | 4.4 | **Testing** | 3d | 2019-01-03 | 2019-01-08 |  |  |  | 2018-12-25 | 2018-12-27 | 3d | 0d |  |  |  |  | 24h |  | 312 | 312 |  |
| 24 | 4.4.1 | Test Pilot Depolyment | 2d | 2019-01-03 | 2019-01-07 | 20 |  |  | 2018-12-25 | 2018-12-26 | 2d | 0d |  |  |  | Software Tester | 16h |  | 208 | 208 |  |
| 25 | 4.4.2 | Pilot Deployment Complete | 1d | 2019-01-07 | 2019-01-08 | 24 |  |  | 2018-12-27 | 2018-12-27 | 1d | 0d |  |  |  | Software Tester | 8h |  | 104 | 104 |  |

Notes:
- 13: Check the compatibility of the software with the purchsed hardware. If the software is compatible, proceed with the purchase. A one day lag was added in case an alternate software needs to be selected and purchased.
- 22: Validate the migration

| ID | WBS | Task | Duration | Start | Finish | Predecessors | Baseline start | Baseline finish | Baseline duration | Total slack | Resources | Work | Cost | Baseline cost |
| --- | --- | --- | --- | --- | --- | --- | --- | --- | --- | --- | --- | --- | --- | --- |
| 26 | 4.5 | **Contingency plan** | 4d | 2019-01-08 | 2019-01-14 |  | 2018-12-28 | 2019-01-02 | 4d | 0d |  | 32h | 800 | 800 |
| 27 | 4.5.1 | Create a risk management plan | 1d | 2019-01-08 | 2019-01-09 | 25 | 2018-12-28 | 2018-12-28 | 1d | 0d | System Analyst | 8h | 200 | 200 |
| 28 | 4.5.2 | Implementation and Test Backup | 2d | 2019-01-09 | 2019-01-11 | 27 | 2018-12-31 | 2019-01-01 | 2d | 0d | System Analyst | 16h | 400 | 400 |
| 29 | 4.5.3 | Implementation Performance Tuning & Monitoring | 1d | 2019-01-11 | 2019-01-14 | 22, 28 | 2019-01-02 | 2019-01-02 | 1d | 0d | System Analyst | 8h | 200 | 200 |
| 30 | 5 | **Complete Software Installation** | 8d | 2019-01-08 | 2019-01-18 |  | 2018-12-28 | 2019-01-08 | 8d | 0d |  | 40h | 640 | 640 |
| 31 | 5.1 | Switch Over of applications | 1d | 2019-01-08 | 2019-01-09 | 25 | 2018-12-28 | 2018-12-28 | 1d | 3d | System Admin | 8h | 160 | 160 |
| 32 | 5.2 | Setup System Maintenance | 2d | 2019-01-14 | 2019-01-16 | 31, 29 | 2019-01-03 | 2019-01-04 | 2d | 0d | System Admin | 16h | 320 | 320 |
| 33 | 5.3 | Documentation | 1d | 2019-01-16 | 2019-01-17 | 32 | 2019-01-07 | 2019-01-07 | 1d | 0d | Tech Support | 8h | 80 | 80 |
| 34 | 5.4 | Customer notification | 1d | 2019-01-17 | 2019-01-18 | 33 | 2019-01-08 | 2019-01-08 | 1d | 0d | Tech Support | 8h | 80 | 80 |
