# Migration of ServiceNow instance from OnPremise to Cloud

Schedule from MS Project, 2018-12-03 to 2019-08-02, status date 2018-12-17, 7.5 hours a day, costs in $, A marks actual dates.
PASBO

## Calendars

- PASBO: Mon-Fri 08:00-12:00, 13:00-17:00; Sat-Sun off.

## Resources

| Resource | Rate | Notes |
| --- | --- | --- |
| Mohammed Mirza | 85 | PM |
| Brent Garner | 70 | Stakeholder |
| Steven Acott | 75 | Testing Team |
| Ashok Kumar | 80 | Technical Lead |
| Rahul Sharma | 75 | Cloud Team |
| Arvind Khanna | 70 | Security Team |
| James Acott | 75 | DBA Team |
| Russel Riley | 70 | Integration |
| License |  |  |
| Servers | 1000 |  |

## Schedule

| ID | WBS | Task | Type | Duration | Start | Finish | Predecessors | Complete | Remaining | Baseline start | Baseline finish | Baseline duration | Total slack | Free slack | Constraint | Resources | Work | Actual work | Cost | Baseline cost | Actual cost |
| --- | --- | --- | --- | --- | --- | --- | --- | --- | --- | --- | --- | --- | --- | --- | --- | --- | --- | --- | --- | --- | --- |
| 1 | 1 | **Planning** |  | 23.77d | 2018-12-03 A | 2019-01-02 |  | 36% | 15.27d | 2018-12-03 | 2019-02-04 | 49.07d | 162.09d |  |  |  | 100.73h | 17h | 8,264.72 | 23,923.21 | 1,445 |
| 2 | 1.1 | **Project Management Plan** |  | 15.64d | 2018-12-03 A | 2018-12-21 |  | 72% | 4.3d | 2018-12-03 | 2019-01-03 | 25.6d | 170.23d |  |  |  | 22.73h | 17h | 1,851.51 | 16,585 | 1,445 |
| 3 | 1.1.1 | Scope |  | 6d | 2018-12-03 A | 2018-12-10 A |  | 100% |  | 2018-12-03 | 2018-12-10 | 6d |  |  |  | Mohammed Mirza [24%] | 9h | 9h | 765 | 765 | 765 |
| 4 | 1.1.1.1 | Activity Sequencing |  | 8.93d | 2018-12-10 A | 2018-12-20 | 3 | 60% | 3.6d | 2018-12-10 | 2018-12-18 | 6d | 170.23d | 0d |  | Mohammed Mirza; Ashok Kumar; Brent Garner | 8h | 8h | 680 | 765 | 680 |
| 5 | 1.1.1.1.3 | Calculate Durations |  | 0.7d | 2018-12-21 | 2018-12-21 | 4 |  |  | 2018-12-18 | 2018-12-25 | 6d | 170.23d |  | start no earlier than 2018-12-20 | Mohammed Mirza; Ashok Kumar; Brent Garner | 5.73h |  | 406.51 | 765 |  |
| 6 | 1.1.1.1.2 | Set Milestones | milestone | 0d | 2018-12-17 A | 2018-12-17 A | 5FF, 4 | 100% |  | 2018-12-18 | 2018-12-27 | 8d |  |  |  | Mohammed Mirza [23.3%] |  |  |  | 850 |  |
| 7 | 1.1.1.1.1 | **Stakeholders** |  | 1d | 2018-12-18 | 2018-12-18 |  |  |  | 2019-01-07 | 2019-01-08 | 2d | 0d |  |  |  | 5h |  | 425 | 340 |  |
| 8 | 1.1.1.3 | Finalize the Stakeholders |  | 1d | 2018-12-18 | 2018-12-18 | 6 |  |  | 2019-01-07 | 2019-01-08 | 2d | 0d |  |  | Mohammed Mirza [66.7%] | 5h |  | 425 | 340 |  |
| 9 | 1.1.1.4 | **Project Team** |  | 4d | 2018-12-18 | 2018-12-24 |  |  |  | 2019-01-09 | 2019-01-14 | 4d | 169.13d |  |  |  | 4h |  | 330 | 660 |  |
| 10 | 1.1.1.5 | Finalize the Project Team |  | 4d | 2018-12-18 | 2018-12-24 | 8 |  |  | 2019-01-09 | 2019-01-14 | 4d | 169.13d |  |  | Mohammed Mirza [80%]; Ashok Kumar [80%] | 4h |  | 330 | 660 |  |
| 11 | 1.1.2 | **Resource Plan** |  | 2d | 2018-12-18 | 2018-12-20 |  |  |  | 2019-01-15 | 2019-01-16 | 2d | 0d |  |  |  | 11h |  | 935 | 935 |  |
| 12 | 1.1.2.1 | Plan all the resources needed |  | 2d | 2018-12-18 | 2018-12-20 | 8 |  |  | 2019-01-15 | 2019-01-16 | 2d | 0d |  |  | Mohammed Mirza [73.3%] | 11h |  | 935 | 935 |  |
| 13 | 1.1.3 | **Preliminary Analysis** |  | 2.47d | 2018-12-20 | 2018-12-25 |  |  |  | 2019-01-17 | 2019-01-22 | 4.27d | 0d |  |  |  | 17h |  | 1,370 | 2,050 |  |
| 14 | 1.1.3.1 | Preliminary Analysis documentation |  | 1.8d | 2018-12-20 | 2018-12-24 | 12 |  |  | 2019-01-17 | 2019-01-21 | 3d | 0d |  |  | Mohammed Mirza [88.9%] | 12h |  | 1,020 | 1,700 |  |
| 15 | 1.1.4 | Get Stakeholder Signoff |  | 0.67d | 2018-12-24 | 2018-12-25 | 14 |  |  | 2019-01-21 | 2019-01-22 | 0.67d | 0d |  |  | Arvind Khanna | 5h |  | 350 | 350 |  |
| 16 | 1.1.4.1 | **Configuration list** |  | 3d | 2018-12-25 | 2018-12-27 |  |  |  | 2019-01-23 | 2019-01-28 | 4d | 0d |  |  |  | 15h |  | 1,207.5 | 1,207.5 |  |
| 17 | 1.1.6 | List all different configurations to make |  | 2d | 2018-12-25 | 2018-12-26 | 15 |  |  | 2019-01-23 | 2019-01-24 | 2d | 0d |  |  | Mohammed Mirza [80%]; Ashok Kumar [80%] | 12h |  | 990 | 990 |  |
| 18 | 1.2 | Get Stakeholder Signoff |  | 1d | 2018-12-27 | 2018-12-27 | 17 |  |  | 2019-01-25 | 2019-01-25 | 0.33d | 0d |  |  | Mohammed Mirza [20%]; Brent Garner | 3h |  | 217.5 | 217.5 |  |
| 19 | 1.6.3 | Get Configuration List | milestone | 0d | 2018-12-27 | 2018-12-27 | 18 |  |  |  |  |  | 0d |  |  | Mohammed Mirza |  |  |  |  |  |
| 20 | 1.2.1 | **Budget** |  | 3.57d | 2018-12-27 | 2019-01-02 |  |  |  | 2019-01-29 | 2019-02-04 | 5.33d | 0d |  |  |  | 26h |  | 2,145.71 | 2,145.71 |  |
| 21 | 1.2.1.1 | Analyze and draft the estimating cost |  | 3d | 2018-12-27 | 2019-01-01 | 19 |  |  | 2019-01-29 | 2019-01-31 | 3d | 0d |  |  | Mohammed Mirza [88.9%] | 20h |  | 1,700 | 1,700 |  |
| 22 | 1.2.1.2 | Stakeholder Signoff |  | 0.57d | 2019-01-01 | 2019-01-02 | 21 |  |  | 2019-02-01 | 2019-02-01 | 0.57d | 0d |  |  | Mohammed Mirza [40%]; Brent Garner | 6h |  | 445.71 | 445.71 |  |
| 23 | 1.7.3 | Get Final Budget | milestone | 0d | 2019-01-02 | 2019-01-02 | 22 |  |  | 2019-02-01 | 2019-02-01 | 0d | 0d |  |  | Mohammed Mirza |  |  |  |  |  |
| 24 | 1.2.2 | **Initiating** |  | 30.68d? | 2019-01-02 | 2019-02-12 |  |  |  | 2019-02-04 | 2019-04-05 | 47.07d? | 0d |  |  |  | 245h |  | 19,266.62 | 19,542.66 |  |
| 25 | 1.2.2.1 | **Functional Requirements** |  | 17.6d? | 2019-01-02 | 2019-01-24 |  |  |  | 2019-02-04 | 2019-02-28 | 19.47d? | 0d |  |  |  | 103h |  | 8,455 | 8,455 |  |
| 26 | 1.2.2.2 | Create Functional requirements list |  | 16d | 2019-01-02 | 2019-01-23 | 23 |  |  | 2019-02-04 | 2019-02-25 | 16d | 0d |  |  | Mohammed Mirza [75%]; Ashok Kumar [75%] | 90h |  | 7,425 | 7,425 |  |
| 27 | 1.2.3 | Review with Process team |  | 1.6d | 2019-01-23 | 2019-01-24 | 26 |  |  | 2019-02-25 | 2019-02-27 | 1.6d | 0d |  |  | Mohammed Mirza [66.7%] | 8h |  | 680 | 680 |  |
| 28 | 1.2.3.1 | Stakeholder Signoff |  | 0.67d? | 2019-01-24 | 2019-01-24 | 26, 27FF |  |  | 2019-02-28 | 2019-02-28 | 0.67d? | 0d |  |  | Brent Garner | 5h |  | 350 | 350 |  |

Notes:
- 22: This has to be done on or before this date as the requirements need to be started on 2/4/2019 due to the availablity of managers.
- 28: This has to be done on same date due to the availablity of Stakeholders

| ID | WBS | Task | Type | Duration | Start | Finish | Predecessors | Baseline start | Baseline finish | Baseline duration | Total slack | Resources | Work | Cost | Baseline cost |
| --- | --- | --- | --- | --- | --- | --- | --- | --- | --- | --- | --- | --- | --- | --- | --- |
| 29 | 1.3 | **Technical Requirements** |  | 3.29d | 2019-01-24 | 2019-01-29 |  | 2019-03-01 | 2019-03-15 | 11.6d | 0d |  | 54h | 3,950 | 4,089.04 |
| 30 | 1.3.5 | Create Technical requirements list |  | 2.67d | 2019-01-24 | 2019-01-29 | 28 | 2019-03-01 | 2019-03-04 | 1.93d | 0d | Rahul Sharma; Arvind Khanna | 40h | 2,900 | 3,039.04 |
| 31 | 1.3.5.1 | Review with cloud technical teams |  | 0.62d | 2019-01-29 | 2019-01-29 | 30 | 2019-03-04 | 2019-03-05 | 0.62d | 0d | Ashok Kumar; Rahul Sharma; Arvind Khanna | 14h | 1,050 | 1,050 |
| 32 | 2.2.3 | Have Technical Requirements | milestone | 0d | 2019-01-29 | 2019-01-29 | 31 | 2019-03-04 | 2019-03-04 | 0d | 0d | Mohammed Mirza |  |  |  |
| 33 | 1.3.5.1.1 | **Plan data transfer strategy** |  | 2.67d | 2019-01-29 | 2019-02-01 |  | 2019-03-15 | 2019-03-21 | 5.33d | 0d |  | 19.5h | 1,417.5 | 1,999.87 |
| 34 | 1.3.5.2 | Discuss and shortlist different Encryption methods |  | 1d | 2019-01-29 | 2019-01-30 | 32 | 2019-03-15 | 2019-03-18 | 2d | 0d | Arvind Khanna; Ashok Kumar | 7.5h | 562.5 | 924 |
| 35 | 1.3.5.2.1 | Review the shortlisted methods with security team and finalize |  | 0.67d | 2019-01-30 | 2019-01-31 | 34 | 2019-03-18 | 2019-03-19 | 0.67d | 0d | Arvind Khanna; Brent Garner | 10h | 700 | 775 |
| 36 | 1.3.6 | Get Stakeholder signoff |  | 1d | 2019-01-31 | 2019-02-01 | 34, 35 | 2019-03-21 | 2019-03-21 | 0.35d | 0d | Mohammed Mirza [53.3%]; Brent Garner | 2h | 155 | 300.87 |
| 37 | 1.3.6.1 | **Plan integrations** |  | 2.72d | 2019-02-01 | 2019-02-05 |  | 2019-03-22 | 2019-03-28 | 5.33d? | 0d |  | 29h | 2,283.5 | 2,687.5 |
| 38 | 1.3.6.1.2 | Analyze Current integrations setup with different teams |  | 1d | 2019-02-01 | 2019-02-04 | 36 | 2019-03-22 | 2019-03-25 | 2d | 0d | Mohammed Mirza; Ashok Kumar; Rahul Sharma; Arvind Khanna | 11h | 852.5 | 697.5 |
| 39 | 1.3.6.4 | Review the compatiblity with cloud teams |  | 0.6d | 2019-02-04 | 2019-02-04 | 38 | 2019-03-25 | 2019-03-26 | 1d? | 136.94d | Mohammed Mirza; Rahul Sharma | 9h | 720 | 1,200 |
| 40 | 2.4.3 | Prepare testing plan |  | 0.72d | 2019-02-05 | 2019-02-05 | 38FS+1d | 2019-03-26 | 2019-03-27 | 0.8d | 0d | Mohammed Mirza [66.7%]; Steven Acott | 9h | 711 | 790 |
| 41 | 1.3.6.4.3 | **Security** |  | 2d | 2019-02-05 | 2019-02-07 |  | 2019-03-29 | 2019-04-02 | 3.2d | 0d |  | 21.5h | 1,630.62 | 2,311.25 |
| 42 | 1.3.7 | Discuss and finalize APIs to match company’s requirements |  | 1d | 2019-02-05 | 2019-02-06 | 40 | 2019-03-29 | 2019-04-01 | 2d | 0d | Mohammed Mirza [60%]; Russel Riley | 9h | 680.62 | 1,361.25 |
| 43 | 1.3.7.9 | Get Information Technology Security's Signoff |  | 1d | 2019-02-06 | 2019-02-07 | 42 | 2019-04-01 | 2019-04-02 | 1d | 0d | Mohammed Mirza [66.7%]; Russel Riley | 12.5h | 950 | 950 |
| 44 | 2.5.3 | Get Security Signoff | milestone | 0d | 2019-02-07 | 2019-02-07 | 43 | 2019-04-02 | 2019-04-02 | 0d | 0d | Mohammed Mirza |  |  |  |
| 45 | 1.3.7.9.5 | **Environment Strategies** |  | 2.4d | 2019-02-07 | 2019-02-12 |  | 2019-04-03 | 2019-04-05 | 3d | 0d |  | 18h | 1,530 |  |
| 46 | 1.3.7.10 | DEV,TEST,TRAIN Strategy |  | 2.4d | 2019-02-07 | 2019-02-12 | 44 | 2019-04-03 | 2019-04-05 | 3d | 0d | Mohammed Mirza | 18h | 1,530 |  |
| 47 | 1.3.8 | **Configuring** |  | 24.31d | 2019-02-12 | 2019-03-14 |  | 2019-04-08 | 2019-05-21 | 34d? | 0d |  | 107h | 9,262.58 | 9,682.58 |
| 48 | 1.4 | **Request for Cloud instances** |  | 1.8d | 2019-02-12 | 2019-02-13 |  | 2019-04-08 | 2019-04-09 | 2.13d | 0d |  | 12h | 900 | 900 |
| 49 | 1.4.1 | Submit ServiceNow HI ticket for Cloud instances by Lead |  | 0.8d | 2019-02-12 | 2019-02-12 | 46 | 2019-04-08 | 2019-04-08 | 0.8d | 0d | Ashok Kumar | 6h | 480 | 480 |
| 50 | 1.6 | Hi Ticket approval by Product owner |  | 1d | 2019-02-12 | 2019-02-13 | 49 | 2019-04-09 | 2019-04-09 | 1d | 0d | Brent Garner [80%]; License [0.1%] | 6h | 420 | 420 |
| 51 | 3.1.3 | Get Cloud Instance | milestone | 0d | 2019-02-13 | 2019-02-13 | 50 | 2019-04-09 | 2019-04-09 | 0d | 0d | Mohammed Mirza |  |  |  |
| 52 | 2 | **Upgrade the cloud instance to match On-Premise version** |  | 2d | 2019-02-13 | 2019-02-15 |  | 2019-04-10 | 2019-04-11 | 2d | 0d |  | 6h | 465 | 465 |
| 53 | 3.2.1 | Upgrade the cloud based application to match the version of on Premise version |  | 2d | 2019-02-13 | 2019-02-15 | 51 | 2019-04-10 | 2019-04-11 | 2d | 0d | Ashok Kumar [66.7%]; Rahul Sharma [66.7%] | 6h | 465 | 465 |

Notes:
- 36: Need to complete this before integration planning 2.1.4
- 50: This has to be done on or before this date due to the additional resources booked for cloning task on 04/12/2019

| ID | WBS | Task | Type | Duration | Start | Finish | Predecessors | Baseline start | Baseline finish | Baseline duration | Total slack | Free slack | Resources | Work | Cost | Baseline cost |
| --- | --- | --- | --- | --- | --- | --- | --- | --- | --- | --- | --- | --- | --- | --- | --- | --- |
| 54 | 2.6 | **Cloning** |  | 3.46d | 2019-02-15 | 2019-02-20 |  | 2019-04-12 | 2019-04-18 | 5.33d | 0d |  |  | 19h | 1,468.91 | 1,468.91 |
| 55 | 2.7 | Take a Clone from DEV database |  | 1.11d | 2019-02-15 | 2019-02-18 | 53 | 2019-04-12 | 2019-04-15 | 1.11d | 0d |  | James Acott [60%] | 5h | 375 | 375 |
| 56 | 2.7.3 | Remove all the sensitive data |  | 2d | 2019-02-18 | 2019-02-20 | 55 | 2019-04-15 | 2019-04-16 | 2d | 0d |  | Ashok Kumar [66.7%] | 10h | 800 | 800 |
| 57 | 2.7.4 | Lock User Accounts except admin users |  | 0.35d | 2019-02-20 | 2019-02-20 | 56 | 2019-04-16 | 2019-04-17 | 0.35d | 0d |  | Ashok Kumar [53.3%]; Arvind Khanna | 4h | 293.91 | 293.91 |
| 58 | 2.1 | **Data Transfer** |  | 3.95d | 2019-02-20 | 2019-02-26 |  | 2019-04-19 | 2019-04-26 | 6d | 0d |  |  | 17h | 1,311.88 | 1,311.88 |
| 59 | 2.1.1 | Encrypt the Cloned database |  | 0.75d | 2019-02-20 | 2019-02-21 | 57 | 2019-04-19 | 2019-04-19 | 0.75d | 0d |  | Ashok Kumar [60%]; James Acott | 9h | 691.88 | 691.88 |
| 60 | 2.1.1.1 | Send it to Cloud technical team |  | 3.2d | 2019-02-21 | 2019-02-26 | 59 | 2019-04-19 | 2019-04-24 | 3.2d | 0d |  | Ashok Kumar [33.3%]; Rahul Sharma [33.3%] | 8h | 620 | 620 |
| 61 | 2.1.1.2 | **Cloud Database Setup** |  | 2d | 2019-02-26 | 2019-02-28 |  | 2019-04-26 | 2019-04-29 | 2d? | 0d |  |  |  | 1,000 | 1,000 |
| 62 | 3.5.1 | Setup the cloud based database server |  | 2d | 2019-02-26 | 2019-02-28 | 60 | 2019-04-26 | 2019-04-29 | 2d | 0d |  | Servers |  | 1,000 | 1,000 |
| 63 | 2.1.2 | **Cloud Database Failover Setup** |  | 2d | 2019-02-28 | 2019-03-04 |  | 2019-04-30 | 2019-05-01 | 2d? | 0d |  |  | 8h | 613.33 | 613.33 |
| 64 | 3.6.1 | Cloud Database Failover Setup |  | 2d | 2019-02-28 | 2019-03-04 | 62 | 2019-04-30 | 2019-05-01 | 2d | 0d |  | Ashok Kumar [53.3%]; James Acott [53.3%]; Rahul Sharma [53.3%] | 8h | 613.33 | 613.33 |
| 65 | 2.1.3 | **User accounts** |  | 3d | 2019-03-04 | 2019-03-07 |  | 2019-05-02 | 2019-05-06 | 3.2d | 0d |  |  | 12h | 940 | 940 |
| 66 | 2.2 | Unlock admin user accounts |  | 1d | 2019-03-04 | 2019-03-05 | 64 | 2019-05-02 | 2019-05-02 | 1d | 0d |  | Rahul Sharma [53.3%] | 4h | 300 | 300 |
| 67 | 2.2.1 | Setup the Single Sign On certificates |  | 2d | 2019-03-05 | 2019-03-07 | 66 | 2019-05-02 | 2019-05-06 | 2d | 0d |  | Ashok Kumar [53.3%] | 8h | 640 | 640 |
| 68 | 2.2.1.1 | **Integrations** |  | 3.5d | 2019-03-07 | 2019-03-12 |  | 2019-05-07 | 2019-05-13 | 5.33d | 0d |  |  | 21h | 1,603.46 | 2,023.46 |
| 69 | 2.2.2 | Register APIs |  | 1d | 2019-03-07 | 2019-03-08 | 67 | 2019-05-07 | 2019-05-07 | 1d | 1d | 0d | Ashok Kumar [80%] | 6h | 480 | 480 |
| 70 | 2.3 | Setup MID Servers |  | 2d | 2019-03-07 | 2019-03-08 | 67 | 2019-05-07 | 2019-05-08 | 2d | 0d |  | Russel Riley | 5h | 350 | 770 |
| 71 | 2.3.1 | Setup API Servers |  | 1d | 2019-03-08 | 2019-03-08 | 69 | 2019-05-07 | 2019-05-08 | 1d | 1d |  | Ashok Kumar [66.7%] | 5h | 400 | 400 |
| 72 | 2.3.2 | Point DEV integrations to Cloud(DEV) instance |  | 0.4d | 2019-03-11 | 2019-03-12 | 71, 70FS+1d | 2019-05-09 | 2019-05-10 | 0.4d | 0d |  | James Acott | 3h | 225 | 225 |
| 73 | 2.3.3 | Push data from integrated tools |  | 0.1d | 2019-03-12 | 2019-03-12 | 72 | 2019-05-10 | 2019-05-10 | 0.1d | 0d |  | Ashok Kumar [60%]; James Acott; Russel Riley | 2h | 148.46 | 148.46 |
| 74 | 2.5 | **Setup Cloud Support Team Direct access to the Instance** |  | 1d | 2019-03-12 | 2019-03-13 |  | 2019-05-14 | 2019-05-14 | 1d? | 0d |  |  | 4h | 320 | 320 |
| 75 | 3.9.1 | Setup Cloud Support Team Direct access to the Instance |  | 1d | 2019-03-12 | 2019-03-13 | 73 | 2019-05-14 | 2019-05-14 | 1d | 0d |  | Ashok Kumar [53.3%] | 4h | 320 | 320 |
| 76 | 2.5.2 | **Latest Update sets** |  | 1.6d | 2019-03-13 | 2019-03-14 |  | 2019-05-15 | 2019-05-16 | 2d | 0d |  |  | 8h | 640 | 640 |
| 77 | 2.5.3 | Deploy latest update sets |  | 1.6d | 2019-03-13 | 2019-03-14 | 75 | 2019-05-15 | 2019-05-16 | 1.6d | 0d |  | Ashok Kumar [66.7%] | 8h | 640 | 640 |
| 78 | 3.10.2 | Complete deploying all updates | milestone | 0d | 2019-03-14 | 2019-03-14 | 77 | 2019-05-16 | 2019-05-16 | 0d | 0d |  | Mohammed Mirza |  |  |  |

| ID | WBS | Task | Type | Duration | Start | Finish | Predecessors | Baseline start | Baseline finish | Baseline duration | Total slack | Free slack | Resources | Work | Cost | Baseline cost |
| --- | --- | --- | --- | --- | --- | --- | --- | --- | --- | --- | --- | --- | --- | --- | --- | --- |
| 79 | 3 | **Testing** |  | 35.61d? | 2019-03-14 | 2019-05-01 |  | 2019-05-17 | 2019-07-12 | 43.73d? | 0d |  |  | 203.24h | 15,735.45 | 19,860.45 |
| 80 | 3.1 | **Single Sign On** |  | 0.91d? | 2019-03-14 | 2019-03-15 |  | 2019-05-17 | 2019-05-17 | 1d? | 0d |  |  | 6h | 468.05 | 468.05 |
| 81 | 3.1.1 | Test Single Sign On |  | 0.91d? | 2019-03-14 | 2019-03-15 | 78 | 2019-05-17 | 2019-05-17 | 0.91d? | 0d |  | Ashok Kumar [53%]; Steven Acott [53%] | 6h | 468.05 | 468.05 |
| 82 | 3.1.1.1 | **Access to the instance** |  | 2d | 2019-03-15 | 2019-03-19 |  | 2019-05-20 | 2019-05-21 | 2.13d | 0d |  |  | 11.97h | 938.06 | 938.06 |
| 83 | 3.1.1.2 | Test In network access |  | 1d | 2019-03-15 | 2019-03-18 | 81 | 2019-05-20 | 2019-05-20 | 1d | 0d |  | Ashok Kumar [53%]; Steven Acott [53%]; Rahul Sharma [53%] | 3.98h | 308.06 | 308.06 |
| 84 | 3.1.1.3 | Test outside the network access |  | 1d | 2019-03-15 | 2019-03-18 | 81 | 2019-05-20 | 2019-05-20 | 1d | 0d |  | Ashok Kumar [53.3%]; Steven Acott [53%] | 4h | 320 | 320 |
| 85 | 3.1.1.4 | Test support team access |  | 1d | 2019-03-18 | 2019-03-19 | 83, 84 | 2019-05-20 | 2019-05-21 | 1d | 0d |  | Ashok Kumar [53.3%]; Steven Acott [53.3%] | 4h | 310 | 310 |
| 86 | 3.2 | **Data** |  | 2d | 2019-03-19 | 2019-03-21 |  | 2019-05-22 | 2019-05-23 | 2d | 0d |  |  | 15h | 1,162.5 | 1,162.5 |
| 87 | 3.2.1 | Compare the data with PROD |  | 2d | 2019-03-19 | 2019-03-21 | 85 | 2019-05-22 | 2019-05-23 | 2d | 0d |  | Ashok Kumar; James Acott | 15h | 1,162.5 | 1,162.5 |
| 88 | 3.2.2 | **Service Portal** |  | 21.06d | 2019-03-21 | 2019-04-18 |  | 2019-05-24 | 2019-06-20 | 21.33d | 0d |  |  | 78h | 5,850 | 6,975 |
| 89 | 3.2.2.1 | Test Catalog Items |  | 8.53d | 2019-03-21 | 2019-04-02 | 87 | 2019-05-24 | 2019-06-04 | 8.53d | 0d |  | Steven Acott [62.5%] | 30h | 2,250 | 3,000 |
| 90 | 3.2.2.2 | Test Order guides |  | 8.53d | 2019-04-02 | 2019-04-12 | 89 | 2019-06-04 | 2019-06-14 | 8.53d | 0d |  | Steven Acott [23.4%] | 15h | 1,125 | 1,125 |
| 91 | 3.2.2.3 | Test Record Producers |  | 5.33d | 2019-03-21 | 2019-03-28 | 87 | 2019-05-24 | 2019-05-30 | 5.33d | 11.73d |  | Steven Acott [37.5%] | 10h | 750 | 1,125 |
| 92 | 3.2.2.4 | Test Knowledge Module |  | 2d | 2019-04-12 | 2019-04-16 | 91, 89, 90 | 2019-06-14 | 2019-06-18 | 2d | 0d |  | Steven Acott [53.3%] | 8h | 600 | 600 |
| 93 | 3.2.2.7 | Test Problem Module |  | 2d | 2019-04-16 | 2019-04-18 | 92 | 2019-06-18 | 2019-06-20 | 2d | 0d |  | Steven Acott | 15h | 1,125 | 1,125 |
| 94 | 3.2.2.5 | **Integrations** |  | 1.64d | 2019-04-18 | 2019-04-19 |  | 2019-06-21 | 2019-06-25 | 3.2d | 0d |  |  | 13h | 959.15 | 959.15 |
| 95 | 3.2.2.6 | Check data sync with Beeline |  | 0.89d | 2019-04-18 | 2019-04-19 | 93 | 2019-06-21 | 2019-06-21 | 0.89d | 0d |  | Ashok Kumar [40%]; Russel Riley | 6h | 446.67 | 446.67 |
| 96 | 3.3 | Check data sync with LDAP |  | 0.46d | 2019-04-19 | 2019-04-19 | 95 | 2019-06-21 | 2019-06-24 | 0.46d | 0d |  | Ashok Kumar [40%]; Russel Riley | 4h | 293.91 | 293.91 |
| 97 | 3.3.1 | Check data sync with CIAM |  | 0.29d | 2019-04-19 | 2019-04-19 | 96 | 2019-06-24 | 2019-06-24 | 0.29d | 0d |  | Ashok Kumar [40%]; Russel Riley | 3h | 218.57 | 218.57 |
| 98 | 3.3.1.1 | **User Acceptance Testing** |  | 8d | 2019-04-19 | 2019-05-01 |  | 2019-06-26 | 2019-07-19 | 19.2d? | 0d |  |  | 79.27h | 6,357.69 | 9,357.69 |
| 99 | 3.3.1.2 | Set User Accounts |  | 0.8d | 2019-04-19 | 2019-04-22 | 97 | 2019-06-26 | 2019-06-26 | 0.4d | 2.2d |  | Rahul Sharma | 6h | 450 | 450 |
| 100 | 3.3.2 | Set Test Plans |  | 2d | 2019-04-22 | 2019-04-24 | 97FS+1d | 2019-06-26 | 2019-06-27 | 2d | 0d |  | Mohammed Mirza; Ashok Kumar | 30h | 2,475 | 2,475 |
| 101 | 4.6.3 | UAT Testing |  | 5d | 2019-04-24 | 2019-05-01 | 99, 100 | 2019-06-27 | 2019-07-11 | 10d? | 0d |  | Ashok Kumar | 37.5h | 3,000 | 6,000 |
| 102 | 3.3.2.1 | UAT SignOFF |  | 1d | 2019-04-24 | 2019-04-25 | 100 | 2019-07-10 | 2019-07-11 | 1d | 4d | 0d | Steven Acott [76.9%] | 5.77h | 432.69 | 432.69 |
| 103 | 4.6.5 | Complete UAT | milestone | 0d | 2019-04-25 | 2019-04-25 | 102 | 2019-07-11 | 2019-07-11 | 0d | 4d |  | Mohammed Mirza |  |  |  |

| ID | WBS | Task | Type | Duration | Start | Finish | Predecessors | Baseline start | Baseline finish | Baseline duration | Total slack | Resources | Work | Cost | Baseline cost |
| --- | --- | --- | --- | --- | --- | --- | --- | --- | --- | --- | --- | --- | --- | --- | --- |
| 104 | 3.3.2.2 | **Deployment** |  | 20.5d | 2019-05-01 | 2019-05-28 |  | 2019-07-22 | 2019-08-26 | 27.73d? | 0d |  | 159h | 12,085 | 12,085 |
| 105 | 3.4 | **PROD Clone** |  | 4d | 2019-05-01 | 2019-05-06 |  | 2019-07-22 | 2019-07-26 | 5.33d | 0d |  | 25h | 1,875 | 1,875 |
| 106 | 3.4.1 | Make Prod Clone |  | 4d | 2019-05-01 | 2019-05-06 | 101, 103 | 2019-07-22 | 2019-07-25 | 4d | 0d | James Acott [83.3%] | 25h | 1,875 | 1,875 |
| 107 | 3.4.2 | **Encrypt** |  | 1.5d | 2019-05-06 | 2019-05-08 |  | 2019-07-29 | 2019-07-31 | 3d | 0d |  | 18h | 1,395 | 1,395 |
| 108 | 3.4.3 | Encrypt the PROD Clone |  | 1.5d | 2019-05-06 | 2019-05-08 | 106 | 2019-07-29 | 2019-07-30 | 1.5d | 0d | Ashok Kumar [80%]; James Acott [80%] | 18h | 1,395 | 1,395 |
| 109 | 3.4.4 | **Data Transfer** |  | 3d | 2019-05-08 | 2019-05-13 |  | 2019-07-29 | 2019-07-31 | 3d | 0d |  | 15h | 1,200 | 1,200 |
| 110 | 3.4.5 | Send Data to Cloud team |  | 3d | 2019-05-08 | 2019-05-13 | 108 | 2019-07-30 | 2019-08-02 | 3d | 0d | Ashok Kumar [66.7%] | 15h | 1,200 | 1,200 |
| 111 | 3.4.6 | **Setup PROD in cloud** |  | 2d | 2019-05-13 | 2019-05-15 |  | 2019-08-01 | 2019-08-02 | 2d | 0d |  | 11h | 880 | 880 |
| 112 | 3.6 | Update themes, Logos, Images |  | 2d | 2019-05-13 | 2019-05-15 | 110 | 2019-08-02 | 2019-08-06 | 2d | 0d | Ashok Kumar [73.3%] | 11h | 880 | 880 |
| 113 | 3.7 | **Setup SSO** |  | 3d | 2019-05-15 | 2019-05-17 |  | 2019-08-05 | 2019-08-07 | 3d | 0d |  | 63h | 4,635 | 4,635 |
| 114 | 4 | Update Certificates for SSO as received from security team |  | 3d | 2019-05-15 | 2019-05-17 | 112 | 2019-08-06 | 2019-08-08 | 3d | 0d | Russel Riley [80%]; Arvind Khanna; Ashok Kumar | 63h | 4,635 | 4,635 |
| 115 | 4.1 | **Setup APIs** |  | 2d | 2019-05-17 | 2019-05-21 |  | 2019-08-08 | 2019-08-09 | 2d | 0d |  | 10h | 750 | 750 |
| 116 | 4.1.1 | Update the URLs in all the APIs with cloud URL |  | 2d | 2019-05-17 | 2019-05-21 | 114 | 2019-08-08 | 2019-08-12 | 2d | 0d | Ashok Kumar [66.7%]; Russel Riley [66.7%] | 10h | 750 | 750 |
| 117 | 4.2 | **Setup Integrations** |  | 2d | 2019-05-21 | 2019-05-23 |  | 2019-08-12 | 2019-08-13 | 2d | 0d |  | 6h | 480 | 480 |
| 118 | 4.2.1 | Start the Scheduled job to load data |  | 2d | 2019-05-21 | 2019-05-23 | 116 | 2019-08-12 | 2019-08-13 | 1.2d | 0d | Ashok Kumar [66.7%] | 6h | 480 | 480 |
| 119 | 4.2.2 | **Deploy Fixes** |  | 2d | 2019-05-23 | 2019-05-27 |  | 2019-08-14 | 2019-08-15 | 2d | 0d |  | 9h | 720 | 720 |
| 120 | 4.3 | Commit the latest update sets |  | 2d | 2019-05-23 | 2019-05-27 | 118 | 2019-08-14 | 2019-08-15 | 1.8d | 0d | Ashok Kumar [66.7%] | 9h | 720 | 720 |
| 121 | 4.3.1 | **Switch current traffic to Cloud** |  | 1d | 2019-05-27 | 2019-05-28 |  | 2019-08-16 | 2019-08-22 | 5.33d? | 0d |  | 2h | 150 | 150 |
| 122 | 4.3.2 | Update the Load Balancers to point towards Cloud instance |  | 1d | 2019-05-27 | 2019-05-28 | 120 | 2019-08-16 | 2019-08-16 | 0.12d | 0d | James Acott [26.7%]; Russel Riley; Ashok Kumar | 2h | 150 | 150 |
| 123 | 5.9.2 | Complete Migration to Cloud | milestone | 0d | 2019-05-28 | 2019-05-28 | 122 |  |  |  | 0d | Mohammed Mirza |  |  |  |
| 124 | 6 | **Closing** |  | 51d | 2019-05-28 | 2019-08-02 |  | 2019-08-16 | 2019-09-11 | 20.27d? | 0d |  | 305h | 22,910 | 11,660 |
| 125 | 6.1 | Document lessons learned |  | 1d | 2019-05-28 | 2019-05-29 | 122, 123 | 2019-08-16 | 2019-08-16 | 0.4d | 0d | Ashok Kumar | 3h | 240 | 240 |
| 126 | 6.2 | Send out Communications |  | 0.27d | 2019-05-28 | 2019-05-28 | 122 | 2019-08-16 | 2019-08-19 | 1d? | 50.73d | Mohammed Mirza | 2h | 170 | 170 |
| 127 | 6.3 | Post Implementation Support |  | 50d | 2019-05-29 | 2019-08-02 | 125 | 2019-08-19 | 2019-09-11 | 19d | 0d | Rahul Sharma; James Acott | 300h | 22,500 | 11,250 |
