# New Employee 1-2

Schedule from MS Project, 2015-01-05 to 2015-01-06.
P8 LLC

## Calendars

- Standard: Mon-Fri 08:00-12:00, 13:00-17:00; Sat-Sun off.

## Resources

| Resource | Rate |
| --- | --- |
| DVD/TV Combo | 1.5 |
| Digital Camera | 6.25 |
| Laminating Machine | 5 |
| Laptop Computer | 12.5 |
| Large Conference Room | 25 |
| Cathan Cook | 25 |
| Karen Berg | 15 |
| Garth Fort | 15 |
| Sidney Higa | 17.5 |
| Steve Masters | 18.5 |
| Kevin McDowell | 20 |
| Britta Simon | 21 |
| John Peoples | 19 |
| Jason Watters | 16.5 |

## Schedule

| ID | WBS | Task | Type | Duration | Start | Finish | Predecessors | Total slack |
| --- | --- | --- | --- | --- | --- | --- | --- | --- |
| 1 | 1 | **New Employee Orientation** |  | 1.81d | 2015-01-05 08:00 | 2015-01-06 15:30 |  | 0d |
| 2 | 1.1 | **Day 1** |  | 1d | 2015-01-05 08:00 | 2015-01-05 17:00 |  | 0d |
| 3 | 1.1.1 | Day 1 begins | milestone | 0d | 2015-01-05 08:00 | 2015-01-05 08:00 |  | 0d |
| 4 | 1.1.2 | Welcome and Introductions |  | 30min | 2015-01-05 08:00 | 2015-01-05 08:30 | 3 | 0d |
| 5 | 1.1.3 | Tour of main buildings |  | 1h | 2015-01-05 08:30 | 2015-01-05 09:30 | 4 | 0d |
| 6 | 1.1.4 | Fill out new hire paperwork |  | 45min | 2015-01-05 09:30 | 2015-01-05 10:15 | 5 | 0d |
| 7 | 1.1.5 | Watch marketing video |  | 90min | 2015-01-05 10:15 | 2015-01-05 11:45 | 6 | 0d |
| 8 | 1.1.6 | Lunch |  | 1h | 2015-01-05 11:45 | 2015-01-05 13:45 | 7 | 0d |
| 9 | 1.1.7 | Take picture for employee ID |  | 15min | 2015-01-05 13:45 | 2015-01-05 14:00 | 8 | 0d |
| 10 | 1.1.8 | Measuring for uniforms |  | 1h | 2015-01-05 14:00 | 2015-01-05 15:00 | 9 | 0d |
| 11 | 1.1.9 | Tour Customer Service Center |  | 90min | 2015-01-05 15:00 | 2015-01-05 16:30 | 10 | 0d |
| 12 | 1.1.10 | Pass out new employee gift bags |  | 30min | 2015-01-05 16:30 | 2015-01-05 17:00 | 11 | 0d |
| 13 | 1.1.11 | Day 1 Complete | milestone | 0d | 2015-01-05 17:00 | 2015-01-05 17:00 | 12 | 0d |
| 14 | 1.2 | **Day 2** |  | 0.81d | 2015-01-05 17:00 | 2015-01-06 15:30 |  | 0d |
| 15 | 1.2.1 | Day 2 begins | milestone | 0d | 2015-01-05 17:00 | 2015-01-05 17:00 | 13 | 0d |
| 16 | 1.2.2 | Icebreaker exercise |  | 30min | 2015-01-06 08:00 | 2015-01-06 08:30 | 15 | 0d |
| 17 | 1.2.3 | Review of Employee Handbook |  | 2h | 2015-01-06 08:30 | 2015-01-06 10:30 | 16 | 0d |
| 18 | 1.2.4 | Review of Compensation Structure |  | 30min | 2015-01-06 10:30 | 2015-01-06 11:00 | 17 | 0d |
| 19 | 1.2.5 | Overview of profit sharing plan |  | 30min | 2015-01-06 11:00 | 2015-01-06 11:30 | 18 | 0d |
| 20 | 1.2.6 | Lunch |  | 1h | 2015-01-06 11:30 | 2015-01-06 13:30 | 19 | 0d |
| 21 | 1.2.7 | Review of health and life insurance coverage |  | 45min | 2015-01-06 13:30 | 2015-01-06 14:15 | 20 | 0d |
| 22 | 1.2.8 | Complete health insurance paperwork |  | 15min | 2015-01-06 14:15 | 2015-01-06 14:30 | 21 | 0d |
| 23 | 1.2.9 | Complete life insurance paperwork |  | 15min | 2015-01-06 14:30 | 2015-01-06 14:45 | 22 | 0d |
| 24 | 1.2.10 | Pick up employee ID |  | 30min | 2015-01-06 14:45 | 2015-01-06 15:15 | 23 | 0d |
| 25 | 1.2.11 | Distribute Day 3 Training Manuals |  | 15min | 2015-01-06 15:15 | 2015-01-06 15:30 | 24 | 0d |
| 26 | 1.2.12 | Day 2 Complete | milestone | 0d | 2015-01-06 15:30 | 2015-01-06 15:30 | 25 | 0d |

Notes:
- 9: Remember to use blue backdrop for digital pics
- 22: Verify all insurance needs and any other insurance carriers
