# N:\Home Drive\Gregg's Docs\Documents\Wiley Press\Project 2013\Authors First\Lessons 13-17\Exercises\Lesson 16\Gregory Weber Biography 16-1

Schedule from MS Project, 2016-07-11 to 2016-10-25.
P8 LLC

## Calendars

- Standard: Mon-Fri 08:00-12:00, 13:00-17:00; Sat-Sun off.

## Schedule

| ID | WBS | Task | Type | Duration | Start | Finish | Predecessors | Total slack |
| --- | --- | --- | --- | --- | --- | --- | --- | --- |
| 1 | 1 | **Pre-Production** |  | 29d | 2016-07-11 | 2016-08-18 |  | 0d |
| 2 | 1.1 | Pre-Production begins | milestone | 0d | 2016-07-11 | 2016-07-11 |  | 0d |
| 3 | 1.2 | Review Screenplay |  | 4d | 2016-07-11 | 2016-07-14 | 2 | 0d |
| 4 | 1.3 | Develop scene blocking and schedule |  | 5d | 2016-07-15 | 2016-07-21 | 3 | 0d |
| 5 | 1.4 | Develop production layouts |  | 2w | 2016-07-22 | 2016-08-04 | 4 | 0d |
| 6 | 1.5 | Identify and reserve locations |  | 1w | 2016-08-05 | 2016-08-11 | 5 | 0d |
| 7 | 1.6 | Reserve audio recording equipment |  | 2d | 2016-08-12 | 2016-08-15 | 6 | 0d |
| 8 | 1.7 | Reserve video recording equipment |  | 3d | 2016-08-16 | 2016-08-18 | 7 | 0d |
| 9 | 2 | Pre Production finished | milestone | 0d | 2016-08-18 | 2016-08-18 | 8 | 0d |
| 10 | 3 | Production |  | 25d | 2016-08-19 | 2016-09-22 | 9 | 0d |
| 11 | 4 | **Post-Production** |  | 23d | 2016-09-22 | 2016-10-25 |  | 0d |
| 12 | 4.1 | Post-Production begins | milestone | 0d | 2016-09-22 | 2016-09-22 | 10 | 0d |
| 13 | 4.2 | Log video footage |  | 2d | 2016-09-23 | 2016-09-26 | 12 | 0d |
| 14 | 4.3 | Log audio tracks by scene |  | 2d | 2016-09-27 | 2016-09-28 | 13 | 0d |
| 15 | 4.4 | Rough edit video - paper |  | 1d | 2016-09-29 | 2016-09-29 | 14 | 0d |
| 16 | 4.5 | Rough audio edit |  | 3d | 2016-09-30 | 2016-10-04 | 15 | 0d |
| 17 | 4.6 | Fine audio edit |  | 4d | 2016-10-05 | 2016-10-10 | 16 | 0d |
| 18 | 4.7 | Fine video edit |  | 2d | 2016-10-11 | 2016-10-12 | 17 | 0d |
| 19 | 4.8 | Dub audio to video |  | 1d | 2016-10-13 | 2016-10-13 | 18 | 0d |
| 20 | 4.9 | Internal review viewing |  | 1d | 2016-10-14 | 2016-10-14 | 19 | 0d |
| 21 | 4.10 | Final edits |  | 3d | 2016-10-17 | 2016-10-19 | 20 | 0d |
| 22 | 4.11 | Formal approval viewing |  | 1d | 2016-10-20 | 2016-10-20 | 21 | 0d |
| 23 | 4.12 | Duplicate audio and video masters |  | 1d | 2016-10-21 | 2016-10-21 | 22 | 0d |
| 24 | 4.13 | Archive Copy 1 AV masters |  | 1d | 2016-10-24 | 2016-10-24 | 23 | 0d |
| 25 | 4.14 | Send Copy 2 AV master and dubbed master to |  | 1d | 2016-10-25 | 2016-10-25 | 24 | 0d |
| 26 | 5 | Post-Production complete | milestone | 0d | 2016-10-25 | 2016-10-25 | 25 | 0d |
