# ITS510_Module2

Schedule from MS Project, 2014-08-05 to 2014-10-21.

## Calendars

- Standard: Mon-Fri 08:00-12:00, 13:00-17:00; Sat-Sun off.

## Resources

| Resource |
| --- |
| Web Developer |
| Mobile Developer |
| System Analyst |
| Project Manager |

## Schedule

| ID | WBS | Task | Type | Duration | Start | Finish | Predecessors | Total slack | Resources | Work |
| --- | --- | --- | --- | --- | --- | --- | --- | --- | --- | --- |
| 1 | 1 | **Project - URCovered** |  | 56d | 2014-08-05 | 2014-10-21 |  | 0d |  | 960h |
| 2 | 1.1 | **Initiation** |  | 5d | 2014-08-05 | 2014-08-11 |  | 0d |  | 48h |
| 3 | 1.1.1 | Review Project Notes |  | 2d | 2014-08-05 | 2014-08-06 |  | 0d | Project Manager | 16h |
| 4 | 1.1.2 | Create Business Case Document |  | 3d | 2014-08-07 | 2014-08-11 | 3 | 0d | Project Manager | 24h |
| 5 | 1.1.3 | Create Schedule |  | 1d | 2014-08-07 | 2014-08-07 | 3 | 2d | Project Manager | 8h |
| 6 | 1.1.4 | Obtain User Signoff to Proceed | milestone | 0d | 2014-08-11 | 2014-08-11 | 4, 5 | 0d |  |  |
| 7 | 1.2 | **Requirements** |  | 14d | 2014-08-12 | 2014-08-29 |  | 0d |  | 448h |
| 8 | 1.2.1 | Fact Find |  | 14d | 2014-08-12 | 2014-08-29 | 6 | 0d | Project Manager; System Analyst | 224h |
| 9 | 1.2.2 | Review Existing System |  | 14d | 2014-08-12 | 2014-08-29 | 6 | 0d | Project Manager; System Analyst | 224h |
| 10 | 1.3 | **Design** |  | 15d | 2014-09-01 | 2014-09-19 |  | 0d |  | 120h |
| 11 | 1.3.1 | Design User Interface |  | 5d | 2014-09-01 | 2014-09-05 | 7 | 0d | System Analyst | 40h |
| 12 | 1.3.2 | Design Data Flow |  | 5d | 2014-09-08 | 2014-09-12 | 11 | 0d | System Analyst | 40h |
| 13 | 1.3.3 | Design User Processes |  | 5d | 2014-09-15 | 2014-09-19 | 12 | 0d | System Analyst | 40h |
| 14 | 1.4 | **Prototype** |  | 14d | 2014-09-22 | 2014-10-09 |  | 0d |  | 224h |
| 15 | 1.4.1 | Create Web Page Prototype |  | 14d | 2014-09-22 | 2014-10-09 | 10 | 0d | Web Developer | 112h |
| 16 | 1.4.2 | Create iOS Prototype |  | 14d | 2014-09-22 | 2014-10-09 | 10 | 0d | Mobile Developer | 112h |
| 17 | 1.5 | **Verification** |  | 5d | 2014-10-10 | 2014-10-16 |  | 0d |  | 80h |
| 18 | 1.5.1 | Review Solution Architecture |  | 5d | 2014-10-10 | 2014-10-16 | 14 | 0d | System Analyst | 40h |
| 19 | 1.5.2 | Validate Prototype |  | 5d | 2014-10-10 | 2014-10-16 | 14 | 0d | System Analyst | 40h |
| 20 | 1.6 | **Finalize** |  | 3d | 2014-10-17 | 2014-10-21 |  | 0d |  | 40h |
| 21 | 1.6.1 | Determine Recommendation |  | 3d | 2014-10-17 | 2014-10-21 | 17 | 0d | Project Manager | 24h |
| 22 | 1.6.2 | Create Executive Presentation |  | 2d | 2014-10-17 | 2014-10-20 | 17 | 1d | Project Manager | 16h |
