# Consumer Market Study

Schedule from MS Project, 2018-01-12 to 2018-07-10.

## Calendars

- Standard: Mon-Fri 08:00-12:00, 13:00-17:00; Sat-Sun off.

## Resources

| Resource | Notes |
| --- | --- |
| Susan |  |
| Steve |  |
| Andy |  |
| Jim |  |
| Travel Expense | Travel expenses for pilot testing questionnaire. |
| Questionnaire Printing |  |
| Questionnaire Mailing |  |

## Schedule

| ID | WBS | Task | Duration | Start | Finish | Predecessors | Baseline start | Baseline finish | Baseline duration | Total slack | Free slack | Resources | Work |
| --- | --- | --- | --- | --- | --- | --- | --- | --- | --- | --- | --- | --- | --- |
| 1 | 1 | **Questionnaire** | 103d | 2018-01-12 | 2018-06-05 |  | 2018-01-12 | 2018-06-05 | 103d | 0d |  |  | 384h |
| 2 | 1.1 | **Design** | 40d | 2018-01-12 | 2018-03-08 |  | 2018-01-12 | 2018-03-08 | 40d | 0d |  |  | 320h |
| 3 | 1.1.1 | Identify Target Consumers | 3d | 2018-01-12 | 2018-01-16 |  | 2018-01-12 | 2018-01-16 | 3d | 0d |  | Susan | 24h |
| 4 | 1.1.2 | Develop Draft Questionnaire | 10d | 2018-01-17 | 2018-01-30 | 3 | 2018-01-17 | 2018-01-30 | 10d | 0d |  | Susan | 80h |
| 5 | 1.1.3 | Pilot Test Questionnaire | 20d | 2018-01-31 | 2018-02-27 | 4 | 2018-01-31 | 2018-02-27 | 20d | 0d |  | Susan; Travel Expense [0.1%] | 160h |
| 6 | 1.1.4 | Review Comments & Finalize Questionnaire | 5d | 2018-02-28 | 2018-03-06 | 5 | 2018-02-28 | 2018-03-06 | 5d | 0d |  | Susan | 40h |
| 7 | 1.1.5 | Develop Software Test Data | 2d | 2018-03-07 | 2018-03-08 | 6 | 2018-03-07 | 2018-03-08 | 2d | 58d | 10d | Susan | 16h |
| 8 | 1.2 | **Responses** | 65d | 2018-03-07 | 2018-06-05 |  | 2018-03-07 | 2018-06-05 | 65d | 0d |  |  | 64h |
| 9 | 1.2.1 | Print Questionnaire | 10d | 2018-03-07 | 2018-03-20 | 6 | 2018-03-07 | 2018-03-20 | 10d | 0d |  | Steve; Questionnaire Printing | 8h |
| 10 | 1.2.2 | Prepare Mailing Labels | 2d | 2018-03-08 | 2018-03-09 | 6 | 2018-03-08 | 2018-03-09 | 2d | 7d |  | Steve | 16h |
| 11 | 1.2.3 | Mail Questionnaire & Get Responses | 55d | 2018-03-21 | 2018-06-05 | 9, 10 | 2018-03-21 | 2018-06-05 | 55d | 0d |  | Steve; Questionnaire Mailing | 40h |
| 12 | 2 | **Report** | 90d | 2018-03-07 | 2018-07-10 |  | 2018-03-07 | 2018-07-10 | 90d | 0d |  |  | 256h |
| 13 | 2.1 | **Software** | 17d | 2018-03-07 | 2018-03-29 |  | 2018-03-07 | 2018-03-29 | 17d | 48d |  |  | 136h |
| 14 | 2.1.1 | Develop Data Analysis Software | 12d | 2018-03-07 | 2018-03-22 | 6 | 2018-03-07 | 2018-03-22 | 12d | 48d | 0d | Andy | 96h |
| 15 | 2.1.2 | Test Software | 5d | 2018-03-23 | 2018-03-29 | 7, 14 | 2018-03-23 | 2018-03-29 | 5d | 48d |  | Andy | 40h |
| 16 | 2.2 | **Report** | 25d | 2018-06-06 | 2018-07-10 |  | 2018-06-06 | 2018-07-10 | 25d | 0d |  |  | 120h |
| 17 | 2.2.1 | Input Response Data | 7d | 2018-06-06 | 2018-06-14 | 11, 15 | 2018-06-06 | 2018-06-14 | 7d | 0d |  | Jim | 56h |
| 18 | 2.2.2 | Analyze Results | 8d | 2018-06-15 | 2018-06-26 | 17 | 2018-06-15 | 2018-06-26 | 8d | 0d |  | Jim | 64h |
| 19 | 2.2.3 | Prepare Report | 10d | 2018-06-27 | 2018-07-10 | 18 | 2018-06-27 | 2018-07-10 | 10d | 0d |  |  |  |
