# Consumer Market Study

Schedule from MS Project, 2018-01-12 to 2018-07-19, A marks actual dates.

## Calendars

- Standard: Mon-Fri 08:00-12:00, 13:00-17:00; Sat-Sun off.

## Resources

| Resource |
| --- |
| Susan |
| Steve |
| Andy |
| Jim |

## Schedule

| ID | WBS | Task | Type | Duration | Start | Finish | Predecessors | Complete | Remaining | Baseline start | Baseline finish | Baseline duration | Total slack | Free slack | Resources | Work | Actual work |
| --- | --- | --- | --- | --- | --- | --- | --- | --- | --- | --- | --- | --- | --- | --- | --- | --- | --- |
| 1 | 1 | **Questionnaire** |  | 110d | 2018-01-12 A | 2018-06-14 |  | 22% | 85.43d | 2018-01-12 | 2018-06-05 | 103d | 0d |  |  | 912h | 241.2h |
| 2 | 1.1 | **Design** |  | 47d | 2018-01-12 A | 2018-03-19 |  | 64% | 16.85d | 2018-01-12 | 2018-03-08 | 40d | 58d |  |  | 376h | 241.2h |
| 3 | 1.1.1 | Identify Target Consumers |  | 2d | 2018-01-12 A | 2018-01-15 A |  | 100% |  | 2018-01-12 | 2018-01-16 | 3d |  |  | Susan | 16h | 16h |
| 4 | 1.1.2 | Develop Draft Questionnaire |  | 9d | 2018-01-16 A | 2018-01-26 A | 3 | 100% |  | 2018-01-17 | 2018-01-30 | 10d |  |  | Susan | 72h | 72h |
| 5 | 1.1.3 | Pilot Test Questionnaire |  | 19d | 2018-01-29 A | 2018-02-22 A | 4 | 100% |  | 2018-01-31 | 2018-02-27 | 20d |  |  | Susan | 152h | 152h |
| 6 | 1.1.4 | Review Comments & Finalize Questionnaire |  | 15d | 2018-02-23 A | 2018-03-15 | 5 | 1% | 14.85d | 2018-02-28 | 2018-03-06 | 5d | 0d |  | Susan | 120h | 1.2h |
| 7 | 1.1.5 | Develop Software Test Data |  | 2d | 2018-03-16 | 2018-03-19 | 6 |  |  | 2018-03-07 | 2018-03-08 | 2d | 58d | 10d | Susan | 16h |  |
| 8 | 1.2 | **Responses** |  | 87d | 2018-02-14 | 2018-06-14 |  |  |  | 2018-03-07 | 2018-06-05 | 65d | 0d |  |  | 536h |  |
| 9 | 1.2.1 | Order New Database for Labels | manual | 21d | 2018-02-14 | 2018-03-14 |  |  |  |  |  |  |  |  |  |  |  |
| 10 | 1.2.2 | Print Questionnaire |  | 10d | 2018-03-16 | 2018-03-29 | 6 |  |  | 2018-03-07 | 2018-03-20 | 10d | 0d |  | Steve | 80h |  |
| 11 | 1.2.3 | Prepare Mailing Labels |  | 2d | 2018-03-16 | 2018-03-19 | 6, 9 |  |  | 2018-03-07 | 2018-03-08 | 2d | 8d |  | Steve | 16h |  |
| 12 | 1.2.4 | Mail Questionnaire & Get Responses |  | 55d | 2018-03-30 | 2018-06-14 | 10, 11 |  |  | 2018-03-21 | 2018-06-05 | 55d | 0d |  | Steve | 440h |  |
| 13 | 2 | **Report** |  | 90d | 2018-03-16 | 2018-07-19 |  |  |  | 2018-03-07 | 2018-07-10 | 90d | 0d |  |  | 256h |  |
| 14 | 2.1 | **Software** |  | 17d | 2018-03-16 | 2018-04-09 |  |  |  | 2018-03-07 | 2018-03-29 | 17d | 48d |  |  | 136h |  |
| 15 | 2.1.1 | Develop Data Analysis Software |  | 12d | 2018-03-16 | 2018-04-02 | 6 |  |  | 2018-03-07 | 2018-03-22 | 12d | 48d | 0d | Andy | 96h |  |
| 16 | 2.1.2 | Test Software |  | 5d | 2018-04-03 | 2018-04-09 | 7, 15 |  |  | 2018-03-23 | 2018-03-29 | 5d | 48d |  | Andy | 40h |  |
| 17 | 2.2 | **Report** |  | 25d | 2018-06-15 | 2018-07-19 |  |  |  | 2018-06-06 | 2018-07-10 | 25d | 0d |  |  | 120h |  |
| 18 | 2.2.1 | Input Response Data |  | 7d | 2018-06-15 | 2018-06-25 | 12, 16 |  |  | 2018-06-06 | 2018-06-14 | 7d | 0d |  | Jim | 56h |  |
| 19 | 2.2.2 | Analyze Results |  | 8d | 2018-06-26 | 2018-07-05 | 18 |  |  | 2018-06-15 | 2018-06-26 | 8d | 0d |  | Jim | 64h |  |
| 20 | 2.2.3 | Prepare Report |  | 10d | 2018-07-06 | 2018-07-19 | 19 |  |  | 2018-06-27 | 2018-07-10 | 10d | 0d |  |  |  |  |
