# Online Retail Grocery Store website’s software development

Schedule from MS Project, 2020-01-06 to 2020-08-25, status date 2020-08-25, scheduled back from the finish, costs in $, A marks actual dates.
Planning and Execution of Project
Retail Grocery Store
This is a project for launching new online web application for ordering grocery and retail products through online.

## Calendars

- Online web application project: Mon-Fri 08:00-12:00, 13:00-17:00; Sat-Sun off. Exceptions (off unless hours are given): 2020-01-06 08:00-12:00, 13:00-17:00 (Project kick off meeting), 2020-01-20 (Martin Luther King Junior Day), 2020-05-25 (Memorial Day).

## Resources

| Resource | Rate |
| --- | --- |
| Project Manager | 90 |
| Business Analyst | 86 |
| Lead Dot Net Developer | 81 |
| Quality Assurance Analyst | 76 |
| Computers | 200 |
| Laptops | 120 |
| Printer | 60 |
| Team Lunch |  |

## Schedule

| ID | WBS | Task | Type | Duration | Start | Finish | Predecessors | Complete | Remaining | Actual start | Actual finish | Baseline start | Baseline finish | Baseline duration | Total slack | Constraint | Resources | Work | Actual work | Cost | Baseline cost | Actual cost |
| --- | --- | --- | --- | --- | --- | --- | --- | --- | --- | --- | --- | --- | --- | --- | --- | --- | --- | --- | --- | --- | --- | --- |
| 1 | 1 | **Online Retail Grocery Store website’s software development** |  | 165d? | 2020-01-06 A | 2020-08-25 |  | 56% | 71.84d? |  |  | 2020-01-06 | 2020-08-25 | 165d? |  | as late as possible |  | 47.2h | 25.87h | 4,678.3 | 4,678.3 | 2,990.56 |
| 2 | 1.1 | **Project Initiation Phase** |  | 29d? | 2020-01-06 A | 2020-02-14 |  | 99% | 0d? |  |  | 2020-01-06 | 2020-02-14 | 29d? |  | as late as possible |  | 3.34h | 3.34h | 661.72 | 661.72 | 661.72 |
| 3 | 1.1.1 | **Project Charter Development** |  | 11d | 2020-01-06 A | 2020-01-21 |  | 100% |  |  | 2020-02-07 | 2020-01-06 | 2020-01-21 | 11d |  | as late as possible |  | 1.1h | 1.1h | 96.44 | 96.44 | 96.44 |
| 4 | 1.1.1.1 | Meeting project internal and external stakeholders | manual | 3d | 2020-01-06 A | 2020-02-07 A |  | 100% |  |  |  | 2020-01-06 | 2020-02-07 | 3d |  |  | Project Manager [1%] | 0.38h | 0.38h | 34.2 | 34.2 | 34.2 |
| 5 | 1.1.1.2 | Onboarding the resources of the project | manual | 3d | 2020-01-08 A | 2020-01-10 A | 4 | 100% |  |  |  | 2020-01-08 | 2020-01-10 | 3d |  |  |  |  |  |  |  |  |
| 6 | 1.1.1.3 | Gather requirements of the project | manual | 2d | 2020-01-13 A | 2020-01-14 A | 5 | 100% |  |  |  | 2020-01-13 | 2020-01-14 | 2d |  |  | Business Analyst [2%] | 0.32h | 0.32h | 27.52 | 27.52 | 27.52 |
| 7 | 1.1.1.4 | Document those requirements into Business Requirement Document and Funtional Requirement Document i.e. FRD & BRD | manual | 2d | 2020-01-15 A | 2020-01-16 A | 6 | 100% |  |  |  | 2020-01-15 | 2020-01-16 | 2d |  |  | Business Analyst [1%] | 0.16h | 0.16h | 13.76 | 13.76 | 13.76 |
| 8 | 1.1.1.5 | Document the entire project charter | manual | 1d | 2020-01-17 A | 2020-01-17 A |  | 100% |  |  |  | 2020-01-17 | 2020-01-17 | 1d |  | start no later than 2018-06-12 | Business Analyst [2%] | 0.16h | 0.16h | 13.76 | 13.76 | 13.76 |
| 9 | 1.1.1.6 | Getting Project Charter Signed | manual | 1d | 2020-01-21 A | 2020-01-21 A | 8 | 100% |  |  |  | 2020-01-21 | 2020-01-21 | 1d |  | as late as possible | Project Manager [1%] | 0.08h | 0.08h | 7.2 | 7.2 | 7.2 |
| 10 | 1.1.2 | **Selection of templates of the web application** |  | 8d? | 2020-01-06 A | 2020-01-15 A |  | 100% |  |  |  | 2020-01-06 | 2020-01-15 | 8d? |  | as late as possible |  | 1.76h | 1.76h | 144.96 | 144.96 | 144.96 |
| 11 | 1.1.2.1 | Collection of sample templates from various sources |  | 3d? | 2020-01-06 A | 2020-01-08 A |  | 100% |  |  |  | 2020-01-06 | 2020-01-08 | 3d? |  |  | Business Analyst [2%]; Lead Dot Net Developer [2%] | 0.96h | 0.96h | 80.16 | 80.16 | 80.16 |
| 12 | 1.1.2.2 | Implementing the template through web application architecture |  | 5d? | 2020-01-09 A | 2020-01-15 A | 11 | 100% |  |  |  | 2020-01-09 | 2020-01-15 | 5d? |  |  | Lead Dot Net Developer [2%] | 0.8h | 0.8h | 64.8 | 64.8 | 64.8 |
| 13 | 1.1.3 | **Selection of Technology and Tool** |  | 2d? | 2020-02-04 | 2020-02-05 A |  | 100% |  | 2020-01-06 |  | 2020-02-04 | 2020-02-05 | 2d? |  | as late as possible |  | 0.32h | 0.32h | 25.92 | 25.92 | 25.92 |
| 14 | 1.1.3.1 | Technology would be Dot Net |  | 1d? | 2020-01-06 A | 2020-01-06 A |  | 100% |  |  |  | 2020-01-06 | 2020-01-06 | 1d? |  |  | Lead Dot Net Developer [2%] | 0.16h | 0.16h | 12.96 | 12.96 | 12.96 |
| 15 | 1.1.3.2 | Tool would be Team Foundation Server |  | 1d? | 2020-02-05 A | 2020-02-05 A | 14 | 100% |  |  |  | 2020-02-05 | 2020-02-05 | 1d? |  | as late as possible | Lead Dot Net Developer [2%] | 0.16h | 0.16h | 12.96 | 12.96 | 12.96 |
| 16 | 1.1.4 | **Developing the organization Chart** |  | 2d? | 2020-02-06 | 2020-02-07 A |  | 100% |  | 2020-01-06 |  | 2020-02-06 | 2020-02-07 | 2d? |  | as late as possible |  | 0.16h | 0.16h | 14.4 | 14.4 | 14.4 |
| 17 | 1.1.4.1 | Documentation report which includes in project who communicates to whom |  | 1d? | 2020-01-06 A | 2020-01-06 A |  | 100% |  |  |  | 2020-01-06 | 2020-01-06 | 1d? |  |  | Project Manager [1%] | 0.08h | 0.08h | 7.2 | 7.2 | 7.2 |
| 18 | 1.1.4.2 | Define the roles and responsibilities |  | 1d? | 2020-02-07 A | 2020-02-07 A | 17FF | 100% |  |  |  | 2020-02-07 | 2020-02-07 | 1d? |  | as late as possible | Project Manager [1%] | 0.08h | 0.08h | 7.2 | 7.2 | 7.2 |
| 19 | 1.1.5 | **Getting the project equipment** |  | 5d? | 2020-02-10 | 2020-02-14 |  | 99% | 0d? | 2020-01-06 |  | 2020-02-10 | 2020-02-14 | 5d? |  | as late as possible |  |  |  | 380 | 380 | 380 |
| 20 | 1.1.5.1 | Installing the desktops, getting laptops and printers for the purpose of the project |  | 4d? | 2020-01-06 A | 2020-01-09 A |  | 100% |  |  |  | 2020-01-06 | 2020-01-09 | 4d? |  |  | Computers; Laptops; Printer |  |  | 380 | 380 | 380 |
| 21 | 1.1.5.2 | Setting up email IDs and getting the project access |  | 1d? | 2020-02-14 A | 2020-02-14 A | 20 | 100% |  |  |  | 2020-02-14 | 2020-02-14 | 1d? |  | as late as possible |  |  |  |  |  |  |
| 22 | 1.1.5.3 | Project Initiation Phase End | milestone | 0d | 2020-02-14 | 2020-02-14 | 21 |  |  |  |  | 2020-02-14 | 2020-02-14 | 0d | 0d | as late as possible |  |  |  |  |  |  |
| 23 | 1.2 | **Project Planning Phase** |  | 35d? | 2020-02-17 | 2020-04-03 |  | 72% | 9.78d? | 2020-01-06 |  | 2020-02-17 | 2020-04-03 | 35d? |  | as late as possible |  | 3.04h | 1.36h | 381.44 | 381.44 | 234.72 |
| 24 | 1.2.1 | **Environment Set up** |  | 4d? | 2020-02-18 | 2020-02-21 |  | 100% |  | 2020-01-06 | 2020-01-09 | 2020-02-18 | 2020-02-21 | 4d? |  | as late as possible |  | 0.64h | 0.64h | 171.84 | 171.84 | 171.84 |
| 25 | 1.2.1.1 | Development Environment set up |  | 2d? | 2020-01-06 A | 2020-01-07 A |  | 100% |  |  |  | 2020-01-06 | 2020-01-07 | 2d? |  |  | Lead Dot Net Developer [2%] | 0.32h | 0.32h | 25.92 | 25.92 | 25.92 |
| 26 | 1.2.1.2 | Test Environment Set up |  | 1d | 2020-01-08 A | 2020-01-08 A | 25 | 100% |  |  |  | 2020-01-08 | 2020-01-08 | 1d |  |  | Lead Dot Net Developer [2%] | 0.16h | 0.16h | 12.96 | 12.96 | 12.96 |
| 27 | 1.2.1.3 | Issuing authentication to the selected project members who will work on the project |  | 1d? | 2020-01-09 A | 2020-01-09 A | 26 | 100% |  |  |  | 2020-01-09 | 2020-01-09 | 1d? |  |  | Laptops; Lead Dot Net Developer [2%] | 0.16h | 0.16h | 132.96 | 132.96 | 132.96 |

| ID | WBS | Task | Type | Duration | Start | Finish | Predecessors | Complete | Remaining | Actual start | Actual finish | Baseline start | Baseline finish | Baseline duration | Total slack | Free slack | Constraint | Resources | Work | Actual work | Cost | Baseline cost | Actual cost |
| --- | --- | --- | --- | --- | --- | --- | --- | --- | --- | --- | --- | --- | --- | --- | --- | --- | --- | --- | --- | --- | --- | --- | --- |
| 28 | 1.2.2 | **Communication Process** |  | 16d? | 2020-02-24 | 2020-03-16 |  | 100% |  | 2020-01-06 | 2020-01-28 | 2020-02-24 | 2020-03-16 | 16d? |  |  | as late as possible |  |  |  |  |  |  |
| 29 | 1.2.2.1 | Creation of Sitemap and wireframe |  | 16d? | 2020-01-06 A | 2020-01-28 A | 27SF | 100% |  |  |  | 2020-01-06 | 2020-01-28 | 16d? |  |  |  |  |  |  |  |  |  |
| 30 | 1.2.3 | **Creation of Roadmap** |  | 8d? | 2020-03-16 | 2020-03-25 |  | 43% | 4.57d? | 2020-01-06 |  | 2020-03-16 | 2020-03-25 | 8d? |  |  | as late as possible |  | 1.68h | 0.72h | 146.72 | 146.72 | 62.88 |
| 31 | 1.2.3.1 | Performing analysis on current market, required investment and estimated earnings |  | 3d? | 2020-01-06 A | 2020-01-08 A |  | 100% |  |  |  | 2020-01-06 | 2020-01-08 | 3d? |  |  |  | Business Analyst [2%]; Project Manager [1%] | 0.72h | 0.72h | 62.88 | 62.88 | 62.88 |
| 32 | 1.2.3.2 | Technical Research analysis |  | 4d | 2020-01-09 | 2020-01-14 | 31 |  |  |  |  | 2020-01-09 | 2020-01-14 | 4d | 50d |  |  | Business Analyst [2%]; Project Manager [1%] | 0.96h |  | 83.84 | 83.84 |  |
| 33 | 1.2.4 | **Risk Analysis** |  | 4d? | 2020-03-26 | 2020-03-31 |  |  |  |  |  | 2020-03-26 | 2020-03-31 | 4d? |  |  | as late as possible |  | 0.48h |  | 41.92 | 41.92 |  |
| 34 | 1.2.4.1 | Doing deep analysis of risks involved in project |  | 2d? | 2020-01-06 | 2020-01-07 |  |  |  |  |  | 2020-01-06 | 2020-01-07 | 2d? | 57d |  |  |  |  |  |  |  |  |
| 35 | 1.2.4.2 | Documenting the risks which can be involved |  | 2d? | 2020-03-30 | 2020-03-31 | 34 |  |  |  |  | 2020-03-30 | 2020-03-31 | 2d? | 0d |  | must start on 2020-03-30 | Business Analyst [2%]; Project Manager [1%] | 0.48h |  | 41.92 | 41.92 |  |
| 36 | 1.2.5 | **Needs of the customer** |  | 3d? | 2020-04-01 | 2020-04-03 |  | 50% | 1.5d? | 2020-01-06 |  | 2020-04-01 | 2020-04-03 | 3d? |  |  | as late as possible |  | 0.24h |  | 20.96 | 20.96 |  |
| 37 | 1.2.5.1 | Knowing what exactly the customer or user the website to be |  | 1d? | 2020-01-06 | 2020-01-06 |  |  |  |  |  | 2020-01-06 | 2020-01-06 | 1d? | 62.5d | 61d |  | Business Analyst [2%]; Project Manager [1%] | 0.24h |  | 20.96 | 20.96 |  |
| 38 | 1.2.5.2 | Conducting customer survey |  | 2d? | 2020-04-02 A | 2020-04-03 | 37 | 75% | 0.5d? |  |  | 2020-04-02 | 2020-04-03 | 2d? | 0d |  |  |  |  |  |  |  |  |
| 39 | 1.2.5.3 | Project Planning Phase End | milestone | 0d | 2020-04-03 | 2020-04-03 |  |  |  |  |  | 2020-04-03 | 2020-04-03 | 0d | 64d | 0d | as late as possible |  |  |  |  |  |  |
| 40 | 1.3 | **Project Execution Phase** |  | 61d? | 2020-04-06 | 2020-06-30 |  | 52% | 29.55d? | 2020-01-13 |  | 2020-04-06 | 2020-06-30 | 61d? |  |  | as late as possible |  | 23.26h | 14.36h | 2,177.14 | 2,177.14 | 1,500.96 |
| 41 | 1.3.1 | **Web Design Architure** |  | 8d? | 2020-04-06 | 2020-04-15 |  | 100% |  | 2020-01-13 | 2020-04-07 | 2020-04-06 | 2020-04-15 | 8d? |  |  | as late as possible |  | 1.44h | 1.44h | 436.64 | 436.64 | 436.64 |
| 42 | 1.3.1.1 | Getting Server, memory and communication interfaces ready |  | 2d? | 2020-04-06 A | 2020-04-07 A |  | 100% |  |  |  | 2020-04-06 | 2020-04-07 | 2d? |  |  |  | Laptops; Lead Dot Net Developer [2%] | 0.32h | 0.32h | 145.92 | 145.92 | 145.92 |
| 43 | 1.3.1.2 | Building functionality aspects |  | 2d? | 2020-01-13 A | 2020-01-14 A | 42FS+3d | 100% |  |  |  | 2020-01-13 | 2020-01-14 | 2d? |  |  |  | Computers; Lead Dot Net Developer [2%] | 0.32h | 0.32h | 225.92 | 225.92 | 225.92 |
| 44 | 1.3.1.3 | Building visual appearance as User Interface design |  | 5d? | 2020-01-15 A | 2020-01-22 A | 43 | 100% |  |  |  | 2020-01-15 | 2020-01-22 | 5d? |  |  |  | Lead Dot Net Developer [2%] | 0.8h | 0.8h | 64.8 | 64.8 | 64.8 |
| 45 | 1.3.2 | **Business Requirement Analysis** |  | 5d? | 2020-04-20 A | 2020-04-24 |  | 40% | 3d? |  |  | 2020-04-20 | 2020-04-24 | 5d? |  |  | as late as possible |  | 4.32h | 4h | 387.52 | 387.52 | 360 |
| 46 | 1.3.2.1 | Preparing the Functional Requirement Document | manual | 2d? | 2020-04-20 | 2020-04-21 |  |  |  |  |  | 2020-04-20 | 2020-04-21 | 2d? |  |  |  | Business Analyst [2%]; Computers | 0.32h |  | 27.52 | 27.52 |  |
| 47 | 1.3.2.2 | Preparing the business requirement document | milestone, manual | 0d? | 2020-04-23 | 2020-04-23 | 46 |  |  |  |  | 2020-04-23 | 2020-04-23 | 0d? |  |  |  | Business Analyst; Computers |  |  |  |  |  |
| 48 | 1.3.2.3 | Conducting Joint Application Development session | manual | 2.98d | 2020-04-24 A | 2020-04-28 |  | 67% | 0.99d |  |  | 2020-04-24 | 2020-04-28 | 2.98d |  |  | finish no later than 2020-04-24 | Business Analyst; Lead Dot Net Developer; Project Manager | 4h | 4h | 360 | 360 | 360 |
| 49 | 1.3.3 | **Web application Development & Testing** |  | 42d? | 2020-04-27 A | 2020-06-24 |  | 43% | 23.98d? |  |  | 2020-04-27 | 2020-06-24 | 42d? |  |  | as late as possible |  | 17.5h | 8.92h | 1,352.98 | 1,352.98 | 704.32 |
| 50 | 1.3.3.1 | Coding or developing the user stories which meets the acceptance critieria | manual | 2d | 2020-04-27 A | 2020-04-28 A |  | 100% |  |  |  | 2020-04-27 | 2020-04-28 | 2d |  |  | finish no later than 2020-04-28 | Lead Dot Net Developer [5%] | 0.8h | 0.8h | 64.8 | 64.8 | 64.8 |
| 51 | 1.3.3.2 | Deploying the features into development envrionment and test environment |  | 0.4d? | 2020-04-29 | 2020-04-29 | 50 |  |  |  |  | 2020-04-29 | 2020-04-29 | 0.4d? | 1.13d | 0d |  | Lead Dot Net Developer [2%] | 0.06h |  | 5.21 | 5.21 |  |
| 52 | 1.3.3.3 | Performing Unit Testing & Integration Testing |  | 1.47d? | 2020-04-29 | 2020-04-30 | 51 |  |  |  |  | 2020-04-29 | 2020-04-30 | 1.47d? | 1.13d | 0d |  |  | 0.23h |  |  |  |  |
| 53 | 1.3.3.4 | Preparing the test plan & test scenarios |  | 5.06d? | 2020-04-27 A | 2020-05-04 | 52 | 96% | 0.21d? |  |  | 2020-04-27 | 2020-05-04 | 5.06d? | 0d |  |  | Quality Assurance Analyst [10%] | 2.42h | 2.26h | 184.27 | 184.27 | 171.76 |
| 54 | 1.3.3.5 | Preparing the test scripts as per organization template |  | 10.88d? | 2020-05-04 A | 2020-05-18 | 53 | 46% | 5.88d? |  |  | 2020-05-04 | 2020-05-18 | 10.88d? | 0d |  |  | Quality Assurance Analyst [10%] | 7.2h | 2.5h | 547.2 | 547.2 | 190 |
| 55 | 1.3.3.6 | Executing the test scripts and updating the results i.e. pass or fail |  | 3d? | 2020-05-13 A | 2020-05-15 A | 54 | 100% |  |  |  | 2020-05-13 | 2020-05-15 | 3d? |  |  |  | Quality Assurance Analyst [10%] | 1.16h | 1.16h | 88.16 | 88.16 | 88.16 |
| 56 | 1.3.3.7 | Loging defects found in the application with bug severirties & priorities |  | 2.34d? | 2020-05-15 A | 2020-05-19 | 55 | 43% | 1.34d? |  |  | 2020-05-15 | 2020-05-19 | 2.34d? | 0d |  |  | Quality Assurance Analyst [10%] | 1.67h | 0.6h | 126.86 | 126.86 | 45.6 |
| 57 | 1.3.3.8 | Developers fix the issues |  | 7.48d? | 2020-05-19 | 2020-06-01 | 56 |  |  |  |  | 2020-05-19 | 2020-06-01 | 7.48d? | 0d |  | must finish on 2020-06-01 | Lead Dot Net Developer [2%] | 1.14h |  | 91.98 | 91.98 |  |
| 58 | 1.3.3.9 | Moving the application into production environment |  | 1.98d? | 2020-06-02 | 2020-06-03 | 57 |  |  |  |  | 2020-06-02 | 2020-06-03 | 1.98d? | 13d | 0d |  | Lead Dot Net Developer [2%] | 0.32h |  | 25.67 | 25.67 |  |
| 59 | 1.3.3.10 | Performing the UAT and coording with business users |  | 2.02d? | 2020-06-03 | 2020-06-08 | 58 |  |  |  |  | 2020-06-03 | 2020-06-08 | 2.02d? | 13d |  |  | Business Analyst [2%] | 0.13h |  | 11.28 | 11.28 |  |
| 60 | 1.3.3.11 | Performing Pilot testing |  | 4d? | 2020-06-12 A | 2020-06-17 |  | 71% | 1.14d? |  |  | 2020-06-12 | 2020-06-17 | 4d? | 3d | 0d | must finish on 2020-06-12 | Business Analyst [2%]; Lead Dot Net Developer [2%]; Project Manager [1%] | 2.24h | 1.6h | 197.44 | 197.44 | 144 |
| 61 | 1.3.3.12 | Moving the application into live environment for users |  | 3d | 2020-06-22 | 2020-06-24 |  |  |  |  |  | 2020-06-22 | 2020-06-24 | 3d | 118d | 0d | start no later than 2020-06-22 | Lead Dot Net Developer [2%] | 0.12h |  | 10.11 | 10.11 |  |
| 62 | 1.3.3.13 | Project Execution phase end | milestone | 0d | 2020-06-24 A | 2020-06-24 A | 61 | 100% |  |  |  | 2020-06-24 | 2020-06-24 | 0d |  |  | as late as possible |  |  |  |  |  |  |

| ID | WBS | Task | Type | Duration | Start | Finish | Predecessors | Complete | Remaining | Actual start | Baseline start | Baseline finish | Baseline duration | Total slack | Free slack | Constraint | Resources | Work | Actual work | Cost | Baseline cost | Actual cost |
| --- | --- | --- | --- | --- | --- | --- | --- | --- | --- | --- | --- | --- | --- | --- | --- | --- | --- | --- | --- | --- | --- | --- |
| 63 | 1.4 | **Project Monitoring & Controlling Phase** |  | 25d? | 2020-06-25 A | 2020-07-29 |  | 12% | 22.05d? |  | 2020-06-25 | 2020-07-29 | 25d? |  |  | as late as possible |  | 12.96h | 3.01h | 1,044 | 1,044 | 251.16 |
| 64 | 1.4.1 | **Solving Application's critical problems quickly.** |  | 7d? | 2020-06-25 | 2020-07-03 |  |  |  |  | 2020-06-25 | 2020-07-03 | 7d? |  |  | as late as possible |  | 1.6h |  | 134.24 | 134.24 |  |
| 65 | 1.4.1.1 | Monitoring key server resources for the purpose of load and usage |  | 2d? | 2020-06-25 | 2020-06-26 |  |  |  |  | 2020-06-25 | 2020-06-26 | 2d? | 121d | 0d | as late as possible | Business Analyst [2%]; Project Manager [1%] | 0.48h |  | 41.92 | 41.92 |  |
| 66 | 1.4.1.2 | Monitoring the response time |  | 2d? | 2020-06-29 | 2020-06-30 | 65 |  |  |  | 2020-06-29 | 2020-06-30 | 2d? | 121d | 0d | as late as possible | Business Analyst [2%]; Lead Dot Net Developer [2%] | 0.64h |  | 53.44 | 53.44 |  |
| 67 | 1.4.1.3 | Monitoring configuration changes |  | 3d? | 2020-07-01 | 2020-07-03 | 66 |  |  |  | 2020-07-01 | 2020-07-03 | 3d? | 121d | 0d | as late as possible | Lead Dot Net Developer [2%] | 0.48h |  | 38.88 | 38.88 |  |
| 68 | 1.4.2 | **Network traffic monitoring** |  | 6d? | 2020-07-06 A | 2020-07-13 |  | 28% | 4.33d? |  | 2020-07-06 | 2020-07-13 | 6d? |  |  | as late as possible |  | 2.56h | 1.6h | 226.56 | 226.56 | 144 |
| 69 | 1.4.2.1 | Monitoring, tracing and analyzing traffic data once for all |  | 2d? | 2020-07-06 A | 2020-07-07 |  | 83% | 0.33d? |  | 2020-07-06 | 2020-07-07 | 2d? | 0d |  | as late as possible | Business Analyst [2%]; Project Manager [1%] | 1.92h | 1.6h | 171.52 | 171.52 | 144 |
| 70 | 1.4.2.2 | Identifying the major users of the network and Improving the network with control measures |  | 4d? | 2020-07-08 | 2020-07-13 | 69 |  |  |  | 2020-07-08 | 2020-07-13 | 4d? | 0d |  | as late as possible | Business Analyst [2%] | 0.64h |  | 55.04 | 55.04 |  |
| 71 | 1.4.3 | **Monitoring the response time of servers** |  | 5d? | 2020-07-14 | 2020-07-20 |  |  |  |  | 2020-07-14 | 2020-07-20 | 5d? |  |  | as late as possible |  | 1.28h |  | 106.08 | 106.08 |  |
| 72 | 1.4.3.1 | Checking server response time with both physically and virtually |  | 3d? | 2020-07-14 | 2020-07-16 |  |  |  |  | 2020-07-14 | 2020-07-16 | 3d? | 134d | 0d | as late as possible | Business Analyst [2%]; Lead Dot Net Developer [2%] | 0.96h |  | 80.16 | 80.16 |  |
| 73 | 1.4.3.2 | Isolating the application issues |  | 2d? | 2020-07-17 | 2020-07-20 | 72 |  |  |  | 2020-07-17 | 2020-07-20 | 2d? | 134d | 0d | as late as possible | Lead Dot Net Developer [2%] | 0.32h |  | 25.92 | 25.92 |  |
| 74 | 1.4.4 | **Identifying infrastructure dependencies** |  | 5d? | 2020-07-21 A | 2020-07-27 |  | 33% | 3.37d? |  | 2020-07-21 | 2020-07-27 | 5d? |  |  | as late as possible |  | 4.8h | 1.41h | 368.8 | 368.8 | 107.16 |
| 75 | 1.4.4.1 | Monitoring web server availability & response time |  | 5d? | 2020-07-21 A | 2020-07-27 |  | 33% | 3.37d? |  | 2020-07-21 | 2020-07-27 | 5d? | 0d |  | as late as possible | Lead Dot Net Developer [2%]; Quality Assurance Analyst [10%] | 4.8h | 1.41h | 368.8 | 368.8 | 107.16 |
| 76 | 1.4.5 | **Post production support** |  | 5d? | 2020-07-28 | 2020-08-03 |  |  |  |  | 2020-07-28 | 2020-08-03 | 5d? |  |  | as late as possible |  | 2.72h |  | 208.32 | 208.32 |  |
| 77 | 1.4.5.1 | Trouble shooting all the issues |  | 2d? | 2020-07-28 | 2020-07-29 |  |  |  |  | 2020-07-28 | 2020-07-29 | 2d? | 144d | 0d | as late as possible | Lead Dot Net Developer [2%] | 0.32h |  | 25.92 | 25.92 |  |
| 78 | 1.4.5.2 | Retesting the application before deploying for confirmation |  | 3d | 2020-07-30 | 2020-08-03 | 77 |  |  |  | 2020-07-30 | 2020-08-03 | 3d | 144d | 0d | as late as possible | Quality Assurance Analyst [10%] | 2.4h |  | 182.4 | 182.4 |  |
| 79 | 1.4.5.3 | Project Monitoring & Controlling Phase End | milestone | 0d | 2020-08-03 | 2020-08-03 |  |  |  |  | 2020-08-03 | 2020-08-03 | 0d | 149d | 0d | as late as possible |  |  |  |  |  |  |
| 80 | 1.5 | **Project Closing Phase** |  | 16d? | 2020-08-04 | 2020-08-25 |  | 41% | 9.41d? | 2020-08-05 | 2020-08-04 | 2020-08-25 | 16d? |  |  | as late as possible |  | 4.6h | 3.8h | 414 | 414 | 342 |
| 81 | 1.5.1 | Preparing the status reports |  | 7d? | 2020-08-05 A | 2020-08-13 A |  | 100% |  |  | 2020-08-05 | 2020-08-13 | 7d? |  |  | as late as possible | Project Manager [1%] | 3.8h | 3.8h | 342 | 342 | 342 |
| 82 | 1.5.2 | Preparing the report on benefits realization |  | 4d? | 2020-08-12 | 2020-08-17 |  |  |  |  | 2020-08-12 | 2020-08-17 | 4d? | 155d | 0d | as late as possible | Project Manager [1%] | 0.32h |  | 28.8 | 28.8 |  |
| 83 | 1.5.3 | Preparing the report on risks |  | 3d? | 2020-08-18 | 2020-08-20 | 82 |  |  |  | 2020-08-18 | 2020-08-20 | 3d? | 155d | 0d | as late as possible | Project Manager [1%] | 0.24h |  | 21.6 | 21.6 |  |
| 84 | 1.5.4 | Project performance reporting |  | 2d? | 2020-08-21 | 2020-08-24 | 83 |  |  |  | 2020-08-21 | 2020-08-24 | 2d? | 155d | 0d | as late as possible | Project Manager [1%] | 0.16h |  | 14.4 | 14.4 |  |
| 85 | 1.5.5 | Report on lessons learnt |  | 1d? | 2020-08-25 | 2020-08-25 |  |  |  |  | 2020-08-25 | 2020-08-25 | 1d? | 164d | 0d | as late as possible | Project Manager [1%] | 0.08h |  | 7.2 | 7.2 |  |
| 86 | 1.5.6 | Project Closing Phase End | milestone | 0d | 2020-08-25 | 2020-08-25 |  |  |  |  | 2020-08-25 | 2020-08-25 | 0d | 165d | 0d | as late as possible |  |  |  |  |  |  |
