# Installation of Antenna on a vessel

Schedule from MS Project, 2021-09-23 to 2022-03-25, costs in $.
Schedule and Budgeting

## Calendars

- Standard: Mon-Fri 08:00-12:00, 13:00-17:00; Sat-Sun off. Exceptions (off unless hours are given): 2022-03-12 08:00-12:00, 13:00-17:00, 2022-03-19 to 2022-03-20 08:00-12:00, 13:00-17:00.

## Resources

| Resource | Rate |
| --- | --- |
| Carnival |  |
| Project Manager |  |
| Shipping/Receiving | 25 |
| Operation Engineer | 45 |
| Field Engineer | 35 |
| Built & Test | 35 |

## Schedule

| ID | WBS | Task | Duration | Start | Finish | Predecessors | Total slack | Free slack | Constraint | Resources | Work | Cost |
| --- | --- | --- | --- | --- | --- | --- | --- | --- | --- | --- | --- | --- |
| 1 | 1 | **Customer** | 112d? | 2021-10-01 | 2022-03-07 |  | 17d |  |  |  | 80h |  |
| 2 | 1.1 | Request of Service | 3d? | 2021-10-01 | 2021-10-05 |  | 124d | 6d | finish no earlier than 2021-10-05 | Carnival | 24h |  |
| 3 | 1.2 | Agree on Service | 2d | 2021-10-14 | 2021-10-15 | 2 | 118d |  | finish no earlier than 2021-10-15 | Carnival | 16h |  |
| 4 | 1.3 | **Prepare Vessel to Receive Equipment** | 20d? | 2022-02-01 | 2022-02-28 |  |  |  |  |  | 40h |  |
| 5 | 1.3.1 | Receive Equipment | 5d? | 2022-03-01 | 2022-03-07 |  | 17d |  | finish no earlier than 2022-03-07 | Carnival | 40h |  |
| 6 | 2 | **Project Management** | 134d? | 2021-09-24 | 2022-03-25 |  | 0d |  |  |  | 928h | 274,200 |
| 7 | 2.1 | Kick off Meeting | 9d? | 2021-10-04 | 2021-10-14 |  | 119d |  | start no earlier than 2021-10-04 | Project Manager | 72h |  |
| 8 | 2.2 | Documentation | 12d? | 2021-10-14 | 2021-10-29 |  | 108d |  | start no earlier than 2021-10-14 | Project Manager | 96h |  |
| 9 | 2.3 | Purchase of equipment | 44d? | 2021-10-22 | 2021-12-22 |  | 70d |  | finish no earlier than 2021-12-22 | Project Manager | 352h | 250,000 |
| 10 | 2.4 | Ship Equipment to Vessel | 46d? | 2021-12-22 | 2022-02-23 |  | 25d |  | start no earlier than 2021-12-22 | Shipping/Receiving | 368h | 24,200 |
| 11 | 2.5 | Request Field Engineer | 3d? | 2022-02-22 | 2022-02-24 |  | 24d |  | finish no earlier than 2022-02-24 | Project Manager | 24h |  |
| 12 | 2.6 | Project Close Out | 1d? | 2022-03-25 | 2022-03-25 |  | 0d |  | start no earlier than 2022-03-25 | Project Manager | 8h |  |
| 13 | 2.7 | Project Review/Lesson learn | 1d? | 2021-09-24 | 2021-09-24 |  | 133d |  | start no earlier than 2021-09-24 | Project Manager | 8h |  |
| 14 | 3 | **Operation Engineer** | 111d? | 2021-10-14 | 2022-03-16 |  | 9d |  |  |  | 408h | 18,280 |
| 15 | 3.1 | Configuration Method | 41d? | 2021-10-14 | 2021-12-09 |  | 79d |  | finish no earlier than 2021-12-09 | Operation Engineer | 328h | 14,760 |
| 16 | 3.2 | **Work with Field Engineer** | 7d? | 2022-03-09 | 2022-03-16 |  |  |  |  | Operation Engineer | 72h | 3,160 |
| 17 | 3.2.1 | Complete SAT/CAT with Customer | 1d? | 2022-03-16 | 2022-03-16 |  | 9d |  | start no earlier than 2022-03-16 | Operation Engineer; Field Engineer | 16h | 640 |
| 18 | 3.3 | Setup Monitoring | 1d? | 2022-03-16 | 2022-03-16 |  | 9d |  | start no earlier than 2022-03-16 | Operation Engineer | 8h | 360 |
| 19 | 4 | **Built and Test Engineer** | 68d? | 2021-11-22 | 2022-02-23 |  | 25d |  |  |  | 1216h | 37,760 |
| 20 | 4.1 | **Configure Equipment** | 8d? | 2021-12-01 | 2021-12-10 |  | 78d |  |  |  | 128h | 5,120 |
| 21 | 4.1.1 | Test Equipment | 8d? | 2021-12-01 | 2021-12-10 |  | 78d |  | finish no earlier than 2021-12-10 | Built & Test; Operation Engineer | 128h | 5,120 |
| 22 | 4.2 | Prepare Equipment for Shipping | 68d? | 2021-11-22 | 2022-02-23 |  | 25d |  | finish no earlier than 2022-02-23 | Built & Test; Shipping/Receiving | 1088h | 32,640 |
| 23 | 5 | **Field Engineer** | 133d? | 2021-09-23 | 2022-03-23 |  | 2d |  |  |  | 200h | 9,100 |
| 24 | 5.1 | Prepare for Travel | 3d? | 2022-03-08 | 2022-03-10 |  | 14d |  | finish no earlier than 2022-03-10 | Field Engineer | 24h | 1,640 |
| 25 | 5.2 | Request documents | 1d? | 2022-03-07 | 2022-03-07 |  | 17d |  | start no earlier than 2022-03-07 | Field Engineer | 8h | 280 |
| 26 | 5.3 | Travel to site | 3d? | 2022-03-09 | 2022-03-11 |  | 13d |  | finish no earlier than 2022-03-11 | Field Engineer | 24h | 840 |

| ID | WBS | Task | Duration | Start | Finish | Predecessors | Total slack | Free slack | Constraint | Resources | Work | Cost |
| --- | --- | --- | --- | --- | --- | --- | --- | --- | --- | --- | --- | --- |
| 27 | 5.4 | **Perform work per SOW** | 6d? | 2022-03-12 | 2022-03-18 |  | 7d |  |  | Field Engineer | 96h | 3,360 |
| 28 | 5.4.1 | Install equipment | 5d? | 2022-03-12 | 2022-03-17 |  | 7d | 0d | finish no earlier than 2022-03-17 | Field Engineer | 40h | 1,400 |
| 29 | 5.4.2 | Complete work/get document signed | 1d? | 2022-03-18 | 2022-03-18 | 28 | 7d |  |  | Field Engineer | 8h | 280 |
| 30 | 5.5 | Travel back home | 1d? | 2022-03-20 | 2022-03-20 |  | 5d |  | finish no earlier than 2022-03-20 | Field Engineer | 8h | 1,080 |
| 31 | 5.6 | **Complete documents** | 3d? | 2022-03-21 | 2022-03-23 |  | 2d |  |  |  | 32h | 1,120 |
| 32 | 5.6.1 | Redline document | 1d? | 2022-03-21 | 2022-03-21 |  | 4d |  | start no earlier than 2022-03-21 | Field Engineer | 8h | 280 |
| 33 | 5.6.2 | Upload document to share drive | 3d? | 2022-03-21 | 2022-03-23 |  | 2d |  | finish no earlier than 2022-03-23 | Field Engineer | 24h | 840 |
| 34 | 5.7 | Complete expense | 1d? | 2021-09-23 | 2021-09-23 |  | 134d |  | start no earlier than 2021-09-23 | Field Engineer | 8h | 780 |
