# PJM Repository Plan

Schedule from MS Project, 2020-07-01 to 2020-11-13.
Northeastern University

## Calendars

- Standard: Mon-Fri 08:00-12:00, 13:00-17:00; Sat-Sun off.

## Resources

| Resource |
| --- |
| Project Team |
| Sponsor |
| Procurement |

## Schedule

| ID | WBS | Task | Duration | Start | Finish | Predecessors | Total slack | Resources | Work |
| --- | --- | --- | --- | --- | --- | --- | --- | --- | --- |
| 1 | 1 | **PJM Template Repository** | 98d | 2020-07-01 | 2020-11-13 |  | 0d |  | 1608h |
| 2 | 1.1 | **Initation/ Plan** | 43d | 2020-07-01 | 2020-08-28 |  | 0d |  | 344h |
| 3 | 1.1.1 | Create project charter | 5d | 2020-07-01 | 2020-07-07 |  | 0d | Project Team | 40h |
| 4 | 1.1.2 | Approve project charter | 5d | 2020-07-08 | 2020-07-14 | 3 | 0d | Sponsor | 40h |
| 5 | 1.1.3 | Create requirements document | 10d | 2020-07-15 | 2020-07-28 | 4 | 0d | Project Team | 80h |
| 6 | 1.1.4 | Approve requirements document | 5d | 2020-07-29 | 2020-08-04 | 5 | 0d | Sponsor | 40h |
| 7 | 1.1.5 | Create project management plan | 10d | 2020-08-05 | 2020-08-18 | 6 | 0d | Project Team | 80h |
| 8 | 1.1.6 | Review/revise project management plan | 5d | 2020-08-19 | 2020-08-25 | 7 | 0d | Project Team | 40h |
| 9 | 1.1.7 | Approve project management plan | 3d | 2020-08-26 | 2020-08-28 | 8 | 0d | Sponsor | 24h |
| 10 | 1.2 | **Project Execution** | 53d | 2020-08-31 | 2020-11-11 |  | 1d |  | 424h |
| 11 | 1.2.1 | Manage issues, risks, changes | 53d | 2020-08-31 | 2020-11-11 | 9 | 1d | Project Team | 424h |
| 12 | 1.2.2 | Communicate project status | 53d | 2020-08-31 | 2020-11-11 | 9 | 1d |  |  |
| 13 | 1.3 | **Design and Development** | 42d | 2020-08-31 | 2020-10-27 |  | 0d |  | 528h |
| 14 | 1.3.1 | **Technology procurement** | 18d | 2020-08-31 | 2020-09-23 |  | 0d |  | 144h |
| 15 | 1.3.1.1 | Research available technologies/vendors | 10d | 2020-08-31 | 2020-09-11 | 9 | 0d | Project Team | 80h |
| 16 | 1.3.1.2 | Negotiate Contract | 5d | 2020-09-14 | 2020-09-18 | 15 | 0d | Procurement | 40h |
| 17 | 1.3.1.3 | Sign Contract/Obtain license | 3d | 2020-09-21 | 2020-09-23 | 16 | 0d | Procurement | 24h |
| 18 | 1.3.2 | **SIte Wireframe** | 10d | 2020-09-24 | 2020-10-07 |  | 0d |  | 56h |
| 19 | 1.3.2.1 | Create site requirements | 5d | 2020-09-24 | 2020-09-30 | 17 | 0d | Project Team | 40h |
| 20 | 1.3.2.2 | Create site Wireframe | 2d | 2020-10-01 | 2020-10-02 | 19 | 0d | Project Team | 16h |
| 21 | 1.3.2.3 | Revew/ revise site wireframe | 3d | 2020-10-05 | 2020-10-07 | 20 | 0d |  |  |
| 22 | 1.3.3 | **Developed website application** | 4d | 2020-10-08 | 2020-10-13 |  | 0d |  | 32h |
| 23 | 1.3.3.1 | Create Repository Site | 3d | 2020-10-08 | 2020-10-12 | 21 | 0d | Project Team | 24h |
| 24 | 1.3.3.2 | Review/revise/approve respository site | 1d | 2020-10-13 | 2020-10-13 | 23 | 0d | Project Team | 8h |

| ID | WBS | Task | Duration | Start | Finish | Predecessors | Total slack | Free slack | Resources | Work |
| --- | --- | --- | --- | --- | --- | --- | --- | --- | --- | --- |
| 25 | 1.3.4 | **Templates collection** | 40d | 2020-08-31 | 2020-10-23 |  | 9d |  |  | 280h |
| 26 | 1.3.4.1 | Request templates | 15d | 2020-08-31 | 2020-09-18 | 9 | 9d | 0d | Project Team | 120h |
| 27 | 1.3.4.2 | Review/ revise templates | 20d | 2020-09-21 | 2020-10-16 | 26 | 9d | 0d | Project Team | 160h |
| 28 | 1.3.4.3 | Upload approved Templates | 5d | 2020-10-19 | 2020-10-23 | 27, 24 | 9d | 0d |  |  |
| 29 | 1.3.5 | **Project Product Evaluation** | 2d | 2020-10-26 | 2020-10-27 |  | 9d |  |  | 16h |
| 30 | 1.3.5.1 | **Repository Testing** | 2d | 2020-10-26 | 2020-10-27 |  | 9d |  |  | 16h |
| 31 | 1.3.5.1.1 | Test Repository Site | 1d | 2020-10-26 | 2020-10-26 | 28 | 9d | 0d | Project Team | 8h |
| 32 | 1.3.5.1.2 | Revise/ approve Repository Site | 1d | 2020-10-27 | 2020-10-27 | 31 | 9d | 7d | Project Team | 8h |
| 33 | 1.4 | **Final Version Release** | 53d | 2020-08-31 | 2020-11-11 |  | 2d |  |  | 216h |
| 34 | 1.4.1 | Create Alumni Communication Plan | 3d | 2020-08-31 | 2020-09-02 | 9 | 44d | 0d | Project Team | 24h |
| 35 | 1.4.2 | Create Student Communication Plan | 3d | 2020-08-31 | 2020-09-02 | 9 | 45d | 0d | Project Team | 24h |
| 36 | 1.4.3 | Communicate to alumni | 5d | 2020-09-03 | 2020-09-09 | 34 | 44d | 42d | Project Team | 40h |
| 37 | 1.4.4 | Communicate to students | 5d | 2020-09-03 | 2020-09-09 | 35 | 45d | 42d | Project Team | 40h |
| 38 | 1.4.5 | Provide access to alumni | 3d | 2020-11-09 | 2020-11-11 | 40, 36 | 2d |  | Project Team | 24h |
| 39 | 1.4.6 | Provide access to students | 2d | 2020-11-09 | 2020-11-10 | 40, 37 | 3d |  | Project Team | 16h |
| 40 | 1.4.7 | Release Final Version of the Website | 1d | 2020-11-06 | 2020-11-06 | 32, 41, 47 | 2d | 0d | Project Team | 8h |
| 41 | 1.4.8 | Create operational/ support plan | 5d | 2020-10-14 | 2020-10-20 | 24 | 14d | 12d | Project Team | 40h |
| 42 | 1.5 | **Lessons learned** | 5d | 2020-11-06 | 2020-11-12 |  | 0d |  |  | 40h |
| 43 | 1.5.1 | Collect Lessons Learned | 3d | 2020-11-06 | 2020-11-10 | 47 | 0d |  | Project Team | 24h |
| 44 | 1.5.2 | Review Lessons Learned | 2d | 2020-11-11 | 2020-11-12 | 43 | 0d |  | Project Team | 16h |
| 45 | 1.6 | **Co-op/Intern onboard process plan** | 23d | 2020-10-14 | 2020-11-13 |  | 0d |  |  | 56h |
| 46 | 1.6.1 | Create Co-op/Intern onboard process plan | 7d | 2020-10-14 | 2020-10-22 | 24 | 0d |  | Project Team | 56h |
| 47 | 1.6.2 | Execute Co-op/Intern onboard process plan | 10d | 2020-10-23 | 2020-11-05 | 46 | 0d |  |  |  |
| 48 | 1.6.3 | Project End | 1d | 2020-11-13 | 2020-11-13 | 44, 40, 11, 12 | 0d |  |  |  |
