# Online Retail Grocery Store website’s software development

Schedule from MS Project, 2021-04-05 to 2022-01-20, status date 2021-04-22, costs in $.

## Calendars

- Standard: Mon-Fri 08:00-12:00, 13:00-17:00; Sat-Sun off. Exceptions (off unless hours are given): 2021-05-31 (Memorial Day), 2021-09-06 (Labor Day), 2021-11-25 to 2021-11-26 (Thanks Giving and Black Friday), 2021-12-24 (Pre-Christmas).

## Resources

| Resource | Group | Rate | Cost per use |
| --- | --- | --- | --- |
| Naga Srinivas | Project Manager | 400 |  |
| Boniface Barrack | Project Sponsor | 350 |  |
| Josephine Joel | Business Analyst | 300 |  |
| Ryan Williamson | Lead Developer | 200 |  |
| Ashley Robertson | Developer | 150 |  |
| Diana James | Quality Assurance Analyst | 100 |  |
| Shaun Micheals | Web Application Architect | 250 |  |
| PNC Bank |  |  |  |
| Federal Credit Union |  |  |  |
| Microsoft |  |  |  |
| State of Ohio |  |  |  |
| Vendor |  |  |  |
| Laptops |  |  | 1500 |
| Printers |  |  | 2000 |
| Desktops |  |  | 2400 |
| Furniture |  |  | 2000 |

## Schedule

| ID | WBS | Task | Type | Duration | Start | Finish | Predecessors | Baseline start | Baseline finish | Baseline duration | Total slack | Free slack | Constraint | Resources | Work | Cost | Baseline cost | hours |
| --- | --- | --- | --- | --- | --- | --- | --- | --- | --- | --- | --- | --- | --- | --- | --- | --- | --- | --- |
| 1 | 1 | **Online Retail Grocery Store website’s software development** |  | 190d? | 2021-04-05 | 2021-12-31 |  | 2021-04-05 | 2021-12-31 | 190d? |  |  |  |  | 2298.67h | 840,824.75 | 813,624.75 | 1800 |
| 2 | 2 | **Project Initiation** |  | 15d? | 2021-04-05 | 2021-04-23 |  | 2021-04-05 | 2021-07-01 | 63d? |  |  |  |  | 106h | 60,924.75 | 60,924.75 |  |
| 3 | 2.1 | Project Charter Review |  | 1d? | 2021-04-05 | 2021-04-05 |  | 2021-04-05 | 2021-04-05 | 1d? | 193.38d | 2d |  | Desktops [50%]; Diana James [50%] | 4h | 2,800 | 2,800 |  |
| 4 | 2.2 | Project proposal Evaluation |  | 2d | 2021-04-07 | 2021-04-08 | 3FS-1d | 2021-04-07 | 2021-04-08 | 2d | 191.38d | 2d | start no earlier than 2021-04-07 | Microsoft [0.1%]; Ryan Williamson [50%] | 8h | 3,000 | 3,000 |  |
| 5 | 2.3 | Project Kick off Meeting |  | 0.62d | 2021-04-12 | 2021-04-12 | 4FS-1d | 2021-04-12 | 2021-04-12 | 0.62d | 189.38d | 3.38d | start no earlier than 2021-04-12 | Printers [50%]; Ashley Robertson | 5h | 2,750 | 2,750 |  |
| 6 | 2.4 | Project Vision and Mission Statement |  | 2.66d? | 2021-04-13 | 2021-04-15 |  | 2021-04-13 | 2021-04-15 | 2.66d? | 195.34d |  | start no earlier than 2021-04-13 | Boniface Barrack [50%]; Naga Srinivas [50%] | 17h | 6,268.75 | 6,268.75 |  |
| 7 | 2.5 | Defining Problem Statement |  | 0.8d? | 2021-04-14 | 2021-04-19 |  | 2021-04-14 | 2021-04-19 | 0.8d? | 193.2d |  | start no earlier than 2021-04-14 | Naga Srinivas [62.5%]; Desktops; Furniture; Laptops; Microsoft [0.1%]; Federal Credit Union [0.1%] | 4h | 8,156 | 8,156 |  |
| 8 | 2.6 | Onboarding of project resources |  | 2d? | 2021-04-15 | 2021-04-16 | 5FS-1d | 2021-04-15 | 2021-04-16 | 2d? | 186d | 0d | start no earlier than 2021-04-15 | Boniface Barrack [50%]; Naga Srinivas [50%]; Desktops; Furniture; Laptops; Microsoft [0.1%] | 12h | 10,300 | 10,300 |  |
| 9 | 2.7 | Documentation of Project Charter |  | 3d | 2021-04-16 | 2021-04-20 | 8FS-1d | 2021-04-16 | 2021-04-20 | 3d | 186d | 0d | start no earlier than 2021-04-15 | Naga Srinivas [91.7%]; Desktops; Furniture; Laptops; Microsoft [0.1%]; Ryan Williamson; State of Ohio [0.1%]; Vendor [0.1%] | 22h | 14,700 | 14,700 |  |
| 10 | 2.8 | Signatures on Project Charter Team |  | 2d? | 2021-04-20 | 2021-04-21 | 9FS-1d | 2021-04-20 | 2021-04-21 | 2d? | 186d | 0d | start no earlier than 2021-04-19 | Boniface Barrack [62.5%]; Naga Srinivas [62.5%] | 10h | 3,750 | 3,750 |  |
| 11 | 2.9 | Defining Responsibilties and goals |  | 1d? | 2021-04-22 | 2021-04-22 | 10SS | 2021-04-22 | 2021-04-22 | 1d? | 186d | 0d | start no earlier than 2021-04-20 | Naga Srinivas | 8h | 3,200 | 3,200 |  |
| 12 | 2.10 | Project Charter Document completion |  | 2d? | 2021-04-22 | 2021-04-23 | 11FS-1d | 2021-04-22 | 2021-04-23 | 2d? | 186d | 13d | start no earlier than 2021-04-21 | Boniface Barrack; Naga Srinivas | 16h | 6,000 | 6,000 |  |
| 13 | 2.11 | Project Charter Approved | milestone | 0d | 2021-04-23 | 2021-04-23 |  | 2021-04-23 | 2021-04-23 | 0d | 190d | 14d | start no earlier than 2021-04-23 | State of Ohio |  |  |  |  |
| 14 | 2.12 | Project Initiation Phase End | milestone | 0d | 2021-04-23 | 2021-04-23 |  | 2021-04-23 | 2021-04-23 | 0d | 189d | 24d | start no earlier than 2021-04-23 |  |  |  |  |  |
| 15 | 3 | **Project Planning** |  | 45d? | 2021-04-26 | 2021-06-28 |  | 2021-04-26 | 2021-06-28 | 45d? |  |  |  |  | 622h | 224,500 | 224,500 |  |
| 16 | 3.1 | Review Project Documentation | milestone | 0d? | 2021-04-26 | 2021-04-30 |  | 2021-04-26 | 2021-04-30 | 0d? | 179d | 0d | start no earlier than 2021-04-26 | Naga Srinivas; Desktops; State of Ohio [0.1%] |  | 3,200 | 3,200 |  |
| 17 | 3.2 | Create a PMP Draft Template |  | 2d? | 2021-04-29 | 2021-04-30 | 16FF | 2021-04-29 | 2021-04-30 | 2d? | 182.33d | 4d | start no earlier than 2021-04-27 | Naga Srinivas [50%]; Desktops; Furniture; Laptops; Microsoft [0.1%]; Printers; Diana James | 8h | 11,100 | 11,100 |  |
| 18 | 3.3 | Review the draft PMP with project team |  | 2.83d? | 2021-05-03 | 2021-05-10 | 16, 17FF+1d | 2021-05-03 | 2021-05-10 | 2.83d? | 178.33d |  | start no earlier than 2021-04-28 | Boniface Barrack [50%]; Naga Srinivas [50%]; Furniture; Laptops; Microsoft [0.1%]; Vendor [0.1%] | 18h | 10,300 | 10,300 |  |
| 19 | 3.4 | Review/Approve PMP with Project Sponsor |  | 2d? | 2021-04-29 | 2021-05-04 |  | 2021-04-29 | 2021-05-04 | 2d? | 182.33d | 0d | start no earlier than 2021-04-29 | Boniface Barrack; Naga Srinivas | 16h | 6,000 | 6,000 |  |
| 20 | 3.5 | PMP Approval | milestone | 0d | 2021-04-29 | 2021-04-29 | 19SF | 2021-04-29 | 2021-04-29 | 0d | 186d |  | start no earlier than 2021-04-29 | State of Ohio |  |  |  |  |
| 21 | 3.6 | **Tool and Technology Selection** |  | 7.67d? | 2021-04-30 | 2021-05-11 |  | 2021-04-30 | 2021-05-11 | 7.67d? | 177.33d |  |  |  | 24h | 10,700 | 10,700 |  |
| 22 | 3.6.1 | MS SQL |  | 1d? | 2021-04-30 | 2021-05-03 |  | 2021-04-30 | 2021-05-03 | 1d? | 183d | 7.67d |  | Shaun Micheals; Desktops; Laptops; Microsoft [0.1%] | 8h | 5,900 | 5,900 |  |
| 23 | 3.6.2 | Dot Net Technology |  | 1.67d? | 2021-05-03 | 2021-05-11 | 22SF | 2021-05-03 | 2021-05-11 | 1.67d? | 177.33d |  | start no earlier than 2021-05-03 | Shaun Micheals; Boniface Barrack | 16h | 4,800 | 4,800 |  |
| 24 | 3.6.3 | License Approval on Tool and Technology | milestone | 0d | 2021-05-03 | 2021-05-03 |  | 2021-05-03 | 2021-05-03 | 0d | 184d |  | start no earlier than 2021-05-03 | Boniface Barrack; Naga Srinivas |  |  |  |  |
| 25 | 3.7 | Development of Organizational Chart which includes who reports to whom |  | 4d? | 2021-05-04 | 2021-05-10 |  | 2021-05-04 | 2021-05-10 | 4d? | 178.17d |  | start no earlier than 2021-05-04 | Josephine Joel; Naga Srinivas | 32h | 11,200 | 11,200 |  |

| ID | WBS | Task | Type | Duration | Start | Finish | Predecessors | Baseline start | Baseline finish | Baseline duration | Total slack | Free slack | Constraint | Resources | Work | Cost | Baseline cost |
| --- | --- | --- | --- | --- | --- | --- | --- | --- | --- | --- | --- | --- | --- | --- | --- | --- | --- |
| 26 | 3.8 | **Template selection of Website** |  | 3d? | 2021-05-06 | 2021-05-10 |  | 2021-05-06 | 2021-05-10 | 3d? |  |  |  |  | 24h | 13,500 | 13,500 |
| 27 | 3.8.1 | Template selection for desktop |  | 2d? | 2021-05-06 | 2021-05-10 |  | 2021-05-06 | 2021-05-10 | 2d? | 165.67d | 0d | start no earlier than 2021-05-06 | Vendor [0.1%]; Boniface Barrack; Desktops; Furniture; Laptops; Shaun Micheals | 16h | 10,700 | 10,700 |
| 28 | 3.8.2 | Template selection for Mobile |  | 1d? | 2021-05-11 | 2021-05-27 | 27FS+1d | 2021-05-11 | 2021-05-27 | 1d? | 165.67d |  | start no earlier than 2021-05-07 | Vendor [0.1%]; Boniface Barrack | 8h | 2,800 | 2,800 |
| 29 | 3.9 | **Authorization Set up** |  | 4.67d? | 2021-05-12 | 2021-05-18 | 26FS+1d | 2021-05-12 | 2021-05-18 | 4.67d? | 172.33d |  |  |  | 112h | 37,100 | 37,100 |
| 30 | 3.9.1 | Authorization includes email set up and permssion to the sharepoint for accessing project relateddocuments |  | 1d | 2021-05-17 | 2021-05-18 |  | 2021-05-17 | 2021-05-18 | 1d | 172.33d |  |  | Boniface Barrack | 8h | 2,800 | 2,800 |
| 31 | 3.9.2 | Uploading Project Documentation |  | 1d? | 2021-05-12 | 2021-05-12 | 13SS-1d | 2021-05-12 | 2021-05-12 | 1d? | 176d |  | start no earlier than 2021-05-11 | Naga Srinivas | 8h | 3,200 | 3,200 |
| 32 | 3.9.3 | Creating Project Communication Process |  | 4d | 2021-05-12 | 2021-05-17 | 12FS-1d | 2021-05-12 | 2021-05-17 | 4d | 173d |  | start no earlier than 2021-05-12 | Naga Srinivas; Boniface Barrack; Diana James; Furniture; Josephine Joel; Laptops; Microsoft [0.1%]; State of Ohio [0.1%] | 96h | 31,100 | 31,100 |
| 33 | 3.10 | **Application Environment Set-up** |  | 24d? | 2021-04-26 | 2021-05-27 |  | 2021-04-26 | 2021-05-27 | 24d? | 165d |  |  |  | 112h | 25,200 | 25,200 |
| 34 | 3.10.1 | Development Environment Set up |  | 4d | 2021-04-26 | 2021-04-29 |  | 2021-04-26 | 2021-04-29 | 4d | 177d | 12d |  | Ryan Williamson; Shaun Micheals | 32h | 7,200 | 7,200 |
| 35 | 3.10.2 | SIT Environment Set up |  | 2d | 2021-05-19 | 2021-05-20 | 34FS+1d | 2021-05-19 | 2021-05-20 | 2d | 165d | 0d | start no earlier than 2021-05-19 | Ryan Williamson; Shaun Micheals | 32h | 7,200 | 7,200 |
| 36 | 3.10.3 | Production Environment Set up |  | 1d? | 2021-05-24 | 2021-05-24 | 35FS+1d | 2021-05-24 | 2021-05-24 | 1d? | 165d | 0d |  | Ryan Williamson; Shaun Micheals | 16h | 3,600 | 3,600 |
| 37 | 3.10.4 | UAT Environment Set up |  | 2d | 2021-05-26 | 2021-05-27 | 14FS-1d, 36FS+1d | 2021-05-26 | 2021-05-27 | 2d | 165d |  | start no earlier than 2021-05-24 | Ryan Williamson; Shaun Micheals | 32h | 7,200 | 7,200 |
| 38 | 3.11 | **Requirement analysis of the customer** |  | 18d? | 2021-05-26 | 2021-06-21 |  | 2021-05-26 | 2021-06-21 | 18d? | 149d |  |  |  | 176h | 59,800 | 59,800 |
| 39 | 3.11.1 | Getting an idea or overview of the website |  | 2d | 2021-05-26 | 2021-05-27 |  | 2021-05-26 | 2021-05-27 | 2d | 165d |  | finish no earlier than 2021-05-27 | Josephine Joel | 16h | 4,800 | 4,800 |
| 40 | 3.11.3 | Identification of Stakeholders |  | 1d? | 2021-05-28 | 2021-05-28 |  | 2021-05-28 | 2021-05-28 | 1d? | 159d | 1d | start no earlier than 2021-05-28 | Josephine Joel | 8h | 2,400 | 2,400 |
| 41 | 3.11.3 | Gather requirements for the web application |  | 2d | 2021-06-01 | 2021-06-02 | 40FS-1d | 2021-06-01 | 2021-06-02 | 2d | 158d | 0d | start no earlier than 2021-06-01 | Josephine Joel; Desktops; Diana James; Furniture; Laptops; Microsoft [0.1%]; Ryan Williamson | 48h | 15,500 | 15,500 |
| 42 | 3.11.4 | Conducting Meeting and Surveys |  | 1d | 2021-06-04 | 2021-06-04 | 41FS+1d | 2021-06-04 | 2021-06-04 | 1d | 158d | 0d | start no earlier than 2021-06-04 | Josephine Joel | 8h | 2,400 | 2,400 |
| 43 | 3.11.5 | Perform Stakeholder Analysis |  | 1d? | 2021-06-08 | 2021-06-08 | 42FS+1d | 2021-06-08 | 2021-06-08 | 1d? | 158d |  | start no earlier than 2021-06-07 | Josephine Joel | 8h | 2,400 | 2,400 |
| 44 | 3.11.6 | Determing Solution Approach |  | 2d | 2021-06-09 | 2021-06-14 |  | 2021-06-09 | 2021-06-14 | 2d | 154d |  | start no earlier than 2021-06-08 | Josephine Joel | 16h | 4,800 | 4,800 |
| 45 | 3.11.7 | Finding new enhanced needs |  | 1d? | 2021-06-10 | 2021-06-10 |  | 2021-06-10 | 2021-06-10 | 1d? | 151d | 2d | start no earlier than 2021-06-10 | Josephine Joel; Boniface Barrack; Desktops; Diana James; Federal Credit Union [0.1%]; Microsoft [0.1%]; Naga Srinivas; PNC Bank [0.1%]; State of Ohio [0.1%] | 32h | 11,600 | 11,600 |
| 46 | 3.11.8 | Creation requirements draft |  | 1d? | 2021-06-11 | 2021-06-11 | 45SS-1d | 2021-06-11 | 2021-06-11 | 1d? | 150d | 0d | start no earlier than 2021-06-11 | Josephine Joel | 8h | 2,400 | 2,400 |
| 47 | 3.11.9 | Document those requirements into Business Requirement Document and Funtional Requirement Document i.e. FRD & BRD |  | 4d | 2021-06-15 | 2021-06-18 | 46FS+1d | 2021-06-15 | 2021-06-18 | 4d | 150d | 0d | start no earlier than 2021-06-14 | Josephine Joel [50%]; PNC Bank [0.1%] | 16h | 4,800 | 4,800 |
| 48 | 3.11.10 | Documented BRD and FRD | milestone | 0d | 2021-06-18 | 2021-06-18 | 47FS-1d | 2021-06-18 | 2021-06-18 | 0d | 151d |  | start no earlier than 2021-06-15 |  |  |  |  |
| 49 | 3.11.11 | Business Analysis Establishment |  | 2d? | 2021-06-16 | 2021-06-17 |  | 2021-06-16 | 2021-06-17 | 2d? | 151d |  | start no earlier than 2021-06-16 | Josephine Joel [50%]; Laptops [500%] | 8h | 3,900 | 3,900 |
| 50 | 3.11.12 | Preparation of Requirement Traceability Matrix |  | 2d | 2021-06-18 | 2021-06-21 |  | 2021-06-18 | 2021-06-21 | 2d | 149d |  | start no earlier than 2021-06-17 | Josephine Joel [50%]; Desktops | 8h | 4,800 | 4,800 |

| ID | WBS | Task | Type | Duration | Start | Finish | Predecessors | Baseline start | Baseline finish | Baseline duration | Total slack | Free slack | Constraint | Resources | Work | Cost | Baseline cost |
| --- | --- | --- | --- | --- | --- | --- | --- | --- | --- | --- | --- | --- | --- | --- | --- | --- | --- |
| 51 | 3.12 | **Project Risk Analysis** |  | 47d? | 2021-04-26 | 2021-06-30 |  | 2021-04-26 | 2021-06-30 | 47d? | 142d |  |  |  | 100h | 36,400 | 36,400 |
| 52 | 3.12.1 | Analysis of risks involved |  | 4d | 2021-04-26 | 2021-04-29 |  | 2021-04-26 | 2021-04-29 | 4d | 177d | 35d |  | Shaun Micheals; Microsoft [0.1%]; Ryan Williamson [50%] | 32h | 7,200 | 7,200 |
| 53 | 3.12.2 | Registering the risks |  | 1d? | 2021-06-22 | 2021-06-22 | 52FS+1d | 2021-06-22 | 2021-06-22 | 1d? | 142d | 0d | start no earlier than 2021-06-22 | Naga Srinivas [50%]; Desktops; Furniture | 4h | 6,000 | 6,000 |
| 54 | 3.12.3 | Documenting the risks involved |  | 2d | 2021-06-24 | 2021-06-25 | 53FS+1d | 2021-06-24 | 2021-06-25 | 2d | 142d | 0d | start no earlier than 2021-06-23 | Josephine Joel; Naga Srinivas | 32h | 11,200 | 11,200 |
| 55 | 3.12.4 | Development of WBS |  | 2d | 2021-06-29 | 2021-06-30 | 54FS+1d | 2021-06-29 | 2021-06-30 | 2d | 142d |  | start no earlier than 2021-06-25 | Naga Srinivas; Boniface Barrack | 32h | 12,000 | 12,000 |
| 56 | 3.12.5 | Work Breakdown Structure Development | milestone | 0d | 2021-06-30 | 2021-06-30 |  | 2021-06-30 | 2021-06-30 | 0d | 143d |  | start no earlier than 2021-06-30 |  |  |  |  |
| 57 | 3.12.6 | Project Planning Phase End | milestone | 0d | 2021-06-30 | 2021-06-30 |  | 2021-06-30 | 2021-06-30 | 0d | 143d |  | start no earlier than 2021-06-30 |  |  |  |  |
| 58 | 4 | **Project Execution** |  | 81d? | 2021-07-01 | 2021-10-22 |  | 2021-07-01 | 2021-10-22 | 81d? |  |  |  |  | 848h | 195,300 | 195,300 |
| 59 | 4.1 | **Web Design Architure** |  | 8d | 2021-07-01 | 2021-07-12 |  | 2021-07-01 | 2021-07-12 | 8d | -51d | 0d |  |  | 80h | 23,600 | 23,600 |
| 60 | 4.1.1 | Getting Server, memory and communication interfaces ready |  | 3d | 2021-07-01 | 2021-07-05 |  | 2021-07-01 | 2021-07-05 | 3d | -46d | 0d |  | Shaun Micheals; Desktops; Microsoft [0.1%]; Printers | 24h | 10,400 | 10,400 |
| 61 | 4.1.2 | Building functionality aspects |  | 4d | 2021-07-02 | 2021-07-12 | 60FF-1d | 2021-07-02 | 2021-07-12 | 4d | -51d | 0d | start no earlier than 2021-07-02 | Shaun Micheals; Ryan Williamson | 32h | 7,200 | 7,200 |
| 62 | 4.1.3 | Building visual appearance as User Interface design |  | 3d | 2021-07-06 | 2021-07-08 |  | 2021-07-06 | 2021-07-08 | 3d | -53d | 0d | start no earlier than 2021-07-06 | Shaun Micheals | 24h | 6,000 | 6,000 |
| 63 | 4.2 | **Business Analysis** |  | 21d? | 2021-07-08 | 2021-08-05 |  | 2021-07-08 | 2021-08-05 | 21d? | -69d | 0d |  |  | 160h | 48,000 | 48,000 |
| 64 | 4.2.1 | Organizing, verifying and validating the gathered requirements |  | 3d | 2021-07-08 | 2021-07-12 | 62FS-1d | 2021-07-08 | 2021-07-12 | 3d | -53d | 0d |  | Josephine Joel | 24h | 7,200 | 7,200 |
| 65 | 4.2.2 | Analysis of change requirements |  | 2d | 2021-07-14 | 2021-07-15 | 64FS-1d | 2021-07-14 | 2021-07-15 | 2d | -55d | 0d | start no earlier than 2021-07-14 | Josephine Joel | 16h | 4,800 | 4,800 |
| 66 | 4.2.3 | Translation of the business requirements into technicality for development purpose |  | 2d? | 2021-07-16 | 2021-07-19 | 65FS-1d | 2021-07-16 | 2021-07-19 | 2d? | -56d | 0d | start no earlier than 2021-07-16 | Josephine Joel | 16h | 4,800 | 4,800 |
| 67 | 4.2.4 | Workshop sessions with vendors |  | 2d | 2021-07-20 | 2021-07-21 |  | 2021-07-20 | 2021-07-21 | 2d | -59d | 0d | start no earlier than 2021-07-20 | Josephine Joel | 16h | 4,800 | 4,800 |
| 68 | 4.2.5 | Use Case Diagrams |  | 1d? | 2021-07-22 | 2021-07-22 | 67 | 2021-07-22 | 2021-07-22 | 1d? | -59d | 0d | start no earlier than 2021-07-22 | Josephine Joel | 8h | 2,400 | 2,400 |
| 69 | 4.2.6 | Conduct Unit Testing Activites |  | 2d | 2021-07-23 | 2021-07-26 |  | 2021-07-23 | 2021-07-26 | 2d | -61d | 0d | start no earlier than 2021-07-23 | Josephine Joel | 16h | 4,800 | 4,800 |
| 70 | 4.2.7 | Performance Reporting and Progress tracking |  | 4d | 2021-07-27 | 2021-07-30 |  | 2021-07-27 | 2021-07-30 | 4d | -65d | 0d | start no earlier than 2021-07-27 | Josephine Joel | 32h | 9,600 | 9,600 |
| 71 | 4.2.8 | Working on Change Requests |  | 2d | 2021-08-02 | 2021-08-03 |  | 2021-08-02 | 2021-08-03 | 2d | -67d | 0d | start no earlier than 2021-08-02 | Josephine Joel | 16h | 4,800 | 4,800 |
| 72 | 4.2.9 | Updating the change documentation |  | 2d | 2021-08-04 | 2021-08-05 | 71SF+1d | 2021-08-04 | 2021-08-05 | 2d | -69d | 0d | start no earlier than 2021-08-04 | Josephine Joel | 16h | 4,800 | 4,800 |
| 73 | 4.3 | **Web application Development & Testing** |  | 79d? | 2021-07-01 | 2021-10-20 |  | 2021-07-01 | 2021-10-20 | 79d? | -122d | 0d |  |  | 608h | 123,700 | 123,700 |
| 74 | 4.3.1 | Review of the requirements or features for development |  | 1d? | 2021-07-01 | 2021-07-01 |  | 2021-07-01 | 2021-07-01 | 1d? | -58d | 0d |  | Ashley Robertson; Ryan Williamson | 16h | 2,800 | 2,800 |
| 75 | 4.3.1 | Coding or developing the requirements which meets the acceptance critieria |  | 3d | 2021-08-09 | 2021-08-11 | 74FS+1d | 2021-08-09 | 2021-08-11 | 3d | -83d | 0d | start no earlier than 2021-08-09 | Ashley Robertson; Ryan Williamson | 48h | 8,400 | 8,400 |
| 76 | 4.3.2 | Mobile application development |  | 2d | 2021-08-12 | 2021-08-13 |  | 2021-08-12 | 2021-08-13 | 2d | -75d | 0d | start no earlier than 2021-08-12 | Ashley Robertson; Ryan Williamson | 32h | 5,600 | 5,600 |
| 77 | 4.3.3 | Performing Unit Testing |  | 2d | 2021-08-16 | 2021-08-17 | 75FS-1d | 2021-08-16 | 2021-08-17 | 2d | -86d | 0d | finish no earlier than 2021-08-17 | Ashley Robertson | 16h | 2,400 | 2,400 |
| 78 | 4.3.4 | Perform Integration Tesing |  | 2d | 2021-08-18 | 2021-08-19 | 77FS-1d | 2021-08-18 | 2021-08-19 | 2d | -87d | 0d | start no earlier than 2021-08-18 | Ryan Williamson | 16h | 3,200 | 3,200 |
| 79 | 4.3.5 | Deploying the features into development envrionment and system integration test environment |  | 1d | 2021-08-20 | 2021-08-20 | 78FS-1d | 2021-08-20 | 2021-08-20 | 1d | -88d | 0d | start no earlier than 2021-08-20 | Ryan Williamson; Desktops; Laptops; Microsoft [0.1%] | 8h | 5,500 | 5,500 |
| 80 | 4.3.6 | Testing the features in development environment |  | 1d? | 2021-08-24 | 2021-08-24 | 79FS+1d | 2021-08-24 | 2021-08-24 | 1d? | -88d | 0d | start no earlier than 2021-08-23 | Ashley Robertson; Diana James; Ryan Williamson | 24h | 3,600 | 3,600 |
| 81 | 4.3.7 | Debugging the application |  | 2d? | 2021-08-25 | 2021-08-26 | 80FS-1d | 2021-08-25 | 2021-08-26 | 2d? | -84d | 0d | start no earlier than 2021-08-24 | Ashley Robertson; Ryan Williamson | 16h | 2,800 | 2,800 |
| 82 | 4.3.7 | Deployment of features into system integration test environment |  | 1d | 2021-08-25 | 2021-08-25 | 80 | 2021-08-25 | 2021-08-25 | 1d | -88d | 0d | start no earlier than 2021-08-25 | Ryan Williamson | 8h | 1,600 | 1,600 |
| 83 | 4.3.8 | Integration of new features in the application |  | 3d | 2021-08-27 | 2021-08-31 | 82FS+1d | 2021-08-27 | 2021-08-31 | 3d | -88d | 0d | start no earlier than 2021-08-26 | Ashley Robertson; Ryan Williamson | 48h | 8,400 | 8,400 |
| 84 | 4.3.9 | Deployment Accomplished | milestone | 0d | 2021-09-01 | 2021-09-01 | 83FS+1d | 2021-09-01 | 2021-09-01 | 0d | -88d | 0d | start no earlier than 2021-08-30 | Diana James |  |  |  |
| 85 | 4.3.10 | Test plan Review |  | 1d? | 2021-08-31 | 2021-08-31 |  | 2021-08-31 | 2021-08-31 | 1d? | -103d | 0d | start no earlier than 2021-08-31 | Diana James | 8h | 800 | 800 |
| 86 | 4.3.11 | Preparing the test plan |  | 3d | 2021-09-02 | 2021-09-07 | 85FS+1d | 2021-09-02 | 2021-09-07 | 3d | -103d | 0d | start no earlier than 2021-09-01 | Diana James | 24h | 2,400 | 2,400 |
| 87 | 4.3.12 | Preparing test scenarios |  | 2d | 2021-09-08 | 2021-09-16 |  | 2021-09-08 | 2021-09-16 | 2d | -98d | 0d | start no earlier than 2021-09-07 | Diana James | 16h | 1,600 | 1,600 |
| 88 | 4.3.13 | Preparing the test scripts as per organization template |  | 5d | 2021-09-09 | 2021-09-15 | 86FS+1d | 2021-09-09 | 2021-09-15 | 5d | -103d | 0d | start no earlier than 2021-09-09 | Diana James | 40h | 4,000 | 4,000 |
| 89 | 4.3.14 | Executing the test scripts and updating the results i.e. pass or fail |  | 2d | 2021-09-17 | 2021-09-20 | 88FS+1d | 2021-09-17 | 2021-09-20 | 2d | -103d | 0d | start no earlier than 2021-09-16 | Diana James | 16h | 1,600 | 1,600 |
| 90 | 4.3.15 | Test result documentation process |  | 1d? | 2021-09-23 | 2021-09-23 | 89FS+1d | 2021-09-23 | 2021-09-23 | 1d? | -103d | 0d | start no earlier than 2021-09-20 | Diana James; Furniture; Laptops; Microsoft [0.1%] | 8h | 4,300 | 4,300 |
| 91 | 4.3.16 | Logging defects found in the application with bug severirties & priorities |  | 2d | 2021-09-21 | 2021-09-22 |  | 2021-09-21 | 2021-09-22 | 2d | -108d | 0d | start no earlier than 2021-09-21 | Diana James | 16h | 1,600 | 1,600 |
| 92 | 4.3.17 | Developers fix the issues |  | 2d | 2021-09-24 | 2021-09-27 | 91FS+1d | 2021-09-24 | 2021-09-27 | 2d | -108d | 0d | start no earlier than 2021-09-23 | Ashley Robertson; Ryan Williamson | 32h | 5,600 | 5,600 |
| 93 | 4.3.18 | Retesting is done |  | 1d? | 2021-09-30 | 2021-09-30 | 92FS+1d | 2021-09-30 | 2021-09-30 | 1d? | -108d | 0d | start no earlier than 2021-09-27 | Diana James | 8h | 800 | 800 |
| 94 | 4.3.19 | Regression testing on newly deployed features |  | 1d | 2021-09-28 | 2021-09-28 |  | 2021-09-28 | 2021-09-28 | 1d | -106d | 0d | start no earlier than 2021-09-28 | Diana James | 8h | 800 | 800 |
| 95 | 4.3.20 | Application's functionality successful in SIT environment | milestone | 0d | 2021-09-28 | 2021-09-28 |  | 2021-09-28 | 2021-09-28 | 0d | -105d | 0d | start no earlier than 2021-09-28 | Microsoft |  |  |  |
| 96 | 4.3.21 | Secuity Based Testing |  | 1d? | 2021-09-29 | 2021-09-29 |  | 2021-09-29 | 2021-09-29 | 1d? | -116d | 0d | start no earlier than 2021-09-29 | Diana James | 8h | 800 | 800 |
| 97 | 4.3.22 | Stress Testing |  | 1d | 2021-10-01 | 2021-10-01 | 96FS+1d | 2021-10-01 | 2021-10-01 | 1d | -116d | 0d | start no earlier than 2021-09-30 | Diana James | 8h | 800 | 800 |
| 98 | 4.3.23 | Performance Testing |  | 1d? | 2021-10-06 | 2021-10-06 | 97FS+2d | 2021-10-06 | 2021-10-06 | 1d? | -113d | 0d | start no earlier than 2021-10-01 | Diana James | 8h | 800 | 800 |
| 99 | 4.3.24 | Load Testing |  | 2d? | 2021-10-06 | 2021-10-07 | 98FS-1d | 2021-10-06 | 2021-10-07 | 2d? | -113d | 0d | start no earlier than 2021-10-04 | Diana James [50%]; Boniface Barrack [25%]; Desktops; Furniture; Josephine Joel [25%]; Laptops | 8h | 7,600 | 7,600 |
| 100 | 4.2.25 | Performing UAT and coording with business users |  | 3d | 2021-10-05 | 2021-10-07 | 97FS-1d | 2021-10-05 | 2021-10-07 | 3d | -118d | 0d | start no earlier than 2021-10-05 | Diana James; Josephine Joel | 32h | 6,400 | 6,400 |
| 101 | 4.3.26 | Making changes before pre-production |  | 1d? | 2021-10-07 | 2021-10-07 |  | 2021-10-07 | 2021-10-07 | 1d? | -113d | 0d | start no earlier than 2021-10-07 | Ryan Williamson | 8h | 1,600 | 1,600 |
| 102 | 4.3.27 | Performing Pilot testing |  | 2d | 2021-10-08 | 2021-10-11 | 100FS-1d | 2021-10-08 | 2021-10-11 | 2d | -119d | 0d | start no earlier than 2021-10-08 | Diana James; Josephine Joel | 32h | 6,400 | 6,400 |
| 103 | 4.3.28 | Training the users on the application usage |  | 3d | 2021-10-13 | 2021-10-15 | 102FS+1d | 2021-10-13 | 2021-10-15 | 3d | -119d | 0d | start no earlier than 2021-10-12 | Josephine Joel; Naga Srinivas | 48h | 16,800 | 16,800 |
| 104 | 4.3.29 | Transfer of new database structures |  | 1d | 2021-10-15 | 2021-10-15 |  | 2021-10-15 | 2021-10-15 | 1d | -121d | 0d | start no earlier than 2021-10-15 | Shaun Micheals | 8h | 2,000 | 2,000 |
| 105 | 4.3.30 | Database testing |  | 1d? | 2021-10-19 | 2021-10-19 | 104FS+1d | 2021-10-19 | 2021-10-19 | 1d? | -121d | 0d | start no earlier than 2021-10-18 | Shaun Micheals | 8h | 2,000 | 2,000 |
| 106 | 4.3.31 | Readiness Review of the application |  | 2d? | 2021-10-19 | 2021-10-20 |  | 2021-10-19 | 2021-10-20 | 2d? | -122d | 0d | start no earlier than 2021-10-19 | Josephine Joel; Naga Srinivas; Shaun Micheals | 24h | 7,600 | 7,600 |
| 107 | 4.3.32 | Moving the application into production environment |  | 1d | 2021-10-15 | 2021-10-18 | 106SF-1d | 2021-10-15 | 2021-10-18 | 1d | -119d | 0d | as late as possible | Ryan Williamson | 8h | 1,600 | 1,600 |
| 108 | 4.3.33 | Project Execution Phase End | milestone | 0d | 2021-10-20 | 2021-10-20 |  | 2021-10-20 | 2021-10-20 | 0d | -121d | 0d | start no earlier than 2021-10-20 | Laptops |  | 1,500 | 1,500 |

| ID | WBS | Task | Duration | Start | Finish | Predecessors | Baseline start | Baseline finish | Baseline duration | Total slack | Free slack | Constraint | Resources | Work | Cost | Baseline cost |
| --- | --- | --- | --- | --- | --- | --- | --- | --- | --- | --- | --- | --- | --- | --- | --- | --- |
| 109 | 5 | **Project Monitoring & Controlling Phase** | 63d? | 2021-10-21 | 2022-01-20 | 58FS+1d | 2021-10-21 | 2021-12-10 | 35d? |  |  |  |  | 458.67h | 125,500 | 125,500 |
| 110 | 5.1 | **Solution towards Application's issues** | 15d? | 2021-10-21 | 2021-11-10 |  | 2021-10-21 | 2021-11-04 | 11d? |  |  |  |  | 136h | 30,400 | 30,400 |
| 111 | 5.1.1 | Monitoring key server resources for the purpose of load and usage | 2d | 2021-10-21 | 2021-10-22 |  | 2021-10-21 | 2021-10-22 | 2d | 57d | 1d |  | Ashley Robertson; Ryan Williamson | 32h | 5,600 | 5,600 |
| 112 | 5.1.2 | Monitoring the response and load time | 2d | 2021-10-25 | 2021-10-26 | 111FS-1d | 2021-10-25 | 2021-10-26 | 2d | 56d | 0d | start no earlier than 2021-10-25 | Diana James; Josephine Joel | 32h | 6,400 | 6,400 |
| 113 | 5.1.3 | Monitoring version and configuration changes | 2d | 2021-10-28 | 2021-10-29 | 112FS+1d | 2021-10-28 | 2021-10-29 | 2d | 56d |  | start no earlier than 2021-10-27 | Diana James | 16h | 1,600 | 1,600 |
| 114 | 5.1.4 | Controlling the scope of the deployed requirements | 2d | 2021-10-29 | 2021-11-01 |  | 2021-10-29 | 2021-11-01 | 2d | 55d |  | start no earlier than 2021-10-29 | Shaun Micheals | 16h | 4,000 | 4,000 |
| 115 | 5.1.5 | Tracking the performance of the application | 2d | 2021-11-02 | 2021-11-03 |  | 2021-11-02 | 2021-11-03 | 2d | 48d | 0d | start no earlier than 2021-11-02 | Naga Srinivas; Shaun Micheals | 32h | 10,400 | 10,400 |
| 116 | 5.1.6 | Information and reporting on end user's issues in production | 1d? | 2021-11-10 | 2021-11-10 | 115FS+1d | 2021-11-10 | 2021-11-10 | 1d? | 48d |  | start no earlier than 2021-11-04 | Josephine Joel | 8h | 2,400 | 2,400 |
| 117 | 5.2 | **Network traffic monitoring** | 5d? | 2021-11-05 | 2021-11-11 |  | 2021-11-05 | 2021-11-11 | 5d? |  |  |  |  | 72h | 18,000 | 18,000 |
| 118 | 5.2.1 | Monitoring, tracing and analyzing traffic data once for all | 2d | 2021-11-05 | 2021-11-08 |  | 2021-11-05 | 2021-11-08 | 2d | 48d | 1d | start no earlier than 2021-11-05 | Josephine Joel; Shaun Micheals | 32h | 8,800 | 8,800 |
| 119 | 5.2.2 | Identifying the major users of the network | 1d | 2021-11-09 | 2021-11-09 | 118FS-1d | 2021-11-09 | 2021-11-09 | 1d | 47d | 0d | finish no earlier than 2021-11-09 | Josephine Joel; Shaun Micheals | 16h | 4,400 | 4,400 |
| 120 | 5.2.3 | Troubleshoot the issues | 1d? | 2021-11-11 | 2021-11-11 | 119FS+1d | 2021-11-11 | 2021-11-11 | 1d? | 47d | 0d | start no earlier than 2021-11-10 | Ryan Williamson; Ashley Robertson | 16h | 2,800 | 2,800 |
| 121 | 5.2.4 | Transition support set up for users | 1d? | 2021-11-11 | 2021-11-11 | 120FS-1d | 2021-11-11 | 2021-11-11 | 1d? | 47d |  | start no earlier than 2021-11-11 | Shaun Micheals | 8h | 2,000 | 2,000 |
| 122 | 5.2 | **Monitoring the response time of servers** | 5d? | 2021-11-12 | 2021-11-18 |  | 2021-11-12 | 2021-11-18 | 5d? |  |  |  |  | 64h | 14,800 | 14,800 |
| 123 | 5.2.1 | Checking the server response time with both physically and virtually | 2d | 2021-11-12 | 2021-11-15 |  | 2021-11-12 | 2021-11-15 | 2d | 44d | 1d |  | Josephine Joel; Ryan Williamson | 32h | 8,000 | 8,000 |
| 124 | 5.2.2 | Reporting from Network and database Administration | 2d | 2021-11-16 | 2021-11-17 | 123FS-1d | 2021-11-16 | 2021-11-17 | 2d | 43d |  | start no earlier than 2021-11-16 | Shaun Micheals | 16h | 4,000 | 4,000 |
| 125 | 5.2.3 | Isolating application Issues | 1d? | 2021-11-18 | 2021-11-18 |  | 2021-11-18 | 2021-11-18 | 1d? | 42d |  | start no earlier than 2021-11-18 | Ashley Robertson; Ryan Williamson | 16h | 2,800 | 2,800 |
| 126 | 5.3 | **Identifying user feedback** | 4d? | 2021-11-19 | 2021-11-24 |  | 2021-11-19 | 2021-11-24 | 4d? |  |  |  |  | 48h | 15,200 | 15,200 |
| 127 | 5.3.1 | Updates on the deployments | 1d? | 2021-11-19 | 2021-11-19 |  | 2021-11-19 | 2021-11-19 | 1d? | 38d | 0d |  | Josephine Joel; Naga Srinivas | 16h | 5,600 | 5,600 |
| 128 | 5.3.2 | Capturing and documenting issues in production | 2d | 2021-11-23 | 2021-11-24 | 127FS+1d | 2021-11-23 | 2021-11-24 | 2d | 38d | 0d | start no earlier than 2021-11-22 | Josephine Joel | 16h | 4,800 | 4,800 |
| 129 | 5.3.3 | Ensuring issues are resolved successfully | 1d | 2021-11-24 | 2021-11-24 | 128FS-1d | 2021-11-24 | 2021-11-24 | 1d | 38d |  | finish no earlier than 2021-11-24 | Ryan Williamson; Naga Srinivas | 16h | 4,800 | 4,800 |
| 130 | 5.4 | **Maintaince of the application** | 4d? | 2021-11-29 | 2021-12-02 |  | 2021-11-29 | 2021-12-02 | 4d? |  |  |  |  | 32h | 14,033.33 | 14,033.33 |
| 131 | 5.4.1 | Minor Bug fixes for new versions | 1d | 2021-11-29 | 2021-11-29 |  | 2021-11-29 | 2021-11-29 | 1d | 34d | 0d |  |  |  |  |  |
| 132 | 5.4.2 | Updating new supporting frameworks | 1d? | 2021-11-30 | 2021-11-30 | 131 | 2021-11-30 | 2021-11-30 | 1d? | 34d | 0d | start no earlier than 2021-11-30 | Shaun Micheals | 8h | 2,000 | 2,000 |
| 133 | 5.4.2 | Inserting or Importing new data for enhancements | 1d | 2021-12-01 | 2021-12-01 | 132 | 2021-12-01 | 2021-12-01 | 1d | 34d | 0d | start no earlier than 2021-12-01 | Shaun Micheals [66.7%]; Desktops; Josephine Joel [33.3%]; Laptops; Microsoft [0.1%] | 8h | 6,033.33 | 6,033.33 |
| 134 | 5.4.3 | Confirmation on the service level agreements | 1d? | 2021-12-02 | 2021-12-02 | 133 | 2021-12-02 | 2021-12-02 | 1d? | 34d |  | start no earlier than 2021-12-02 | Boniface Barrack; Naga Srinivas | 16h | 6,000 | 6,000 |

| ID | WBS | Task | Type | Duration | Start | Finish | Predecessors | Baseline start | Baseline finish | Baseline duration | Total slack | Free slack | Constraint | Resources | Work | Cost | Baseline cost |
| --- | --- | --- | --- | --- | --- | --- | --- | --- | --- | --- | --- | --- | --- | --- | --- | --- | --- |
| 135 | 5.5 | **Post production support** |  | 34d? | 2021-12-03 | 2022-01-20 |  | 2021-05-03 | 2022-01-03 | 171d? |  |  |  |  | 106.67h | 33,066.67 | 33,066.67 |
| 136 | 5.5.1 | Retesting the new version changes |  | 1d? | 2021-12-03 | 2021-12-03 |  | 2021-10-21 | 2021-10-21 | 1d? | 29d | 0d |  | Diana James | 8h | 800 | 800 |
| 137 | 5.5.2 | Approval of new version changes |  | 1d? | 2021-12-06 | 2021-12-06 | 136 | 2021-12-06 | 2021-12-06 | 1d? | 29d | 0d | start no earlier than 2021-12-06 | Boniface Barrack | 8h | 2,800 | 2,800 |
| 138 | 5.5.3 | Version Approval | milestone | 0d | 2021-12-06 | 2021-12-06 | 137 | 2021-12-06 | 2021-12-06 | 0d | 29d | 0d | start no earlier than 2021-12-06 |  |  |  |  |
| 139 | 5.5.4 | Implementing critical changes |  | 1d? | 2021-12-07 | 2021-12-07 | 138 | 2021-12-07 | 2021-12-07 | 1d? | 29d | 0d | start no earlier than 2021-12-07 | Ryan Williamson | 8h | 1,600 | 1,600 |
| 140 | 5.5.5 | Regulatory maintainence and Compliances |  | 2d? | 2021-12-08 | 2021-12-09 | 139 | 2021-12-08 | 2021-12-09 | 2d? | 29d |  | finish no earlier than 2021-12-09 | Shaun Micheals | 16h | 4,000 | 4,000 |
| 141 | 5.5.6 | Residual Error fixes |  | 1d? | 2021-12-10 | 2021-12-10 |  | 2021-12-10 | 2021-12-10 | 1d? | 28d |  | start no earlier than 2021-12-10 | Ashley Robertson | 8h | 1,200 | 1,200 |
| 142 | 5.6.7 | **Montly Status Meeting** |  | 151d | 2021-05-03 | 2021-12-03 |  | 2021-05-03 | 2021-12-03 | 151d |  |  |  |  | 58.67h | 20,266.67 | 20,266.67 |
| 143 | 5.6.7.1 | Montly Status Meeting 1 |  | 0.67d | 2021-05-03 | 2021-05-03 |  | 2021-05-03 | 2021-05-03 | 0.67d | 161.33d | 0d |  | Naga Srinivas [50%]; Laptops [50%] | 2.67h | 2,566.67 | 2,566.67 |
| 144 | 5.6.7.2 | Montly Status Meeting 2 |  | 1d | 2021-05-03 | 2021-05-04 | 143 | 2021-05-03 | 2021-05-04 | 1d | 161.33d | 0d |  | Boniface Barrack | 8h | 2,800 | 2,800 |
| 145 | 5.6.7.3 | Montly Status Meeting 3 |  | 2d | 2021-05-04 | 2021-05-06 | 144 | 2021-05-04 | 2021-05-06 | 2d | 161.33d | 0d |  | Boniface Barrack [50%]; Naga Srinivas [50%] | 12h | 4,400 | 4,400 |
| 146 | 5.6.7.4 | Montly Status Meeting 4 |  | 1d | 2021-05-06 | 2021-05-07 | 145 | 2021-05-06 | 2021-05-07 | 1d | 161.33d | 85.33d | finish no later than 2021-12-27 | Boniface Barrack | 8h | 2,800 | 2,800 |
| 147 | 5.6.7.5 | Montly Status Meeting 5 |  | 1d | 2021-09-08 | 2021-09-08 | 146 | 2021-09-08 | 2021-09-08 | 1d | 90d |  | start no earlier than 2021-09-08 | Boniface Barrack [50%]; Desktops; Laptops; Microsoft [0.1%] | 4h | 5,300 | 5,300 |
| 148 | 5.6.7.6 | Montly Status Meeting 6 |  | 1d | 2022-01-18 | 2022-01-18 | 147 | 2021-12-30 | 2021-12-30 | 1d | 0d |  | as late as possible | Diana James | 8h | 800 | 800 |
| 149 | 5.6.7.7 | Montly Status Meeting 7 |  | 1d | 2022-01-19 | 2022-01-19 | 148, 153FS-1d, 157 | 2021-12-31 | 2021-12-31 | 1d | 0d |  | start no earlier than 2021-11-08 | Diana James | 8h | 800 | 800 |
| 150 | 5.6.7.8 | Montly Status Meeting 8 |  | 1d | 2022-01-20 | 2022-01-20 | 149 | 2022-01-03 | 2022-01-03 | 1d | 0d |  | start no earlier than 2021-12-08 | Diana James | 8h | 800 | 800 |
| 151 | 5.5.7 | Project Monitoring & Controlling Phase End | milestone | 0d | 2021-12-10 | 2021-12-10 |  | 2021-12-10 | 2021-12-10 | 0d | 29d |  | start no earlier than 2021-12-10 | Desktops |  | 2,400 | 2,400 |
| 152 | 6 | **Project Closing Phase** |  | 204d? | 2021-04-05 | 2022-01-20 |  | 2021-04-05 | 2022-01-03 | 191d? | 0d |  |  |  | 264h | 234,600 | 207,400 |
| 153 | 6.1 | **Evaluation Reporting** |  | 8d? | 2021-12-13 | 2021-12-22 |  | 2021-12-13 | 2021-12-22 | 8d? | 19d |  |  |  | 48h | 18,000 | 18,000 |
| 154 | 6.1.1 | Collection and Evaluation of performances of the application |  | 2d | 2021-12-13 | 2021-12-14 |  | 2021-12-13 | 2021-12-14 | 2d | 23d | 1d | start no earlier than 2021-12-13 | Boniface Barrack | 16h | 5,600 | 5,600 |
| 155 | 6.1.2 | Formal Acceptability from the users |  | 2d? | 2021-12-16 | 2021-12-17 | 154FS-1d | 2021-12-16 | 2021-12-17 | 2d? | 22d |  | start no earlier than 2021-12-15 | Boniface Barrack; Naga Srinivas | 16h | 6,000 | 6,000 |
| 156 | 6.1.3 | Lessons learnt document analysis |  | 2d | 2021-12-20 | 2021-12-22 |  | 2021-12-20 | 2021-12-22 | 2d | 19d |  | start no earlier than 2021-12-16 | Naga Srinivas | 16h | 6,400 | 6,400 |
| 157 | 6.2 | **Benfit Analysis Reporting** |  | 183d | 2021-04-05 | 2021-12-21 |  | 2021-04-05 | 2021-12-21 | 183d | 19d |  |  |  | 16h | 5,600 | 5,600 |
| 158 | 6.2.1 | Highlighting of web application features |  | 1d | 2021-04-05 | 2021-04-05 |  | 2021-04-05 | 2021-04-05 | 1d | 201d | 182d |  | Josephine Joel | 8h | 2,400 | 2,400 |
| 159 | 6.2.2 | Brief summary of final product or service |  | 1d | 2021-12-21 | 2021-12-21 | 158FF | 2021-12-21 | 2021-12-21 | 1d | 19d |  | start no earlier than 2021-12-21 | Naga Srinivas | 8h | 3,200 | 3,200 |

Notes:
- 142: Occur ass soon as possible

| ID | WBS | Task | Type | Duration | Start | Finish | Predecessors | Baseline start | Baseline finish | Baseline duration | Total slack | Free slack | Constraint | Resources | Work | Cost | Baseline cost |
| --- | --- | --- | --- | --- | --- | --- | --- | --- | --- | --- | --- | --- | --- | --- | --- | --- | --- |
| 160 | 6.3 | **Project Status Reporting** |  | 21d? | 2021-12-22 | 2022-01-20 |  | 2022-01-20 | 2022-01-03 | 191d? |  |  |  |  | 88h | 33,000 | 26,600 |
| 161 | 6.3.1 | Operational and Support documentation |  | 1d | 2021-12-22 | 2021-12-22 |  | 2021-12-22 | 2021-04-05 | 1d? | 15d | 0d |  | Naga Srinivas; Shaun Micheals | 16h | 5,200 | 5,200 |
| 162 | 6.3.2 | Phase closure documentation |  | 2d? | 2021-12-27 | 2021-12-28 | 161FS+1d | 2021-12-29 | 2021-04-08 | 2d? | 15d | 10d | start no earlier than 2021-12-23 | Naga Srinivas [50%]; Boniface Barrack [50%] | 12h | 4,600 | 4,600 |
| 163 | 6.3.3 | Execution of new change features |  | 8d | 2021-12-30 | 2022-01-10 |  |  |  |  | 8d |  | start no earlier than 2021-12-30 |  |  |  |  |
| 164 | 6.3.4 | Scope, quality and objective reporting |  | 3d | 2022-01-11 | 2022-01-13 | 162FS-1d | 2021-04-15 | 2021-04-16 | 2d | 5d |  | start no earlier than 2022-01-11 | Naga Srinivas | 24h | 9,600 | 6,400 |
| 165 | 6.3.5 | Genrating Monthly and weekly status reports |  | 2d | 2022-01-14 | 2022-01-17 |  | 2021-12-29 | 2021-12-29 | 1d | 3d |  | start no earlier than 2022-01-14 | Naga Srinivas | 16h | 6,400 | 3,200 |
| 166 | 6.3.6 | Successful Project Reporting | milestone | 0d | 2022-01-17 | 2022-01-17 |  | 2021-12-29 | 2021-12-29 | 0d | 4d |  | start no earlier than 2022-01-17 | Naga Srinivas [50%]; Boniface Barrack [50%] |  |  |  |
| 167 | 6.3.7 | Project Review Documentation |  | 1d? | 2022-01-18 | 2022-01-18 |  | 2021-12-30 | 2021-12-30 | 1d? | 1d |  | start no earlier than 2022-01-18 | Boniface Barrack | 8h | 2,800 | 2,800 |
| 168 | 6.3.8 | Release the project Resoures |  | 2d? | 2022-01-19 | 2022-01-20 | 167FS-1d | 2021-12-31 | 2022-01-03 | 2d? | 0d |  | start no earlier than 2022-01-19 | Boniface Barrack [50%]; Naga Srinivas [50%] | 12h | 4,400 | 4,400 |
| 169 | 6.3.8 | Project Closing Phase End | milestone | 0d | 2022-01-20 | 2022-01-20 |  | 2021-12-31 | 2021-12-31 | 0d | 1d |  | start no earlier than 2022-01-20 | Microsoft |  |  |  |
| 170 | 7 | **Contingency** |  | 71d? | 2021-09-20 | 2021-12-30 |  | 2021-09-20 | 2021-12-30 | 71d? |  |  |  |  |  | 150,000 | 157,200 |
| 171 | 7.1 | Contingency #1 |  | 31d? | 2021-09-20 | 2021-11-01 |  | 2021-09-20 | 2021-11-01 | 31d? | 49d | 0d | finish no earlier than 2021-11-01 |  |  | 50,000 | 52,400 |
| 172 | 7.2 | Contingency #2 |  | 5d? | 2021-11-02 | 2021-11-08 | 171 | 2021-11-02 | 2021-11-08 | 5d? | 49d | 34d | finish no earlier than 2021-10-22 |  |  | 50,000 | 52,400 |
| 173 | 7.3 | Contingency #3 |  | 1d? | 2021-12-30 | 2021-12-30 | 172 | 2021-12-30 | 2021-12-30 | 1d? | 15d |  | start no earlier than 2021-12-30 |  |  | 50,000 | 52,400 |
| 174 | 8 | **Project Change Requests** |  | 14d? | 2021-09-22 | 2021-10-11 |  |  |  |  |  |  |  |  | 112h | 28,000 |  |
| 175 | 8.1 | Adding and modification in new design features |  | 14d? | 2021-09-22 | 2021-10-11 |  |  |  |  | 70d |  |  | Shaun Micheals | 112h | 28,000 |  |
