# Online Retail Grocery Store website’s software development

Schedule from MS Project, 2009-10-12 to 2021-12-31, costs in $.

## Calendars

- Standard: Mon-Fri 08:00-12:00, 13:00-17:00; Sat-Sun off. Exceptions (off unless hours are given): 2021-05-31 (Memorial Day), 2021-09-06 (Labor Day), 2021-11-25 to 2021-11-26 (Thanks Giving and Black Friday), 2021-12-24 (Pre-Christmas).

## Resources

| Resource | Group | Rate |
| --- | --- | --- |
| Naga Srinivas | Project Manager | 100 |
| Boniface Barrack | Project Sponsor | 109 |
| Josephine Joel | Business Analyst | 94 |
| Ryan Williamson | Lead Developer | 91 |
| Ashley Robertson | Developer | 88 |
| Diana James | Quality Assurance Analyst | 86 |
| Shaun Micheals | Web Application Architect | 97 |
| PNC Bank |  |  |
| Federal Credit Union |  |  |
| Microsoft |  |  |
| State of Ohio |  |  |
| Vendor |  |  |
| Laptops |  |  |
| Printers |  |  |
| Deskstops |  |  |
| Furniture |  |  |

## Schedule

| ID | WBS | Task | Type | Duration | Start | Finish | Predecessors | Total slack | Free slack | Constraint | Resources | Work | Cost | hours |
| --- | --- | --- | --- | --- | --- | --- | --- | --- | --- | --- | --- | --- | --- | --- |
| 1 | 0 | Online Retail Grocery Store website’s software development |  | 190d | 2009-10-12 | 2010-07-02 |  | 2995d |  |  |  |  |  |  |
| 2 | 1 | **Project Management** |  | 190d? | 2021-04-05 | 2021-12-31 |  |  |  |  |  | 3987h | 539,417.5 | 1800 |
| 3 | 2 | **Project Initiation** |  | 15d? | 2021-04-05 | 2021-04-23 |  |  |  |  | Boniface Barrack; Naga Srinivas | 387h | 40,513.5 |  |
| 4 | 2.1.1 | Project Charter Review |  | 1d? | 2021-04-05 | 2021-04-05 |  | 185.69d | 2d |  | Boniface Barrack; Naga Srinivas | 16h | 1,672 |  |
| 5 | 2.1.2 | Project proposal Evaluation |  | 1d | 2021-04-07 | 2021-04-07 | 4FS-1d | 183.69d | 3d | start no earlier than 2021-04-07 | Boniface Barrack; Naga Srinivas | 16h | 1,672 |  |
| 6 | 2.1.3 | Project Kick off Meeting |  | 0.31d | 2021-04-12 | 2021-04-12 | 5FS-1d | 180.69d | 3.69d | start no earlier than 2021-04-12 | Boniface Barrack; Naga Srinivas | 5h | 522.5 |  |
| 7 | 2.1.4 | Project Vision and Mission Statement |  | 1d? | 2021-04-13 | 2021-04-13 |  | 183d |  | start no earlier than 2021-04-13 | Boniface Barrack | 8h | 872 |  |
| 8 | 2.1.5 | Defining Problem Statement |  | 0.8d? | 2021-04-14 | 2021-04-14 |  | 182.2d |  | start no earlier than 2021-04-14 | Boniface Barrack [62.5%]; Naga Srinivas [62.5%] | 8h | 836 |  |
| 9 | 2.1.6 | Onboarding of project resources |  | 1d? | 2021-04-15 | 2021-04-15 | 6FS-1d | 177d | 0d | start no earlier than 2021-04-15 | Boniface Barrack | 8h | 872 |  |
| 10 | 2.1.7 | Documentation of Project Charter |  | 3d | 2021-04-15 | 2021-04-19 | 9FS-1d | 177d | 0d | start no earlier than 2021-04-15 | Boniface Barrack [91.7%]; Naga Srinivas [91.7%] | 44h | 4,598 |  |
| 11 | 2.1.8 | Signatures on Project Charter Team |  | 1d? | 2021-04-19 | 2021-04-19 | 10FS-1d | 177d | 1d | start no earlier than 2021-04-19 | Boniface Barrack [62.5%]; Naga Srinivas [62.5%] | 10h | 1,045 |  |
| 12 | 2.1.9 | Defining Responsibilties and goals |  | 1d? | 2021-04-20 | 2021-04-20 | 11SS | 176d | 1d | start no earlier than 2021-04-20 | Boniface Barrack; Naga Srinivas | 16h | 1,672 |  |
| 13 | 2.1.10 | Project Charter Document completion |  | 1d? | 2021-04-21 | 2021-04-21 | 12FS-1d | 175d | 15d | start no earlier than 2021-04-21 | Boniface Barrack; Naga Srinivas | 16h | 1,672 |  |
| 14 | 2.1.11 | Project Charter Approved | milestone | 0d | 2021-04-23 | 2021-04-23 |  | 176d | 14d | start no earlier than 2021-04-23 |  |  |  |  |
| 15 | 2.1.12 | Project Initiation Phase End | milestone | 0d | 2021-04-23 | 2021-04-23 |  | 175d | 24d | start no earlier than 2021-04-23 |  |  |  |  |
| 16 | 3 | **Project Planning** |  | 45d? | 2021-04-26 | 2021-06-28 |  |  |  |  | Boniface Barrack; Naga Srinivas; Josephine Joel; Shaun Micheals | 2160h | 213,960 |  |
| 17 | 3.1 | Review Project Documentation |  | 1d? | 2021-04-26 | 2021-04-26 |  | 173d | 1d | start no earlier than 2021-04-26 | Josephine Joel; Naga Srinivas; Shaun Micheals | 24h | 2,328 |  |
| 18 | 3.2 | Create a PMP Draft Template |  | 1d? | 2021-04-27 | 2021-04-27 | 17FF | 172d | 0d | start no earlier than 2021-04-27 | Boniface Barrack; Naga Srinivas | 16h | 1,672 |  |
| 19 | 3.3 | Review the draft PMP with project team |  | 1d? | 2021-04-28 | 2021-04-28 | 17, 18FF+1d | 172d |  | start no earlier than 2021-04-28 | Boniface Barrack; Naga Srinivas | 16h | 1,672 |  |
| 20 | 3.4 | Review/Approve PMP with Project Sponsor |  | 1d? | 2021-04-29 | 2021-04-29 |  | 171d | 0d | start no earlier than 2021-04-29 | Boniface Barrack; Naga Srinivas | 16h | 1,672 |  |
| 21 | 3.5 | PMP Approval | milestone | 0d | 2021-04-29 | 2021-04-29 | 20SF | 172d |  | start no earlier than 2021-04-29 |  |  |  |  |
| 22 | 3.6 | **Tool and Technology Selection** |  | 6d? | 2021-04-26 | 2021-05-03 |  | 169d |  |  | Shaun Micheals | 80h | 7,952 |  |
| 23 | 3.6.1 | MS SQL |  | 1d? | 2021-04-26 | 2021-04-26 |  | 174d | 6d |  | Shaun Micheals; Boniface Barrack | 16h | 1,648 |  |
| 24 | 3.6.2 | Dot Net Technology |  | 1d? | 2021-05-03 | 2021-05-03 | 23SF | 169d |  | start no earlier than 2021-05-03 | Shaun Micheals; Boniface Barrack | 16h | 1,648 |  |
| 25 | 3.6.3 | License Approval on Tool and Technology | milestone | 0d | 2021-05-03 | 2021-05-03 |  | 170d |  | start no earlier than 2021-05-03 | Boniface Barrack; Naga Srinivas |  |  |  |
| 26 | 3.7 | Development of Organizational Chart which includes who reports to whom |  | 2d? | 2021-05-04 | 2021-05-05 |  | 167d |  | start no earlier than 2021-05-04 | Josephine Joel; Naga Srinivas | 32h | 3,104 |  |

| ID | WBS | Task | Type | Duration | Start | Finish | Predecessors | Total slack | Free slack | Constraint | Resources | Work | Cost |
| --- | --- | --- | --- | --- | --- | --- | --- | --- | --- | --- | --- | --- | --- |
| 27 | 3.8 | **Template selection of Website** |  | 3d? | 2021-05-06 | 2021-05-10 |  | 160d | 0d |  | Vendor [0.1%] | 16h | 1,744 |
| 28 | 3.8.1 | Template selection for desktop |  | 1d? | 2021-05-06 | 2021-05-06 |  | 160d | 0d | start no earlier than 2021-05-06 | Vendor [0.1%]; Boniface Barrack | 8h | 872 |
| 29 | 3.8.2 | Template selection for Mobile |  | 1d? | 2021-05-10 | 2021-05-10 | 28FS+1d | 160d |  | start no earlier than 2021-05-07 | Vendor [0.1%]; Boniface Barrack | 8h | 872 |
| 30 | 3.9 | **Authorization Set up** |  | 3d? | 2021-05-12 | 2021-05-14 | 27FS+1d | 160d |  |  |  | 40h | 4,072 |
| 31 | 3.9.1 | Authorization includes email set up and permssion to the sharepoint for accessing project relateddocuments |  | 1d | 2021-05-12 | 2021-05-12 |  | 162d |  |  | Boniface Barrack | 8h | 872 |
| 32 | 3.9.2 | Uploading Project Documentation |  | 1d? | 2021-05-12 | 2021-05-12 | 14SS-1d | 162d |  | start no earlier than 2021-05-11 | Naga Srinivas | 8h | 800 |
| 33 | 3.9.3 | Creating Project Communication Process |  | 3d | 2021-05-12 | 2021-05-14 | 13FS-1d | 160d |  | start no earlier than 2021-05-12 | Naga Srinivas | 24h | 2,400 |
| 34 | 3.10 | **Application Environment Set-up** |  | 24d? | 2021-04-26 | 2021-05-27 |  | 151d |  |  |  | 112h | 10,528 |
| 35 | 3.10.1 | Development Environment Set up |  | 2d | 2021-04-26 | 2021-04-27 |  | 165d | 14d |  | Ryan Williamson; Shaun Micheals | 32h | 3,008 |
| 36 | 3.10.2 | SIT Environment Set up |  | 2d | 2021-05-19 | 2021-05-20 | 35FS+1d | 151d | 0d | start no earlier than 2021-05-19 | Ryan Williamson; Shaun Micheals | 32h | 3,008 |
| 37 | 3.10.3 | Production Environment Set up |  | 1d? | 2021-05-24 | 2021-05-24 | 36FS+1d | 151d | 0d |  | Ryan Williamson; Shaun Micheals | 16h | 1,504 |
| 38 | 3.10.4 | UAT Environment Set up |  | 2d | 2021-05-26 | 2021-05-27 | 15FS-1d, 37FS+1d | 151d |  | start no earlier than 2021-05-24 | Ryan Williamson; Shaun Micheals | 32h | 3,008 |
| 39 | 3.11 | **Requirement analysis of the customer** |  | 17d? | 2021-05-26 | 2021-06-18 |  | 136d |  |  | Josephine Joel | 264h | 24,816 |
| 40 | 3.11.1 | Getting an idea or overview of the website |  | 2d | 2021-05-26 | 2021-05-27 |  | 151d |  | finish no earlier than 2021-05-27 | Josephine Joel | 16h | 1,504 |
| 41 | 3.11.3 | Identification of Stakeholders |  | 1d? | 2021-05-28 | 2021-05-28 |  | 145d | 1d | start no earlier than 2021-05-28 | Josephine Joel | 8h | 752 |
| 42 | 3.11.3 | Gather requirements for the web application |  | 2d | 2021-06-01 | 2021-06-02 | 41FS-1d | 144d | 0d | start no earlier than 2021-06-01 | Josephine Joel | 16h | 1,504 |
| 43 | 3.11.4 | Conducting Meeting and Surveys |  | 1d | 2021-06-04 | 2021-06-04 | 42FS+1d | 144d | 0d | start no earlier than 2021-06-04 | Josephine Joel | 8h | 752 |
| 44 | 3.11.5 | Perform Stakeholder Analysis |  | 1d? | 2021-06-08 | 2021-06-08 | 43FS+1d | 144d |  | start no earlier than 2021-06-07 | Josephine Joel | 8h | 752 |
| 45 | 3.11.6 | Determing Solution Approach |  | 2d | 2021-06-08 | 2021-06-09 |  | 143d |  | start no earlier than 2021-06-08 | Josephine Joel | 16h | 1,504 |
| 46 | 3.11.7 | Finding new enhanced needs |  | 1d? | 2021-06-10 | 2021-06-10 |  | 139d | 2d | start no earlier than 2021-06-10 | Josephine Joel | 8h | 752 |
| 47 | 3.11.8 | Creation requirements draft |  | 1d? | 2021-06-11 | 2021-06-11 | 46SS-1d | 138d | 0d | start no earlier than 2021-06-11 | Josephine Joel | 8h | 752 |
| 48 | 3.11.9 | Document those requirements into Business Requirement Document and Funtional Requirement Document i.e. FRD & BRD |  | 2d | 2021-06-15 | 2021-06-16 | 47FS+1d | 138d | 0d | start no earlier than 2021-06-14 | Josephine Joel | 16h | 1,504 |
| 49 | 3.11.10 | Documented BRD and FRD | milestone | 0d | 2021-06-16 | 2021-06-16 | 48FS-1d | 139d |  | start no earlier than 2021-06-15 |  |  |  |
| 50 | 3.11.11 | Business Analysis Establishment |  | 1d? | 2021-06-16 | 2021-06-16 |  | 138d |  | start no earlier than 2021-06-16 | Josephine Joel | 8h | 752 |
| 51 | 3.11.12 | Preparation of Requirement Traceability Matrix |  | 2d | 2021-06-17 | 2021-06-18 |  | 136d |  | start no earlier than 2021-06-17 | Josephine Joel | 16h | 1,504 |

| ID | WBS | Task | Type | Duration | Start | Finish | Predecessors | Total slack | Free slack | Constraint | Resources | Work | Cost |
| --- | --- | --- | --- | --- | --- | --- | --- | --- | --- | --- | --- | --- | --- |
| 52 | 3.12 | **Project Risk Analysis** |  | 47d? | 2021-04-26 | 2021-06-30 |  | 128d |  |  |  | 104h | 10,400 |
| 53 | 3.12.1 | Analysis of risks involved |  | 2d | 2021-04-26 | 2021-04-27 |  | 165d | 37d |  | Naga Srinivas; Shaun Micheals | 32h | 3,152 |
| 54 | 3.12.2 | Registering the risks |  | 1d? | 2021-06-22 | 2021-06-22 | 53FS+1d | 128d | 0d | start no earlier than 2021-06-22 | Naga Srinivas | 8h | 800 |
| 55 | 3.12.3 | Documenting the risks involved |  | 2d | 2021-06-24 | 2021-06-25 | 54FS+1d | 128d | 0d | start no earlier than 2021-06-23 | Josephine Joel; Naga Srinivas | 32h | 3,104 |
| 56 | 3.12.4 | Development of WBS |  | 2d | 2021-06-29 | 2021-06-30 | 55FS+1d | 128d |  | start no earlier than 2021-06-25 | Naga Srinivas; Boniface Barrack | 32h | 3,344 |
| 57 | 3.12.5 | Work Breakdown Structure Development | milestone | 0d | 2021-06-30 | 2021-06-30 |  | 129d |  | start no earlier than 2021-06-30 |  |  |  |
| 58 | 3.12.6 | Project Planning Phase End | milestone | 0d | 2021-06-30 | 2021-06-30 |  | 129d |  | start no earlier than 2021-06-30 |  |  |  |
| 59 | 4 | **Project Execution** |  | 81d? | 2021-07-01 | 2021-10-22 |  |  |  |  |  | 848h | 77,216 |
| 60 | 4.1 | **Web Design Architure** |  | 6d | 2021-07-01 | 2021-07-08 |  | -50d | 0d |  |  | 80h | 7,664 |
| 61 | 4.1.1 | Getting Server, memory and communication interfaces ready |  | 3d | 2021-07-01 | 2021-07-05 |  | -46d | 0d |  | Shaun Micheals | 24h | 2,328 |
| 62 | 4.1.2 | Building functionality aspects |  | 2d | 2021-07-02 | 2021-07-05 | 61FF-1d | -46d | 0d | start no earlier than 2021-07-02 | Shaun Micheals; Ryan Williamson | 32h | 3,008 |
| 63 | 4.1.3 | Building visual appearance as User Interface design |  | 3d | 2021-07-06 | 2021-07-08 |  | -53d | 0d | start no earlier than 2021-07-06 | Shaun Micheals | 24h | 2,328 |
| 64 | 4.2 | **Business Analysis** |  | 21d? | 2021-07-08 | 2021-08-05 |  | -69d | 0d |  |  | 160h | 15,040 |
| 65 | 4.2.1 | Organizing, verifying and validating the gathered requirements |  | 3d | 2021-07-08 | 2021-07-12 | 63FS-1d | -53d | 0d |  | Josephine Joel | 24h | 2,256 |
| 66 | 4.2.2 | Analysis of change requirements |  | 2d | 2021-07-14 | 2021-07-15 | 65FS-1d | -55d | 0d | start no earlier than 2021-07-14 | Josephine Joel | 16h | 1,504 |
| 67 | 4.2.3 | Translation of the business requirements into technicality for development purpose |  | 2d? | 2021-07-16 | 2021-07-19 | 66FS-1d | -56d | 0d | start no earlier than 2021-07-16 | Josephine Joel | 16h | 1,504 |
| 68 | 4.2.4 | Workshop sessions with vendors |  | 2d | 2021-07-20 | 2021-07-21 |  | -59d | 0d | start no earlier than 2021-07-20 | Josephine Joel | 16h | 1,504 |
| 69 | 4.2.5 | Use Case Diagrams |  | 1d? | 2021-07-22 | 2021-07-22 | 68 | -59d | 0d | start no earlier than 2021-07-22 | Josephine Joel | 8h | 752 |
| 70 | 4.2.6 | Conduct Unit Testing Activites |  | 2d | 2021-07-23 | 2021-07-26 |  | -61d | 0d | start no earlier than 2021-07-23 | Josephine Joel | 16h | 1,504 |
| 71 | 4.2.7 | Performance Reporting and Progress tracking |  | 4d | 2021-07-27 | 2021-07-30 |  | -65d | 0d | start no earlier than 2021-07-27 | Josephine Joel | 32h | 3,008 |
| 72 | 4.2.8 | Working on Change Requests |  | 2d | 2021-08-02 | 2021-08-03 |  | -67d | 0d | start no earlier than 2021-08-02 | Josephine Joel | 16h | 1,504 |
| 73 | 4.2.9 | Updating the change documentation |  | 2d | 2021-08-04 | 2021-08-05 | 72SF+1d | -69d | 0d | start no earlier than 2021-08-04 | Josephine Joel | 16h | 1,504 |
| 74 | 4.3 | **Web application Development & Testing** |  | 78d? | 2021-07-01 | 2021-10-20 |  | -121d | 0d |  |  | 608h | 54,512 |
| 75 | 4.3.1 | Review of the requirements or features for development |  | 1d? | 2021-07-01 | 2021-07-01 |  | -58d | 0d |  | Ashley Robertson; Ryan Williamson | 16h | 1,432 |
| 76 | 4.3.1 | Coding or developing the requirements which meets the acceptance critieria |  | 3d | 2021-08-09 | 2021-08-11 | 75FS+1d | -83d | 0d | start no earlier than 2021-08-09 | Ashley Robertson; Ryan Williamson | 48h | 4,296 |
| 77 | 4.3.2 | Mobile application development |  | 2d | 2021-08-12 | 2021-08-13 |  | -75d | 0d | start no earlier than 2021-08-12 | Ashley Robertson; Ryan Williamson | 32h | 2,864 |
| 78 | 4.3.3 | Performing Unit Testing |  | 2d | 2021-08-16 | 2021-08-17 | 76FS-1d | -86d | 0d | finish no earlier than 2021-08-17 | Ashley Robertson | 16h | 1,408 |
| 79 | 4.3.4 | Perform Integration Tesing |  | 2d | 2021-08-18 | 2021-08-19 | 78FS-1d | -87d | 0d | start no earlier than 2021-08-18 | Ryan Williamson | 16h | 1,456 |
| 80 | 4.3.3 | Deploying the features into development envrionment and system integration test environment |  | 1d | 2021-08-20 | 2021-08-20 | 79FS-1d | -88d | 0d | start no earlier than 2021-08-20 | Ryan Williamson | 8h | 728 |
| 81 | 4.3.4 | Testing the features in development environment |  | 1d? | 2021-08-24 | 2021-08-24 | 80FS+1d | -88d | 0d | start no earlier than 2021-08-23 | Ashley Robertson; Diana James; Ryan Williamson | 24h | 2,120 |
| 82 | 4.3.5 | Debugging the application |  | 1d? | 2021-08-24 | 2021-08-24 | 81FS-1d | -82d | 0d | start no earlier than 2021-08-24 | Ashley Robertson; Ryan Williamson | 16h | 1,432 |
| 83 | 4.3.6 | Deployment of features into system integration test environment |  | 1d | 2021-08-25 | 2021-08-25 | 81 | -88d | 0d | start no earlier than 2021-08-25 | Ryan Williamson | 8h | 728 |
| 84 | 4.3.7 | Integration of new features in the application |  | 3d | 2021-08-27 | 2021-08-31 | 83FS+1d | -88d | 0d | start no earlier than 2021-08-26 | Ashley Robertson; Ryan Williamson | 48h | 4,296 |
| 85 | 4.3.8 | Deployment Accomplished | milestone | 0d | 2021-09-01 | 2021-09-01 | 84FS+1d | -88d | 0d | start no earlier than 2021-08-30 |  |  |  |
| 86 | 4.3.9 | Test plan Review |  | 1d? | 2021-08-31 | 2021-08-31 |  | -102d | 0d | start no earlier than 2021-08-31 | Diana James | 8h | 688 |
| 87 | 4.3.10 | Preparing the test plan |  | 3d | 2021-09-02 | 2021-09-07 | 86FS+1d | -102d | 0d | start no earlier than 2021-09-01 | Diana James | 24h | 2,064 |
| 88 | 4.3.11 | Preparing test scenarios |  | 2d | 2021-09-07 | 2021-09-08 |  | -92d | 0d | start no earlier than 2021-09-07 | Diana James | 16h | 1,376 |
| 89 | 4.3.12 | Preparing the test scripts as per organization template |  | 5d | 2021-09-09 | 2021-09-15 | 87FS+1d | -102d | 0d | start no earlier than 2021-09-09 | Diana James | 40h | 3,440 |
| 90 | 4.3.13 | Executing the test scripts and updating the results i.e. pass or fail |  | 2d | 2021-09-17 | 2021-09-20 | 89FS+1d | -102d | 0d | start no earlier than 2021-09-16 | Diana James | 16h | 1,376 |
| 91 | 4.3.14 | Test result documentation process |  | 1d? | 2021-09-22 | 2021-09-22 | 90FS+1d | -102d | 0d | start no earlier than 2021-09-20 | Diana James | 8h | 688 |
| 92 | 4.3.15 | Logging defects found in the application with bug severirties & priorities |  | 2d | 2021-09-21 | 2021-09-22 |  | -107d | 0d | start no earlier than 2021-09-21 | Diana James | 16h | 1,376 |
| 93 | 4.3.16 | Developers fix the issues |  | 2d | 2021-09-24 | 2021-09-27 | 92FS+1d | -107d | 0d | start no earlier than 2021-09-23 | Ashley Robertson; Ryan Williamson | 32h | 2,864 |
| 94 | 4.3.17 | Retesting is done |  | 1d? | 2021-09-29 | 2021-09-29 | 93FS+1d | -107d | 0d | start no earlier than 2021-09-27 | Diana James | 8h | 688 |
| 95 | 4.3.18 | Regression testing on newly deployed features |  | 1d | 2021-09-28 | 2021-09-28 |  | -106d | 0d | start no earlier than 2021-09-28 | Diana James | 8h | 688 |
| 96 | 4.3.19 | Application's functionality successful in SIT environment | milestone | 0d | 2021-09-28 | 2021-09-28 |  | -105d | 0d | start no earlier than 2021-09-28 |  |  |  |
| 97 | 4.3.20 | Secuity Based Testing |  | 1d? | 2021-09-29 | 2021-09-29 |  | -115d | 0d | start no earlier than 2021-09-29 | Diana James | 8h | 688 |
| 98 | 4.3.21 | Stress Testing |  | 1d | 2021-10-01 | 2021-10-01 | 97FS+1d | -115d | 0d | start no earlier than 2021-09-30 | Diana James | 8h | 688 |
| 99 | 4.3.22 | Performance Testing |  | 1d? | 2021-10-06 | 2021-10-06 | 98FS+2d | -112d | 0d | start no earlier than 2021-10-01 | Diana James | 8h | 688 |
| 100 | 4.3.23 | Load Testing |  | 1d? | 2021-10-06 | 2021-10-06 | 99FS-1d | -112d | 0d | start no earlier than 2021-10-04 | Diana James | 8h | 688 |
| 101 | 4.3.24 | Performing UAT and coording with business users |  | 2d | 2021-10-05 | 2021-10-06 | 98FS-1d | -117d | 0d | start no earlier than 2021-10-05 | Diana James; Josephine Joel | 32h | 2,880 |
| 102 | 4.3.25 | Making changes before pre-production |  | 1d? | 2021-10-07 | 2021-10-07 |  | -113d | 0d | start no earlier than 2021-10-07 | Ryan Williamson | 8h | 728 |
| 103 | 4.3.26 | Performing Pilot testing |  | 2d | 2021-10-08 | 2021-10-11 | 101FS-1d | -119d | 0d | start no earlier than 2021-10-08 | Diana James; Josephine Joel | 32h | 2,880 |
| 104 | 4.3.27 | Training the users on the application usage |  | 3d | 2021-10-13 | 2021-10-15 | 103FS+1d | -119d | 0d | start no earlier than 2021-10-12 | Josephine Joel; Naga Srinivas | 48h | 4,656 |
| 105 | 4.3.28 | Transfer of new database structures |  | 1d | 2021-10-15 | 2021-10-15 |  | -121d | 0d | start no earlier than 2021-10-15 | Shaun Micheals | 8h | 776 |
| 106 | 4.3.29 | Database testing |  | 1d? | 2021-10-19 | 2021-10-19 | 105FS+1d | -121d | 0d | start no earlier than 2021-10-18 | Shaun Micheals | 8h | 776 |
| 107 | 4.3.30 | Readiness Review of the application |  | 1d? | 2021-10-19 | 2021-10-19 |  | -121d | 0d | start no earlier than 2021-10-19 | Josephine Joel; Naga Srinivas; Shaun Micheals | 24h | 2,328 |
| 108 | 4.3.31 | Moving the application into production environment |  | 1d | 2021-10-15 | 2021-10-18 | 107SF-1d | -119d | 0d | as late as possible | Ryan Williamson | 8h | 728 |
| 109 | 4.3.32 | Project Execution Phase End | milestone | 0d | 2021-10-20 | 2021-10-20 |  | -121d | 0d | start no earlier than 2021-10-20 |  |  |  |

| ID | WBS | Task | Duration | Start | Finish | Predecessors | Total slack | Free slack | Constraint | Resources | Work | Cost |
| --- | --- | --- | --- | --- | --- | --- | --- | --- | --- | --- | --- | --- |
| 110 | 5 | **Project Monitoring & Controlling Phase** | 35d? | 2021-10-21 | 2021-12-10 | 59FS+1d |  |  |  |  | 464h | 44,640 |
| 111 | 5.1 | **Solution towards Application's issues** | 11d? | 2021-10-21 | 2021-11-04 |  |  |  |  |  | 136h | 12,576 |
| 112 | 5.1.1 | Monitoring key server resources for the purpose of load and usage | 2d | 2021-10-21 | 2021-10-22 |  | 43d | 1d |  | Ashley Robertson; Ryan Williamson | 32h | 2,864 |
| 113 | 5.1.2 | Monitoring the response and load time | 2d | 2021-10-25 | 2021-10-26 | 112FS-1d | 42d | 0d | start no earlier than 2021-10-25 | Diana James; Josephine Joel | 32h | 2,880 |
| 114 | 5.1.3 | Monitoring version and configuration changes | 2d | 2021-10-28 | 2021-10-29 | 113FS+1d | 42d |  | start no earlier than 2021-10-27 | Diana James | 16h | 1,376 |
| 115 | 5.1.4 | Controlling the scope of the deployed requirements | 2d | 2021-10-29 | 2021-11-01 |  | 41d |  | start no earlier than 2021-10-29 | Shaun Micheals | 16h | 1,552 |
| 116 | 5.1.5 | Tracking the performance of the application | 2d | 2021-11-02 | 2021-11-03 |  | 37d | 0d | start no earlier than 2021-11-02 | Naga Srinivas; Shaun Micheals | 32h | 3,152 |
| 117 | 5.1.6 | Information and reporting on end user's issues in production | 1d? | 2021-11-05 | 2021-11-05 | 116FS+1d | 37d |  | start no earlier than 2021-11-04 | Josephine Joel | 8h | 752 |
| 118 | 5.2 | **Network traffic monitoring** | 5d? | 2021-11-05 | 2021-11-11 |  |  |  |  |  | 72h | 6,792 |
| 119 | 5.2.1 | Monitoring, tracing and analyzing traffic data once for all | 2d | 2021-11-05 | 2021-11-08 |  | 34d | 1d | start no earlier than 2021-11-05 | Josephine Joel; Shaun Micheals | 32h | 3,056 |
| 120 | 5.2.2 | Identifying the major users of the network | 1d | 2021-11-09 | 2021-11-09 | 119FS-1d | 33d | 0d | finish no earlier than 2021-11-09 | Josephine Joel; Shaun Micheals | 16h | 1,528 |
| 121 | 5.2.3 | Troubleshoot the issues | 1d? | 2021-11-11 | 2021-11-11 | 120FS+1d | 33d | 0d | start no earlier than 2021-11-10 | Ryan Williamson; Ashley Robertson | 16h | 1,432 |
| 122 | 5.2.4 | Transition support set up for users | 1d? | 2021-11-11 | 2021-11-11 | 121FS-1d | 33d |  | start no earlier than 2021-11-11 | Shaun Micheals | 8h | 776 |
| 123 | 5.2 | **Monitoring the response time of servers** | 5d? | 2021-11-12 | 2021-11-18 |  |  |  |  |  | 64h | 5,944 |
| 124 | 5.2.1 | Checking the server response time with both physically and virtually | 2d | 2021-11-12 | 2021-11-15 |  | 30d | 1d |  | Josephine Joel; Ryan Williamson | 32h | 2,960 |
| 125 | 5.2.2 | Reporting from Network and database Administration | 2d | 2021-11-16 | 2021-11-17 | 124FS-1d | 29d |  | start no earlier than 2021-11-16 | Shaun Micheals | 16h | 1,552 |
| 126 | 5.2.3 | Isolating application Issues | 1d? | 2021-11-18 | 2021-11-18 |  | 28d |  | start no earlier than 2021-11-18 | Ashley Robertson; Ryan Williamson | 16h | 1,432 |
| 127 | 5.3 | **Identifying user feedback** | 4d? | 2021-11-19 | 2021-11-24 |  |  |  |  |  | 48h | 4,584 |
| 128 | 5.3.1 | Updates on the deployments | 1d? | 2021-11-19 | 2021-11-19 |  | 24d | 0d |  | Josephine Joel; Naga Srinivas | 16h | 1,552 |
| 129 | 5.3.2 | Capturing and documenting issues in production | 2d | 2021-11-23 | 2021-11-24 | 128FS+1d | 24d | 0d | start no earlier than 2021-11-22 | Josephine Joel | 16h | 1,504 |
| 130 | 5.3.3 | Ensuring issues are resolved successfully | 1d | 2021-11-24 | 2021-11-24 | 129FS-1d | 24d |  | finish no earlier than 2021-11-24 | Ryan Williamson; Naga Srinivas | 16h | 1,528 |
| 131 | 5.4 | **Maintaince of the application** | 4d? | 2021-11-29 | 2021-12-02 |  |  |  |  |  | 32h | 3,224 |
| 132 | 5.4.1 | Minor Bug fixes for new versions | 1d | 2021-11-29 | 2021-11-29 |  | 20d | 0d |  |  |  |  |
| 133 | 5.4.2 | Updating new supporting frameworks | 1d? | 2021-11-30 | 2021-11-30 | 132 | 20d | 0d | start no earlier than 2021-11-30 | Shaun Micheals | 8h | 776 |
| 134 | 5.4.2 | Inserting or Importing new data for enhancements | 1d | 2021-12-01 | 2021-12-01 | 133 | 20d | 0d | start no earlier than 2021-12-01 | Shaun Micheals | 8h | 776 |
| 135 | 5.4.3 | Confirmation on the service level agreements | 1d? | 2021-12-02 | 2021-12-02 | 134 | 20d |  | start no earlier than 2021-12-02 | Boniface Barrack; Naga Srinivas | 16h | 1,672 |

| ID | WBS | Task | Type | Duration | Start | Finish | Predecessors | Total slack | Free slack | Constraint | Resources | Work | Cost |
| --- | --- | --- | --- | --- | --- | --- | --- | --- | --- | --- | --- | --- | --- |
| 136 | 5.5 | **Post production support** |  | 6d? | 2021-12-03 | 2021-12-10 |  |  |  |  |  | 112h | 11,520 |
| 137 | 5.5.1 | Retesting the new version changes |  | 1d? | 2021-12-03 | 2021-12-03 |  | 15d | 0d |  | Diana James | 8h | 688 |
| 138 | 5.5.2 | Approval of new version changes |  | 1d? | 2021-12-06 | 2021-12-06 | 137 | 15d | 0d | start no earlier than 2021-12-06 | Boniface Barrack | 8h | 872 |
| 139 | 5.5.3 | Version Approval | milestone | 0d | 2021-12-06 | 2021-12-06 | 138 | 15d | 0d | start no earlier than 2021-12-06 |  |  |  |
| 140 | 5.5.4 | Implementing critical changes |  | 1d? | 2021-12-07 | 2021-12-07 | 139 | 15d | 0d | start no earlier than 2021-12-07 | Ryan Williamson | 8h | 728 |
| 141 | 5.5.5 | Regulatory maintainence and Compliances |  | 2d? | 2021-12-08 | 2021-12-09 | 140 | 15d |  | finish no earlier than 2021-12-09 | Shaun Micheals | 16h | 1,552 |
| 142 | 5.5.6 | Residual Error fixes |  | 1d? | 2021-12-10 | 2021-12-10 |  | 14d |  | start no earlier than 2021-12-10 | Ashley Robertson | 8h | 704 |
| 143 | 5.6.7 | **Montly Status Meeting** |  | 151d | 2021-05-03 | 2021-12-03 |  |  |  |  |  | 64h | 6,976 |
| 144 | 5.6.7.1 | Montly Status Meeting 1 |  | 1d | 2021-05-03 | 2021-05-03 |  | 162d | 0d |  | Boniface Barrack | 8h | 872 |
| 145 | 5.6.7.2 | Montly Status Meeting 2 |  | 1d | 2021-05-04 | 2021-05-04 | 144 | 162d | 0d |  | Boniface Barrack | 8h | 872 |
| 146 | 5.6.7.3 | Montly Status Meeting 3 |  | 1d | 2021-05-05 | 2021-05-05 | 145 | 162d | 0d |  | Boniface Barrack | 8h | 872 |
| 147 | 5.6.7.4 | Montly Status Meeting 4 |  | 1d | 2021-05-06 | 2021-05-06 | 146 | 162d | 86d | finish no later than 2021-12-27 | Boniface Barrack | 8h | 872 |
| 148 | 5.6.7.5 | Montly Status Meeting 5 |  | 1d | 2021-09-08 | 2021-09-08 | 147 | 76d |  | start no earlier than 2021-09-08 | Boniface Barrack | 8h | 872 |
| 149 | 5.6.7.6 | Montly Status Meeting 6 |  | 1d | 2021-12-29 | 2021-12-29 | 148 | 0d |  | as late as possible | Boniface Barrack | 8h | 872 |
| 150 | 5.6.7.7 | Montly Status Meeting 7 |  | 1d | 2021-12-30 | 2021-12-30 | 149, 154FS-1d, 158 | 0d |  | start no earlier than 2021-11-08 | Boniface Barrack | 8h | 872 |
| 151 | 5.6.7.8 | Montly Status Meeting 8 |  | 1d | 2021-12-31 | 2021-12-31 | 150 | 0d |  | start no earlier than 2021-12-08 | Boniface Barrack | 8h | 872 |
| 152 | 5.5.7 | Project Monitoring & Controlling Phase End | milestone | 0d | 2021-12-10 | 2021-12-10 |  | 15d |  | start no earlier than 2021-12-10 |  |  |  |
| 153 | 6 | **Project Closing Phase** |  | 14d? | 2021-12-13 | 2021-12-31 |  |  |  |  |  | 128h | 163,088 |
| 154 | 6.1 | **Evaluation Reporting** |  | 5d? | 2021-12-13 | 2021-12-17 |  | 8d |  |  |  | 48h | 5,016 |
| 155 | 6.1.1 | Collection and Evaluation of performances of the application |  | 2d | 2021-12-13 | 2021-12-14 |  | 11d | 1d | start no earlier than 2021-12-13 | Boniface Barrack | 16h | 1,744 |
| 156 | 6.1.2 | Formal Acceptability from the users |  | 1d? | 2021-12-15 | 2021-12-15 | 155FS-1d | 10d |  | start no earlier than 2021-12-15 | Boniface Barrack; Naga Srinivas | 16h | 1,672 |
| 157 | 6.1.3 | Lessons learnt document analysis |  | 2d | 2021-12-16 | 2021-12-17 |  | 8d |  | start no earlier than 2021-12-16 | Naga Srinivas | 16h | 1,600 |
| 158 | 6.2 | **Benfit Analysis Reporting** |  | 7d | 2021-12-13 | 2021-12-21 |  | 5d |  |  |  | 16h | 1,552 |
| 159 | 6.2.1 | Highlighting of web application features |  | 1d | 2021-12-13 | 2021-12-13 |  | 11d | 6d |  | Josephine Joel | 8h | 752 |
| 160 | 6.2.2 | Brief summary of final product or service |  | 1d | 2021-12-21 | 2021-12-21 | 159FF | 5d |  | start no earlier than 2021-12-21 | Naga Srinivas | 8h | 800 |

Notes:
- 143: Occur ass soon as possible

| ID | WBS | Task | Type | Duration | Start | Finish | Predecessors | Total slack | Free slack | Constraint | Resources | Work | Cost |
| --- | --- | --- | --- | --- | --- | --- | --- | --- | --- | --- | --- | --- | --- |
| 161 | 6.3 | **Project Status Reporting** |  | 14d? | 2021-12-13 | 2021-12-31 |  | 0d |  |  |  | 64h | 6,520 |
| 162 | 6.3.1 | Operational and Support documentation |  | 1d? | 2021-12-13 | 2021-12-13 |  | 10d | 0d |  | Naga Srinivas; Shaun Micheals | 16h | 1,576 |
| 163 | 6.3.2 | Phase closure documentation |  | 1d? | 2021-12-15 | 2021-12-15 | 162FS+1d | 10d | 0d |  | Naga Srinivas | 8h | 800 |
| 164 | 6.3.3 | Scope, quality and objective reporting |  | 2d | 2021-12-15 | 2021-12-16 | 163FS-1d | 10d |  |  | Naga Srinivas | 16h | 1,600 |
| 165 | 6.3.4 | Genrating Monthly and weekly status reports |  | 1d | 2021-12-29 | 2021-12-29 |  | 2d |  | start no earlier than 2021-12-29 | Naga Srinivas | 8h | 800 |
| 166 | 6.3.5 | Successful Project Reporting | milestone | 0d | 2021-12-29 | 2021-12-29 |  | 3d |  | start no earlier than 2021-12-29 | Naga Srinivas |  |  |
| 167 | 6.3.6 | Project Review Documentation |  | 1d? | 2021-12-30 | 2021-12-30 |  | 1d |  | start no earlier than 2021-12-30 | Boniface Barrack | 8h | 872 |
| 168 | 6.3.7 | Release the project Resoures |  | 1d? | 2021-12-31 | 2021-12-31 | 167FS-1d | 0d |  | start no earlier than 2021-12-31 | Boniface Barrack | 8h | 872 |
| 169 | 6.3.8 | Project Closing Phase End | milestone | 0d | 2021-12-31 | 2021-12-31 |  | 1d |  | start no earlier than 2021-12-31 |  |  |  |
| 170 | 6.3.9 | **Contingency** |  | 71d? | 2021-09-20 | 2021-12-30 |  |  |  |  |  |  | 150,000 |
| 171 | 6.3.9.1 | Contingency #1 |  | 31d? | 2021-09-20 | 2021-11-01 |  | 35d | 0d | finish no earlier than 2021-11-01 |  |  | 50,000 |
| 172 | 6.3.9.2 | Contingency #2 |  | 5d? | 2021-11-02 | 2021-11-08 | 171 | 35d | 34d | finish no earlier than 2021-10-22 |  |  | 50,000 |
| 173 | 2.5.4.3 | Contingency #3 |  | 1d? | 2021-12-30 | 2021-12-30 | 172 | 1d |  | start no earlier than 2021-12-30 |  |  | 50,000 |
