# PROJ592_Week7_CourseProject_Schedule Compression_McLaughlin_20171126

Schedule from MS Project, 2017-01-09 to 2018-01-18, status date 2017-05-26, costs in $, A marks actual dates.
Microsoft

## Calendars

- Standard: Mon-Fri 08:00-12:00, 13:00-17:00; Sat-Sun off.

## Resources

| Resource | Unit | Rate | Cost per use |
| --- | --- | --- | --- |
| Customer |  |  |  |
| Accounting staff representative |  | 65 |  |
| Chief accounting officer |  | 125 |  |
| Hardware technicians I |  | 110 |  |
| Hardware technicians II |  | 80 |  |
| Hardware Manager |  | 125 |  |
| Software Lead developer |  | 100 |  |
| Lead Testing manager |  | 90 |  |
| Logistics manager |  | 150 |  |
| Project manager |  | 150 |  |
| Sales department manager |  | 150 |  |
| Software developers Senior |  | 100 |  |
| Software developers Jr |  | 70 |  |
| Building maintenance person |  | 50 |  |
| General manager |  | 200 |  |
| Architect |  | 100 |  |
| Builder |  | 40 |  |
| Designer |  | 50 |  |
| Electrician |  | 60 |  |
| HVAC tech |  | 40 |  |
| Painter |  | 40 |  |
| Purchasing Agent |  | 50 |  |
| Computer | each | 8500 |  |
| Servers | each | 5000 |  |
| Cable | per 100 feet | 200 |  |
| Routers | each | 3000 |  |
| Construction materials |  |  | 50000 |
| Racks and etc. |  |  | 20000 |
| Hardware Tech contract |  | 120 |  |
| Procurement Agent |  | 65 |  |
| Test facilitator |  | 85 |  |
| Users |  | 40 |  |
| Logistics Associate |  | 95 |  |
| Contract builder |  | 100 |  |
| Contract Software Developer |  | 200 |  |
| Contract Hardware tech |  | 200 |  |
| Project manager assistant |  | 75 |  |
| Sales department representative |  | 60 |  |

## Schedule

| ID | WBS | Task | Type | Duration | Start | Finish | Predecessors | Complete | Remaining | Baseline start | Baseline finish | Baseline duration | Total slack | Free slack | Constraint | Resources | Work | Actual work | Cost | Baseline cost | Actual cost |
| --- | --- | --- | --- | --- | --- | --- | --- | --- | --- | --- | --- | --- | --- | --- | --- | --- | --- | --- | --- | --- | --- |
| 1 | 1 | project plan published |  | 2d | 2017-01-09 A | 2017-01-10 A |  | 100% |  | 2017-01-09 | 2017-01-10 | 2d |  |  |  | Project manager | 16h | 16h | 2,400 | 2,400 | 2,400 |
| 2 | 2 | **Remodel facility** |  | 133.76d | 2017-01-11 A | 2017-07-17 |  | 74% | 35.43d | 2017-01-11 | 2017-06-27 | 120d | 25d |  |  |  | 3034h | 2407.15h | 271,900 | 236,900 | 224,133.6 |
| 3 | 2.1 | Facilities for new hardware designed |  | 25d | 2017-01-11 A | 2017-02-14 A | 1 | 100% |  | 2017-01-11 | 2017-02-14 | 25d |  |  |  | Architect; General manager [50%]; Hardware Manager [50%]; Designer | 360h | 360h | 44,500 | 44,500 | 44,500 |
| 4 | 2.2 | **New IT room constructed** |  | 78.76d | 2017-02-15 A | 2017-06-05 |  | 93% | 5.67d | 2017-02-15 | 2017-05-16 | 65d | 5d |  |  |  | 2110h | 2047.15h | 183,000 | 148,000 | 179,633.6 |
| 5 | 2.2.1 | Basic construction |  | 40d | 2017-02-15 A | 2017-04-11 A | 3 | 100% |  | 2017-02-15 | 2017-04-11 | 40d |  |  |  | Builder [200%]; Electrician; HVAC tech; Building maintenance person; Construction materials | 1360h | 1360h | 126,600 | 111,600 | 126,600 |
| 6 | 2.2.2 | HVAC installation |  | 15d | 2017-04-12 A | 2017-05-02 A | 5 | 100% |  | 2017-04-12 | 2017-05-02 | 15d |  |  |  | HVAC tech [200%]; Building maintenance person; Builder | 300h | 300h | 12,300 | 12,300 | 12,300 |
| 7 | 2.2.3 | Fire suppression system installed |  | 15d | 2017-04-12 A | 2017-05-02 A | 5 | 100% |  | 2017-04-12 | 2017-05-02 | 15d |  |  |  | Builder; Electrician; Designer; Hardware technicians I | 282h | 282h | 35,900 | 15,900 | 35,900 |
| 8 | 2.2.4 | Paint and final clean up |  | 10d | 2017-05-03 A | 2017-06-05 | 6, 7 | 42% | 5.76d | 2017-05-03 | 2017-05-16 | 10d | 5d | 0d |  | Painter [200%]; Building maintenance person; Hardware Manager [10%] | 168h | 105.15h | 8,200 | 8,200 | 4,833.6 |
| 9 | 2.3 | Network cabling installed |  | 30d | 2017-06-05 | 2017-07-17 | 8 |  |  | 2017-05-17 | 2017-06-27 | 30d | 25d | 20d | start no earlier than 2017-05-26 | Hardware technicians II [200%]; Hardware Manager [10%]; Building maintenance person | 564h |  | 44,400 | 44,400 |  |
| 10 | 3 | **Hardware upgrade** |  | 143.76d | 2017-02-15 A | 2017-09-04 |  | 43% | 82.24d | 2017-02-15 | 2017-08-15 | 130d | 5d |  |  |  | 1586h | 360.18h | 255,400 | 230,400 | 105,921.09 |
| 11 | 3.1 | Specifications for hardware developed |  | 35d | 2017-02-15 A | 2017-04-04 A | 3 | 100% |  | 2017-02-15 | 2017-04-04 | 35d |  |  |  | Hardware Manager [50%]; Hardware technicians I; Project manager [20%]; Designer [50%] | 236h | 236h | 26,700 | 26,700 | 26,700 |
| 12 | 3.2 | procurement specifications written |  | 10d | 2017-04-05 A | 2017-04-18 A | 11 | 100% |  | 2017-04-05 | 2017-04-18 | 10d |  |  |  | Purchasing Agent; Project manager [25%]; Hardware Manager [50%] | 90h | 90h | 8,500 | 8,500 | 8,500 |
| 13 | 3.3 | Racks and supporting hardware procured |  | 20d | 2017-04-19 A | 2017-06-05 | 12 | 71% | 5.76d | 2017-04-19 | 2017-05-16 | 20d | 5d | 0d |  | Racks and etc.; Purchasing Agent [10%] | 16h | 11.39h | 20,800 | 20,800 | 20,569.6 |
| 14 | 3.4 | computers and servers procured |  | 35d | 2017-04-19 A | 2017-06-26 | 12 | 41% | 20.76d | 2017-04-19 | 2017-06-06 | 35d | 15d | 0d |  | Computer [4 each]; Purchasing Agent [10%]; Servers [4 each] | 28h | 11.39h | 70,400 | 55,400 | 28,689.89 |
| 15 | 3.5 | wireless system equipment procured |  | 15d | 2017-04-19 A | 2017-05-29 | 12 | 95% | 0.76d | 2017-04-19 | 2017-05-09 | 15d | 45d | 40d |  | Purchasing Agent [10%]; Routers [4 each] | 12h | 11.39h | 22,600 | 12,600 | 21,461.6 |
| 16 | 3.6 | **Hardware connected and tested** |  | 65d | 2017-06-05 | 2017-09-04 |  |  |  | 2017-05-17 | 2017-08-15 | 65d | 5d |  |  |  | 1204h |  | 106,400 | 106,400 |  |
| 17 | 3.6.1 | rack mounted equipment installed |  | 10d | 2017-06-05 | 2017-06-19 | 13, 8 |  |  | 2017-05-17 | 2017-05-30 | 10d | 5d | 0d | start no earlier than 2017-05-26 | Hardware technicians I; Hardware technicians II [200%]; Building maintenance person | 240h |  | 19,200 | 19,200 |  |
| 18 | 3.6.2 | computers installed and connected |  | 25d | 2017-06-26 | 2017-07-31 | 17, 14 |  |  | 2017-06-07 | 2017-07-11 | 25d | 15d | 10d |  | Hardware Manager [10%]; Hardware technicians I; Hardware technicians II | 340h |  | 32,900 | 32,900 |  |
| 19 | 3.6.3 | servers installed and connected |  | 25d | 2017-06-19 | 2017-07-24 | 17 |  |  | 2017-05-31 | 2017-07-04 | 25d | 5d | 0d |  | Hardware Manager [10%]; Hardware technicians I; Hardware technicians II | 60h |  | 6,300 | 6,300 |  |
| 20 | 3.6.4 | wireless systems installed |  | 15d | 2017-07-24 | 2017-08-14 | 19, 15 |  |  | 2017-07-05 | 2017-07-25 | 15d | 5d | 0d |  | Hardware Manager [10%]; Hardware technicians II [200%] | 252h |  | 20,700 | 20,700 |  |
| 21 | 3.6.5 | all final connections made and tested |  | 15d | 2017-08-14 | 2017-09-04 | 19, 20, 9, 18 |  |  | 2017-07-26 | 2017-08-15 | 15d | 5d | 0d |  | Hardware Manager [10%]; Hardware technicians I; Hardware technicians II [200%] | 312h |  | 27,300 | 27,300 |  |
| 22 | 3.6.6 | Hardware upgrade complete | milestone | 0d | 2017-09-04 | 2017-09-04 | 21 |  |  | 2017-08-15 | 2017-08-15 | 0d | 5d | 0d |  | Project manager |  |  |  |  |  |
| 23 | 4 | **software upgrade** |  | 178.76d | 2017-01-11 A | 2017-09-18 |  | 40% | 107.07d | 2017-01-11 | 2017-08-29 | 165d | 0d |  |  |  | 4172h | 1299.84h | 413,100 | 413,100 | 163,084 |
| 24 | 4.1 | Business requirements for software finalized |  | 10d | 2017-01-11 A | 2017-01-24 A | 1 | 100% |  | 2017-01-11 | 2017-01-24 | 10d |  |  |  | Project manager [50%]; General manager [50%]; Chief accounting officer [50%]; Logistics manager [50%]; Sales department manager [50%] | 200h | 200h | 31,000 | 31,000 | 31,000 |

| ID | WBS | Task | Type | Duration | Start | Finish | Predecessors | Complete | Remaining | Baseline start | Baseline finish | Baseline duration | Total slack | Constraint | Resources | Work | Actual work | Cost | Baseline cost | Actual cost |
| --- | --- | --- | --- | --- | --- | --- | --- | --- | --- | --- | --- | --- | --- | --- | --- | --- | --- | --- | --- | --- |
| 25 | 4.2 | **Business unit's requirements verified** |  | 70d | 2017-01-25 A | 2017-05-02 A |  | 100% |  | 2017-01-25 | 2017-05-02 | 70d |  |  |  | 972h | 972h | 115,300 | 115,300 | 115,300 |
| 26 | 4.2.1 | Adapted to specific needs of business units |  | 25d | 2017-01-25 A | 2017-02-28 A | 24 | 100% |  | 2017-01-25 | 2017-02-28 | 25d |  |  | Accounting staff representative; Logistics manager | 400h | 400h | 43,000 | 43,000 | 43,000 |
| 27 | 4.2.2 | Business units accept the adaptions |  | 45d | 2017-03-01 A | 2017-05-02 A | 26 | 100% |  | 2017-03-01 | 2017-05-02 | 45d |  |  | Chief accounting officer [50%]; Logistics manager [50%]; Project manager [20%]; Sales department manager [50%]; Logistics Associate | 572h | 572h | 72,300 | 72,300 | 72,300 |
| 28 | 4.3 | backward compatibly requirements established |  | 10d | 2017-03-01 A | 2017-03-14 A | 26 | 100% |  | 2017-03-01 | 2017-03-14 | 10d |  |  | General manager [25%]; Project manager [50%] | 60h | 60h | 10,000 | 10,000 | 10,000 |
| 29 | 4.4 | Software design outlined |  | 15d | 2017-05-03 A | 2017-06-12 | 27, 28 | 28% | 10.76d | 2017-05-03 | 2017-05-23 | 15d | 0d |  | Software developers Senior; Software Lead developer | 240h | 67.84h | 24,000 | 24,000 | 6,784 |
| 30 | 4.5 | **software development** |  | 70d | 2017-06-12 | 2017-09-18 |  |  |  | 2017-05-24 | 2017-08-29 | 70d | 0d |  |  | 2700h |  | 232,800 | 232,800 |  |
| 31 | 4.5.1 | Accounting Module |  | 30d | 2017-06-12 | 2017-07-24 | 29 |  |  | 2017-05-24 | 2017-07-04 | 30d | 10d | start no earlier than 2017-05-26 | Accounting staff representative; Software developers Jr; Software developers Senior | 640h |  | 48,400 | 48,400 |  |
| 32 | 4.5.2 | Sales module |  | 25d | 2017-06-12 | 2017-07-17 | 29 |  |  | 2017-05-24 | 2017-06-27 | 25d | 15d | start no earlier than 2017-05-26 | Software developers Jr; Software developers Senior | 300h |  | 24,000 | 24,000 |  |
| 33 | 4.5.3 | inventory module |  | 40d | 2017-06-12 | 2017-08-07 | 29 |  |  | 2017-05-24 | 2017-07-18 | 40d | 0d | start no earlier than 2017-05-26 | Software developers Jr; Software developers Senior [50%]; Procurement Agent [50%]; Logistics Associate | 960h |  | 79,200 | 79,200 |  |
| 34 | 4.5.4 | All module integrated |  | 15d | 2017-07-31 | 2017-08-21 | 31FS-5d, 32FS-5d, 33FS-5d |  |  | 2017-07-12 | 2017-08-01 | 15d | 0d |  | Software developers Jr; Software developers Senior; Software Lead developer; Lead Testing manager | 480h |  | 43,200 | 43,200 |  |
| 35 | 4.5.5 | **Initial software review.** |  | 20d | 2017-08-21 | 2017-09-18 |  |  |  | 2017-08-02 | 2017-08-29 | 20d | 0d |  |  | 320h |  | 38,000 | 38,000 |  |
| 36 | 4.5.5.1 | Software reviewed vs. the requirements |  | 5d | 2017-08-21 | 2017-08-28 | 34 |  |  | 2017-08-02 | 2017-08-08 | 5d | 0d |  | General manager; Project manager | 80h |  | 14,000 | 14,000 |  |
| 37 | 4.5.5.2 | Deficiencies identified and resolved |  | 15d | 2017-08-28 | 2017-09-18 | 36 |  |  | 2017-08-09 | 2017-08-29 | 15d | 0d |  | Software developers Senior; Software Lead developer | 240h |  | 24,000 | 24,000 |  |
| 38 | 4.5.6 | Software creation complete | milestone | 0d | 2017-09-18 | 2017-09-18 | 37 |  |  | 2017-08-29 | 2017-08-29 | 0d | 0d |  | Project manager |  |  |  |  |  |
| 39 | 5 | **Tests and acceptance** |  | 98d | 2017-09-04 | 2018-01-18 |  |  |  | 2017-08-16 | 2017-12-29 | 98d | 0d |  |  | 2788h |  | 232,300 | 232,300 |  |
| 40 | 5.1 | Full hardware testing |  | 5d | 2017-09-04 | 2017-09-11 | 22 |  |  | 2017-08-16 | 2017-08-22 | 5d | 5d |  | Hardware Manager; Hardware technicians I; Hardware technicians II | 120h |  | 12,600 | 12,600 |  |
| 41 | 5.2 | Software modules tested individually |  | 15d | 2017-09-18 | 2017-10-09 | 40, 38 |  |  | 2017-08-30 | 2017-09-19 | 15d | 0d |  | Software developers Jr; Software developers Senior; Software Lead developer | 360h |  | 32,400 | 32,400 |  |
| 42 | 5.3 | Modules integrated into full system |  | 15d | 2017-10-09 | 2017-10-30 | 41 |  |  | 2017-09-20 | 2017-10-10 | 15d | 0d |  | Software developers Senior; Software Lead developer | 240h |  | 24,000 | 24,000 |  |
| 43 | 5.4 | Full system tested by technicians |  | 5d | 2017-10-30 | 2017-11-06 | 42 |  |  | 2017-10-11 | 2017-10-17 | 5d | 0d |  | Hardware technicians I; Lead Testing manager; Software developers Senior; Test facilitator | 120h |  | 11,700 | 11,700 |  |
| 44 | 5.5 | Problems with full system resolved |  | 10d | 2017-11-01 | 2017-11-15 | 43FS-3d |  |  | 2017-10-13 | 2017-10-26 | 10d | 0d |  | Hardware technicians I; Software developers Senior | 120h |  | 12,800 | 12,800 |  |
| 45 | 5.6 | Full system tested by representative |  | 15d | 2017-11-15 | 2017-12-06 | 44 |  |  | 2017-10-27 | 2017-11-16 | 15d | 0d |  | Accounting staff representative; Logistics manager [50%]; Procurement Agent [50%]; Software Lead developer; Users [300%] | 600h |  | 37,200 | 37,200 |  |
| 46 | 5.7 | Tests of system accepted by representatives |  | 20d | 2017-12-06 | 2018-01-03 | 45 |  |  | 2017-11-17 | 2017-12-14 | 20d | 0d |  | Accounting staff representative; Logistics manager [25%]; Procurement Agent; Software Lead developer | 70h |  | 8,300 | 8,300 |  |
| 47 | 5.8 | **Parallel operations of systems** |  | 53d | 2017-11-06 | 2018-01-18 |  |  |  | 2017-10-18 | 2017-12-29 | 53d | 0d |  |  | 1158h |  | 93,300 | 93,300 |  |
| 48 | 5.8.1 | new and old systems operation by users |  | 35d | 2017-11-06 | 2017-12-25 | 43 |  |  | 2017-10-18 | 2017-12-05 | 35d | 18d |  | Accounting staff representative; Logistics manager [25%]; Procurement Agent; Purchasing Agent; Software developers Senior; Users [300%] | 830h |  | 49,300 | 49,300 |  |
| 49 | 5.8.2 | acceptance of new system by departments |  | 10d | 2018-01-03 | 2018-01-17 | 46 |  |  | 2017-12-15 | 2017-12-28 | 10d | 0d |  | Chief accounting officer; General manager; Procurement Agent; Sales department manager | 320h |  | 43,200 | 43,200 |  |
| 50 | 5.8.3 | shut down of old system |  | 1d | 2018-01-17 | 2018-01-18 | 49 |  |  | 2017-12-29 | 2017-12-29 | 1d | 0d |  | Software Lead developer | 8h |  | 800 | 800 |  |
| 51 | 6 | Project complete | milestone | 0d | 2018-01-18 | 2018-01-18 | 50 |  |  | 2017-12-29 | 2017-12-29 | 0d | 0d |  | General manager; Project manager |  |  |  |  |  |
