# S15Lab_Dickison

Schedule from MS Project, 2018-04-12 to 2018-10-04.

## Calendars

- Standard: Mon-Fri 08:00-12:00, 13:00-17:00; Sat-Sun off.

## Resources

| Resource |
| --- |
| BackHoe |
| PileDriver |
| Crane |
| Concrete Pump |
| Girder Supplier |
| Concrete |

## Schedule

| ID | Task | Type | Duration | Start | Finish | Predecessors | Resources | Work |
| --- | --- | --- | --- | --- | --- | --- | --- | --- |
| 1 | Move on site | manual | 2d | 2018-04-12 | 2018-04-13 |  |  |  |
| 2 | Rough Grade site | manual | 5d | 2018-04-16 | 2018-04-20 | 1 |  |  |
| 3 | Excavate for footing or pile cap | manual | 2d | 2018-04-23 | 2018-04-24 | 2 | BackHoe | 16h |
| 4 | Drive Pile cluster | manual | 3d | 2018-04-25 | 2018-04-27 | 3 | PileDriver | 24h |
| 5 | Form and reinf. Footing or pile cap | manual | 3d | 2018-04-30 | 2018-05-02 | 4 |  |  |
| 6 | Place footing or pile cap concrete | manual | 1d | 2018-05-02 | 2018-05-02 |  | Concrete Pump | 8h |
| 7 | Strip footing or pile cap forms | manual | 1d | 2018-05-03 | 2018-05-03 |  |  |  |
| 8 | form and reinf. Bent columns | manual | 2d | 2018-05-04 | 2018-05-07 |  | Crane | 16h |
| 9 | place bent column concrete | manual | 1d | 2018-05-08 | 2018-05-08 |  | Concrete Pump | 8h |
| 10 | Strip bent column forms | manual | 1d | 2018-05-09 | 2018-05-09 |  | Crane | 8h |
| 11 | Form and reinf. Bent caps | manual | 5d | 2018-05-10 | 2018-05-16 |  | Crane | 40h |
| 12 | Place bent cap concrete | manual | 1d | 2018-05-17 | 2018-05-17 |  | Concrete Pump | 8h |
| 13 | Strip bent cap forms | manual | 2d | 2018-05-18 | 2018-05-21 |  | Crane | 16h |
| 14 | Install girders- Bay 1 | manual | 1d | 2018-05-21 | 2018-05-21 |  | Girder Supplier | 8h |
| 15 | Form and reinf. Midbay slab | manual | 7d | 2018-05-21 | 2018-05-29 |  |  |  |
| 16 | Place midbay slab concrete | manual | 1d | 2018-05-30 | 2018-05-30 |  | Concrete Pump | 8h |
| 17 | Strip midbay slab forms | manual | 3d | 2018-05-31 | 2018-06-04 |  | Crane | 24h |
| 18 | Form and reinf. Endbay slabs | manual | 5d | 2018-06-05 | 2018-06-11 |  |  |  |
| 19 | Place endbay slab concrete | manual | 1d | 2018-06-12 | 2018-06-12 |  | Concrete Pump | 8h |
| 20 | Strip endbay slab forms | manual | 2d | 2018-06-13 | 2018-06-14 |  | Crane | 16h |
| 21 | Set aliminum rails | manual | 3d | 2018-06-15 | 2018-06-19 |  |  |  |
| 22 | Install Girder- Bay 2 | manual | 1d | 2018-06-20 | 2018-06-20 |  | Girder Supplier | 8h |
| 23 | Form and reinf. Midbay slab | manual | 7d | 2018-06-21 | 2018-06-29 |  |  |  |
| 24 | Place midbay slab concrete | manual | 1d | 2018-07-02 | 2018-07-02 |  | Concrete Pump | 8h |
| 25 | Strip midbay slab forms | manual | 3d | 2018-07-03 | 2018-07-05 |  | Crane | 24h |
| 26 | Form and reinf. Endbay slabs | manual | 7d | 2018-07-04 | 2018-07-12 |  |  |  |
| 27 | Place endbay slab concrete | manual | 1d | 2018-07-16 | 2018-07-16 |  |  |  |
| 28 | Strip endbay slab forms | manual | 2d | 2018-07-18 | 2018-07-19 |  | Crane | 16h |
| 29 | Set aliminum rails | manual | 3d | 2018-07-20 | 2018-07-24 |  |  |  |
| 30 | Install Girder- Bay 3 | manual | 1d | 2018-07-25 | 2018-07-25 |  | Girder Supplier | 8h |
| 31 | Form and reinf. Midbay slab | manual | 7d | 2018-07-26 | 2018-08-03 |  |  |  |
| 32 | Place midbay slab concrete | manual | 1d | 2018-08-06 | 2018-08-06 |  | Concrete Pump | 8h |
| 33 | Strip midbay slab forms | manual | 3d | 2018-08-07 | 2018-08-09 |  | Crane | 24h |
| 34 | Form and reinf. Endbay slabs | manual | 7d | 2018-08-10 | 2018-08-20 |  |  |  |
| 35 | Place endbay slab concrete | manual | 1d | 2018-08-21 | 2018-08-21 |  |  |  |
| 36 | Strip endbay slab forms | manual | 2d | 2018-08-22 | 2018-08-23 |  | Crane | 16h |
| 37 | Set aliminum rails | manual | 3d | 2018-08-24 | 2018-08-28 |  |  |  |
| 38 | Install Girder- Bay 4 | manual | 1d | 2018-08-29 | 2018-08-29 |  | Girder Supplier | 8h |
| 39 | Form and reinf. Midbay slab | manual | 7d | 2018-08-30 | 2018-09-07 |  |  |  |
| 40 | Place midbay slab concrete | manual | 1d | 2018-09-10 | 2018-09-10 |  | Concrete Pump | 8h |
| 41 | Strip midbay slab forms | manual | 3d | 2018-09-11 | 2018-09-13 |  |  |  |
| 42 | Form and reinf. Endbay slabs | manual | 7d | 2018-09-14 | 2018-09-24 |  |  |  |
| 43 | Place endbay slab concrete | manual | 1d | 2018-09-25 | 2018-09-25 |  | Concrete Pump | 8h |
| 44 | Strip endbay slab forms | manual | 2d | 2018-09-26 | 2018-09-27 |  | Crane | 16h |
| 45 | Set aliminum rails | manual | 3d | 2018-09-28 | 2018-10-02 |  |  |  |
| 46 | Move off and Clean up | manual | 2d | 2018-10-03 | 2018-10-04 |  |  |  |
