# TeamB_WBS(March31v2)

Schedule from MS Project, 2018-03-05 to 2019-09-24, costs in $.

## Calendars

- Standard: Mon-Fri 08:00-12:00, 13:00-17:00; Sat-Sun off. Exceptions (off unless hours are given): 2018-11-22 (Thanksgiving), 2018-12-24 to 2018-12-26 (Christmas), 2019-01-01 (New Years).

## Resources

| Resource | Rate |
| --- | --- |
| Project Manager | 200 |
| Project Sponsor |  |
| Contract Manager | 175 |
| Business Analyst 1 | 90 |
| Business Analyst 2 | 90 |
| Business Analyst 3 | 90 |
| Educational Advisor | 60 |
| Business Analyst 4 | 90 |
| Business Analyst Lead | 120 |
| Software Architect Lead | 130 |
| Graphic Designer 1 | 80 |
| Graphic Designer 2 | 80 |
| Software Architect 1 | 130 |
| Software Architect 2 | 130 |
| Software Developer 1 | 130 |
| Software Developer 2 | 130 |
| Subcontractor 1 | 130 |
| Database Analyst 1 | 100 |
| Software Developer 3 | 130 |
| Software Developer 4 | 130 |
| Subcontractor 2 | 130 |
| Database Analyst 2 | 100 |
| Software Developer Lead | 150 |
| Database Administrator | 120 |
| Database Analyst 3 | 100 |
| Database Analyst 4 | 100 |
| Technical Writer | 90 |
| Network Engineer | 120 |
| Network Administrator | 120 |
| Quality Assurance Manager | 120 |
| Software Tester 1 | 100 |
| Software Tester 2 | 100 |
| Software Tester 3 | 100 |
| Technical Support 1 | 50 |
| Technical Support 2 | 50 |
| Technical Support Lead | 65 |

## Schedule

| ID | WBS | Task | Type | Duration | Start | Finish | Predecessors | Baseline start | Baseline finish | Baseline duration | Total slack | Free slack | Constraint | Resources | Work | Cost | Baseline cost |
| --- | --- | --- | --- | --- | --- | --- | --- | --- | --- | --- | --- | --- | --- | --- | --- | --- | --- |
| 1 | 1 | E-Learning Educational Software |  | 402d | 2018-03-05 | 2019-09-24 |  | 2018-03-05 | 2019-09-24 | 402d | 0d |  | must start on 2018-03-05 |  |  |  |  |
| 2 | 2 | Start Project | milestone | 0d | 2018-03-05 | 2018-03-05 |  | 2018-03-05 | 2018-03-05 | 0d | 402d |  |  |  |  |  |  |
| 3 | 3 | **Project Charter Approval** |  | 34d? | 2018-03-05 | 2018-04-19 |  | 2018-03-05 | 2018-04-19 | 34d? | 0d |  | start no earlier than 2018-03-05 |  | 272h | 52,800 | 52,800 |
| 4 | 3.1 | Collect Requirements from Stakeholders |  | 7d | 2018-03-05 | 2018-03-13 |  | 2018-03-05 | 2018-03-13 | 7d | 0d |  | must start on 2018-03-05 | Project Manager | 56h | 11,200 | 11,200 |
| 5 | 3.2 | Develop Mission/Purpose |  | 1d | 2018-03-14 | 2018-03-14 | 4 | 2018-03-14 | 2018-03-14 | 1d | 0d |  | must start on 2018-03-14 | Project Manager | 8h | 1,600 | 1,600 |
| 6 | 3.3 | Identify Stakeholders |  | 1d | 2018-03-15 | 2018-03-15 | 5 | 2018-03-15 | 2018-03-15 | 1d | 0d |  | start no earlier than 2018-03-14 | Project Manager | 8h | 1,600 | 1,600 |
| 7 | 3.4 | Identify Objectives |  | 2d | 2018-03-16 | 2018-03-19 | 6 | 2018-03-16 | 2018-03-19 | 2d | 0d |  | start no earlier than 2018-03-13 | Project Manager | 16h | 3,200 | 3,200 |
| 8 | 3.5 | Identify Business Needs |  | 3d | 2018-03-20 | 2018-03-22 | 7 | 2018-03-20 | 2018-03-22 | 3d | 0d |  |  | Project Manager | 24h | 4,800 | 4,800 |
| 9 | 3.6 | Define Statement of Work |  | 3d | 2018-03-23 | 2018-03-27 | 4, 6, 8 | 2018-03-23 | 2018-03-27 | 3d | 0d |  |  | Project Manager | 24h | 4,800 | 4,800 |
| 10 | 3.7 | List Project Milestones |  | 2d | 2018-03-28 | 2018-03-29 | 9, 8 | 2018-03-28 | 2018-03-29 | 2d | 0d |  |  | Project Manager | 16h | 3,200 | 3,200 |
| 11 | 3.8 | Determine Budget |  | 3d | 2018-03-30 | 2018-04-03 | 8, 9, 10, 6 | 2018-03-30 | 2018-04-03 | 3d | 0d |  |  | Project Manager | 24h | 4,800 | 4,800 |
| 12 | 3.9 | Identify User Acceptance Criteria/Quality |  | 2d | 2018-04-04 | 2018-04-05 | 11 | 2018-04-04 | 2018-04-05 | 2d | 0d |  |  | Project Manager | 16h | 3,200 | 3,200 |
| 13 | 3.10 | Identify Major Risk |  | 3d | 2018-04-06 | 2018-04-10 | 12 | 2018-04-06 | 2018-04-10 | 3d | 0d |  |  | Project Manager | 24h | 4,800 | 4,800 |
| 14 | 3.11 | Gather charter information and insert into charter |  | 2d | 2018-04-11 | 2018-04-12 | 13 | 2018-04-11 | 2018-04-12 | 2d | 0d |  |  | Project Manager | 16h | 3,200 | 3,200 |
| 15 | 3.12 | Generate Timeline |  | 1d? | 2018-04-13 | 2018-04-13 | 14 | 2018-04-13 | 2018-04-13 | 1d? | 0d |  |  | Project Manager | 8h | 1,600 | 1,600 |
| 16 | 3.13 | Formalize Project Charter |  | 2d | 2018-04-16 | 2018-04-17 | 15 | 2018-04-16 | 2018-04-17 | 2d | 0d |  |  | Project Manager | 16h | 3,200 | 3,200 |
| 17 | 3.14 | Project Manager Approval |  | 1d | 2018-04-18 | 2018-04-18 | 16 | 2018-04-18 | 2018-04-18 | 1d | 0d |  |  | Project Manager | 8h | 1,600 | 1,600 |
| 18 | 3.15 | Sponsor Approval |  | 1d | 2018-04-19 | 2018-04-19 | 17 | 2018-04-19 | 2018-04-19 | 1d | 0d |  |  | Project Sponsor | 8h |  |  |
| 19 | 3.16 | Project charter approved | milestone | 0d | 2018-04-19 | 2018-04-19 | 18 | 2018-04-19 | 2018-04-19 | 0d | 0d |  |  |  |  |  |  |
| 20 | 4 | **Develop Project Scope Statement** |  | 20d | 2018-04-20 | 2018-05-17 | 3 | 2018-04-20 | 2018-05-17 | 20d | 0d |  | start no earlier than 2018-03-05 |  | 160h | 30,400 | 30,400 |
| 21 | 4.1 | Establish Detailed SOW |  | 2d | 2018-04-20 | 2018-04-23 |  | 2018-04-20 | 2018-04-23 | 2d | 0d |  |  | Project Manager | 16h | 3,200 | 3,200 |
| 22 | 4.2 | Determine Product Solution |  | 1d | 2018-04-24 | 2018-04-24 | 21 | 2018-04-24 | 2018-04-24 | 1d | 0d |  |  | Project Manager | 8h | 1,600 | 1,600 |
| 23 | 4.3 | Determine Deliverables |  | 2d | 2018-04-25 | 2018-04-26 | 22 | 2018-04-25 | 2018-04-26 | 2d | 0d |  |  | Project Manager | 16h | 3,200 | 3,200 |
| 24 | 4.4 | Identify Objectives |  | 1d | 2018-04-27 | 2018-04-27 | 23 | 2018-04-27 | 2018-04-27 | 1d | 0d |  |  | Project Manager | 8h | 1,600 | 1,600 |
| 25 | 4.5 | Identify Project Assumption |  | 2d | 2018-04-30 | 2018-05-01 | 24, 21, 22, 23 | 2018-04-30 | 2018-05-01 | 2d | 0d |  | must start on 2018-04-30 | Project Manager | 16h | 3,200 | 3,200 |
| 26 | 4.6 | Identify project constraints |  | 2d | 2018-05-02 | 2018-05-03 | 21, 22, 23, 24 | 2018-05-02 | 2018-05-03 | 2d | 6d | 0d | start no earlier than 2018-04-30 | Project Manager | 16h | 3,200 | 3,200 |
| 27 | 4.7 | List of Exclusions |  | 2d | 2018-05-04 | 2018-05-07 | 26 | 2018-05-04 | 2018-05-07 | 2d | 6d | 0d |  | Project Manager | 16h | 3,200 | 3,200 |
| 28 | 4.8 | Detailed Acceptance Criteria |  | 2d | 2018-05-08 | 2018-05-09 | 27 | 2018-05-08 | 2018-05-09 | 2d | 6d |  |  | Project Manager | 16h | 3,200 | 3,200 |
| 29 | 4.9 | Identify Technical Requirements |  | 3d | 2018-05-10 | 2018-05-14 |  | 2018-05-10 | 2018-05-14 | 3d | 0d |  | start no earlier than 2018-05-10 | Project Manager | 24h | 4,800 | 4,800 |
| 30 | 4.10 | Document information in scope statement document |  | 1d | 2018-05-15 | 2018-05-15 | 29 | 2018-05-15 | 2018-05-15 | 1d | 0d |  |  | Project Manager | 8h | 1,600 | 1,600 |
| 31 | 4.11 | Project Manager Approval |  | 1d | 2018-05-16 | 2018-05-16 | 30 | 2018-05-16 | 2018-05-16 | 1d | 0d |  |  | Project Manager | 8h | 1,600 | 1,600 |
| 32 | 4.12 | Sponsor Approval |  | 1d | 2018-05-17 | 2018-05-17 | 31 | 2018-05-17 | 2018-05-17 | 1d | 0d |  |  | Project Sponsor | 8h |  |  |
| 33 | 4.13 | Project scope statement approved | milestone | 0d | 2018-05-17 | 2018-05-17 | 32 | 2018-05-17 | 2018-05-17 | 0d | 0d |  | start no earlier than 2018-05-17 |  |  |  |  |

| ID | WBS | Task | Type | Duration | Start | Finish | Predecessors | Baseline start | Baseline finish | Baseline duration | Total slack | Free slack | Constraint | Resources | Work | Cost | Baseline cost |
| --- | --- | --- | --- | --- | --- | --- | --- | --- | --- | --- | --- | --- | --- | --- | --- | --- | --- |
| 34 | 5 | **Project Contract Approval** |  | 16d | 2018-05-18 | 2018-06-08 | 20 | 2018-05-18 | 2018-06-08 | 16d | 0d |  |  |  | 128h | 23,000 | 23,000 |
| 35 | 5.1 | Develop SOW |  | 2d | 2018-05-18 | 2018-05-21 |  | 2018-05-18 | 2018-05-21 | 2d | 0d |  |  | Contract Manager | 16h | 2,800 | 2,800 |
| 36 | 5.2 | Evaluate Criteria (Terms, Agreements) |  | 2d | 2018-05-22 | 2018-05-23 | 35 | 2018-05-22 | 2018-05-23 | 2d | 0d |  |  | Contract Manager | 16h | 2,800 | 2,800 |
| 37 | 5.3 | Identify Deliverables |  | 1d | 2018-05-24 | 2018-05-24 | 36 | 2018-05-24 | 2018-05-24 | 1d | 0d |  |  | Project Manager | 8h | 1,600 | 1,600 |
| 38 | 5.4 | Proposed timelines |  | 1d | 2018-05-25 | 2018-05-25 | 37 | 2018-05-25 | 2018-05-25 | 1d | 0d |  |  | Project Manager | 8h | 1,600 | 1,600 |
| 39 | 5.5 | Invoice/Payment |  | 1d | 2018-05-28 | 2018-05-28 | 38 | 2018-05-28 | 2018-05-28 | 1d | 0d |  |  | Project Manager | 8h | 1,600 | 1,600 |
| 40 | 5.6 | Draft contract |  | 2d | 2018-05-29 | 2018-05-30 | 39 | 2018-05-29 | 2018-05-30 | 2d | 0d |  |  | Project Manager | 16h | 3,200 | 3,200 |
| 41 | 5.7 | Review Contract |  | 2d | 2018-05-31 | 2018-06-01 | 40 | 2018-05-31 | 2018-06-01 | 2d | 0d |  |  | Project Manager | 16h | 3,200 | 3,200 |
| 42 | 5.8 | Contract Adjustments |  | 1d | 2018-06-04 | 2018-06-04 | 41 | 2018-06-04 | 2018-06-04 | 1d | 0d |  |  | Project Manager | 8h | 1,600 | 1,600 |
| 43 | 5.9 | Finalized contract |  | 1d | 2018-06-05 | 2018-06-05 | 42 | 2018-06-05 | 2018-06-05 | 1d | 0d |  |  | Contract Manager | 8h | 1,400 | 1,400 |
| 44 | 5.10 | Project Manager Sign-off |  | 2d | 2018-06-06 | 2018-06-07 | 43 | 2018-06-06 | 2018-06-07 | 2d | 0d |  |  | Project Manager | 16h | 3,200 | 3,200 |
| 45 | 5.11 | Project Sponsor Sign-off |  | 1d | 2018-06-08 | 2018-06-08 | 44 | 2018-06-08 | 2018-06-08 | 1d | 0d |  |  | Project Sponsor | 8h |  |  |
| 46 | 5.12 | Contract approved | milestone | 0d | 2018-06-08 | 2018-06-08 | 45 | 2018-06-08 | 2018-06-08 | 0d | 0d |  |  |  |  |  |  |
| 47 | 6 | **Begin Kickoff Meeting** |  | 12d | 2018-06-11 | 2018-06-26 | 34 | 2018-06-11 | 2018-06-26 | 12d | 0d |  |  |  | 96h | 19,200 | 19,200 |
| 48 | 6.1 | Identify Project team |  | 2d | 2018-06-11 | 2018-06-12 |  | 2018-06-11 | 2018-06-12 | 2d | 0d |  |  | Project Manager | 16h | 3,200 | 3,200 |
| 49 | 6.2 | Schedule dates to meet project team |  | 2d | 2018-06-13 | 2018-06-14 | 48 | 2018-06-13 | 2018-06-14 | 2d | 0d |  |  | Project Manager | 16h | 3,200 | 3,200 |
| 50 | 6.3 | Get attendance confirmation from team |  | 2d | 2018-06-15 | 2018-06-18 | 49 | 2018-06-15 | 2018-06-18 | 2d | 0d |  |  | Project Manager | 16h | 3,200 | 3,200 |
| 51 | 6.4 | Discuss Project with team |  | 2d | 2018-06-19 | 2018-06-20 | 50 | 2018-06-19 | 2018-06-20 | 2d | 0d |  |  | Project Manager | 16h | 3,200 | 3,200 |
| 52 | 6.5 | Gather feedback |  | 2d | 2018-06-21 | 2018-06-22 | 51 | 2018-06-21 | 2018-06-22 | 2d | 0d |  |  | Project Manager | 16h | 3,200 | 3,200 |
| 53 | 6.6 | Document meeting |  | 2d | 2018-06-25 | 2018-06-26 | 52 | 2018-06-25 | 2018-06-26 | 2d | 0d |  |  | Project Manager | 16h | 3,200 | 3,200 |
| 54 | 6.7 | Kickoff meeting complete | milestone | 0d | 2018-06-26 | 2018-06-26 | 53 | 2018-06-26 | 2018-06-26 | 0d | 0d |  |  |  |  |  |  |
| 55 | 7 | **Business Requirements Gathered** |  | 27d | 2018-06-27 | 2018-08-02 | 47 | 2018-06-27 | 2018-08-02 | 27d | 0d |  | start no earlier than 2018-06-27 |  | 336h | 30,240 | 30,240 |
| 56 | 7.1 | Interview stakeholders |  | 3d | 2018-06-27 | 2018-06-29 |  | 2018-06-27 | 2018-06-29 | 3d | 0d |  | must start on 2018-06-27 | Business Analyst 1; Business Analyst 2 | 40h | 3,600 | 3,600 |
| 57 | 7.2 | Collect requirements |  | 2d | 2018-07-02 | 2018-07-03 | 56 | 2018-07-02 | 2018-07-03 | 2d | 4d | 0d | start no earlier than 2018-07-02 | Business Analyst 1; Business Analyst 2 | 16h | 1,440 | 1,440 |
| 58 | 7.3 | Evaluate pre-existing processes |  | 2d | 2018-07-04 | 2018-07-05 | 57 | 2018-07-04 | 2018-07-05 | 2d | 4d | 0d | start no earlier than 2018-07-04 | Business Analyst 1 | 16h | 1,440 | 1,440 |
| 59 | 7.4 | Define business processes |  | 3d | 2018-07-06 | 2018-07-10 | 58 | 2018-07-06 | 2018-07-10 | 3d | 4d | 0d |  | Business Analyst 3 | 24h | 2,160 | 2,160 |
| 60 | 7.5 | Identify business process modifications |  | 4d | 2018-07-11 | 2018-07-16 | 59 | 2018-07-11 | 2018-07-16 | 4d | 4d | 0d |  | Business Analyst 1; Business Analyst 2 | 64h | 5,760 | 5,760 |
| 61 | 7.6 | Define business solution requirements (behavioral conditions) |  | 3d | 2018-07-17 | 2018-07-19 | 60 | 2018-07-17 | 2018-07-19 | 3d | 4d | 0d |  | Business Analyst 1; Business Analyst 2; Educational Advisor | 64h | 5,040 | 5,040 |
| 62 | 7.7 | Identify affected business areas |  | 1d | 2018-07-20 | 2018-07-20 | 61 | 2018-07-20 | 2018-07-20 | 1d | 4d | 0d |  | Business Analyst 4 | 8h | 720 | 720 |
| 63 | 7.8 | Document requirements/process information |  | 2d | 2018-07-23 | 2018-07-24 | 62 | 2018-07-23 | 2018-07-24 | 2d | 4d | 0d |  | Business Analyst 4 | 16h | 1,440 | 1,440 |
| 64 | 7.9 | Analyze requirements |  | 4d | 2018-07-25 | 2018-07-30 | 63 | 2018-07-25 | 2018-07-30 | 4d | 4d | 0d |  | Business Analyst 1; Business Analyst 2 | 64h | 5,760 | 5,760 |
| 65 | 7.10 | Review requirements |  | 2d | 2018-07-31 | 2018-08-01 | 64 | 2018-07-31 | 2018-08-01 | 2d | 4d | 0d |  | Business Analyst Lead | 16h | 1,920 | 1,920 |
| 66 | 7.11 | Approve requirements |  | 1d | 2018-08-02 | 2018-08-02 | 65 | 2018-08-02 | 2018-08-02 | 1d | 4d | 0d |  | Business Analyst Lead | 8h | 960 | 960 |
| 67 | 7.12 | Collected business requirements | milestone | 0d | 2018-08-02 | 2018-08-02 | 66 | 2018-08-02 | 2018-08-02 | 0d | 4d |  |  |  |  |  |  |

| ID | WBS | Task | Type | Duration | Start | Finish | Predecessors | Baseline start | Baseline finish | Baseline duration | Total slack | Free slack | Constraint | Resources | Work | Cost | Baseline cost |
| --- | --- | --- | --- | --- | --- | --- | --- | --- | --- | --- | --- | --- | --- | --- | --- | --- | --- |
| 68 | 8 | **Develop Design Concept** |  | 32d | 2018-08-03 | 2018-09-17 | 55 | 2018-08-03 | 2018-09-17 | 32d | 4d | 0d | start no earlier than 2018-08-03 |  | 544h | 61,120 | 61,120 |
| 69 | 8.1 | Define the problem |  | 1d | 2018-08-03 | 2018-08-03 |  | 2018-08-03 | 2018-08-03 | 1d | 4d | 0d | start no earlier than 2018-08-03 | Software Architect Lead | 8h | 1,040 | 1,040 |
| 70 | 8.2 | Research indusrty standards |  | 2d | 2018-08-06 | 2018-08-07 | 69 | 2018-08-06 | 2018-08-07 | 2d | 4d | 0d |  | Software Architect Lead | 16h | 2,080 | 2,080 |
| 71 | 8.3 | Setup brainstorming sessions |  | 2d | 2018-08-08 | 2018-08-09 | 70 | 2018-08-08 | 2018-08-09 | 2d | 4d | 0d |  | Software Architect Lead | 16h | 2,080 | 2,080 |
| 72 | 8.4 | Establish detailed design workshops |  | 2d | 2018-08-10 | 2018-08-13 | 71 | 2018-08-10 | 2018-08-13 | 2d | 4d | 0d |  | Software Architect Lead | 16h | 2,080 | 2,080 |
| 73 | 8.5 | Establish Joint application design workshop |  | 2d | 2018-08-14 | 2018-08-15 | 72 | 2018-08-14 | 2018-08-15 | 2d | 4d | 0d |  | Software Architect Lead | 16h | 2,080 | 2,080 |
| 74 | 8.6 | Establish Storyboard workshops |  | 3d | 2018-08-16 | 2018-08-20 | 73 | 2018-08-16 | 2018-08-20 | 3d | 4d | 0d |  | Software Architect Lead | 24h | 3,120 | 3,120 |
| 75 | 8.7 | Document brainstorming sessions |  | 2d | 2018-08-21 | 2018-08-22 | 74 | 2018-08-21 | 2018-08-22 | 2d | 4d | 0d |  | Graphic Designer 1; Graphic Designer 2; Software Architect 1; Software Architect 2 | 64h | 6,720 | 6,720 |
| 76 | 8.8 | Sketch prototype |  | 3d | 2018-08-23 | 2018-08-27 | 75 | 2018-08-23 | 2018-08-27 | 3d | 4d | 0d |  | Graphic Designer 1; Graphic Designer 2; Software Architect 1; Software Architect 2 | 96h | 10,080 | 10,080 |
| 77 | 8.9 | Create physical model |  | 3d | 2018-08-28 | 2018-08-30 | 76 | 2018-08-28 | 2018-08-30 | 3d | 4d | 0d |  | Graphic Designer 1; Graphic Designer 2; Software Architect 1; Software Architect 2 | 96h | 10,080 | 10,080 |
| 78 | 8.10 | Evaluation of software using |  | 4d | 2018-08-31 | 2018-09-05 | 77 | 2018-08-31 | 2018-09-05 | 4d | 4d | 0d |  | Graphic Designer 1; Graphic Designer 2; Software Architect 1; Software Architect 2 | 128h | 13,440 | 13,440 |
| 79 | 8.11 | Integrate technical standards |  | 2d | 2018-09-06 | 2018-09-07 | 78 | 2018-09-06 | 2018-09-07 | 2d | 4d | 0d |  | Software Architect Lead | 16h | 2,080 | 2,080 |
| 80 | 8.12 | Review design prototype |  | 2d | 2018-09-10 | 2018-09-11 | 79 | 2018-09-10 | 2018-09-11 | 2d | 4d | 0d |  | Software Architect Lead | 16h | 2,080 | 2,080 |
| 81 | 8.13 | Approve design prototype |  | 1d | 2018-09-12 | 2018-09-12 | 80 | 2018-09-12 | 2018-09-12 | 1d | 4d | 0d |  | Software Architect Lead | 8h | 1,040 | 1,040 |
| 82 | 8.14 | Review storyboard |  | 2d | 2018-09-13 | 2018-09-14 | 81 | 2018-09-13 | 2018-09-14 | 2d | 4d | 0d |  | Software Architect Lead | 16h | 2,080 | 2,080 |
| 83 | 8.15 | Approve storyboard |  | 1d | 2018-09-17 | 2018-09-17 | 82 | 2018-09-17 | 2018-09-17 | 1d | 4d | 0d |  | Software Architect Lead | 8h | 1,040 | 1,040 |
| 84 | 8.16 | Design concept developed | milestone | 0d | 2018-09-17 | 2018-09-17 | 83 | 2018-09-17 | 2018-09-17 | 0d | 4d |  |  |  |  |  |  |
| 85 | 9 | **Develop Detailed Software Design** |  | 88d | 2018-09-18 | 2019-01-24 | 68 | 2018-09-18 | 2019-01-24 | 88d | 4d | 0d |  |  | 2840h | 345,760 | 345,760 |
| 86 | 9.1 | Design prototypes |  | 8d | 2018-09-18 | 2018-09-27 |  | 2018-09-18 | 2018-09-27 | 8d | 4d | 0d |  | Software Developer 1; Software Developer 2; Subcontractor 1 | 192h | 24,960 | 24,960 |
| 87 | 9.2 | Design of user interfaces |  | 8d | 2018-09-28 | 2018-10-09 | 86 | 2018-09-28 | 2018-10-09 | 8d | 4d | 0d |  | Software Developer 1; Software Developer 2 | 128h | 16,640 | 16,640 |
| 88 | 9.3 | Design storyboard |  | 8d | 2018-10-10 | 2018-10-19 | 87 | 2018-10-10 | 2018-10-19 | 8d | 4d | 0d |  | Database Analyst 1; Software Developer 3; Software Developer 4; Subcontractor 2 | 256h | 31,360 | 31,360 |
| 89 | 9.4 | Design graphics |  | 16d | 2018-10-22 | 2018-11-12 | 88 | 2018-10-22 | 2018-11-12 | 16d | 4d | 0d |  | Graphic Designer 1; Graphic Designer 2; Software Developer 1; Software Developer 2 | 512h | 53,760 | 53,760 |
| 90 | 9.5 | Design Functionality |  | 16d | 2018-11-13 | 2018-12-05 | 89 | 2018-11-13 | 2018-12-05 | 16d | 4d | 0d |  | Software Developer 1; Software Developer 2; Subcontractor 1 | 384h | 49,920 | 49,920 |
| 91 | 9.6 | Design Process flows |  | 24d | 2018-12-06 | 2019-01-14 | 90 | 2018-12-06 | 2019-01-14 | 24d | 4d | 0d |  | Database Analyst 1; Database Analyst 2; Software Developer 1; Software Developer 2; Software Developer Lead; Database Administrator | 1152h | 140,160 | 140,160 |
| 92 | 9.7 | Design SQL database schemas |  | 8d | 2019-01-15 | 2019-01-24 | 91 | 2019-01-15 | 2019-01-24 | 8d | 4d |  |  | Software Developer 2 | 64h | 8,320 | 8,320 |
| 93 | 9.8 | Verification of detailed designs |  | 3d | 2018-09-18 | 2018-09-20 |  | 2018-09-18 | 2018-09-20 | 3d | 10d | 0d |  | Database Administrator; Software Developer Lead | 48h | 6,480 | 6,480 |
| 94 | 9.9 | Document system design specifications |  | 3d | 2018-10-10 | 2018-10-12 | 93 | 2018-10-10 | 2018-10-12 | 3d | 10d | 0d |  | Software Developer 1 | 24h | 3,120 | 3,120 |
| 95 | 9.10 | Review detailed designs |  | 3d | 2018-10-15 | 2018-10-17 | 94 | 2018-10-15 | 2018-10-17 | 3d | 10d | 0d |  | Software Developer Lead | 24h | 3,600 | 3,600 |
| 96 | 9.11 | Approve detailed designs |  | 2d | 2018-10-18 | 2018-10-19 | 95 | 2018-10-18 | 2018-10-19 | 2d | 10d | 0d |  | Software Developer Lead; Database Administrator | 32h | 4,320 | 4,320 |
| 97 | 9.12 | Documentation of detailed design |  | 3d | 2019-01-15 | 2019-01-17 | 96 | 2019-01-15 | 2019-01-17 | 3d | 9d |  |  | Software Developer 1 | 24h | 3,120 | 3,120 |
| 98 | 9.13 | Software design completed | milestone | 0d | 2019-01-24 | 2019-01-24 |  | 2019-01-24 | 2019-01-24 | 0d | 5d |  | start no earlier than 2019-01-24 |  |  |  |  |

| ID | WBS | Task | Type | Duration | Start | Finish | Predecessors | Baseline start | Baseline finish | Baseline duration | Total slack | Free slack | Constraint | Resources | Work | Cost | Baseline cost |
| --- | --- | --- | --- | --- | --- | --- | --- | --- | --- | --- | --- | --- | --- | --- | --- | --- | --- |
| 99 | 10 | **Software Development** |  | 31d | 2019-01-25 | 2019-03-08 | 85 | 2019-01-25 | 2019-03-08 | 31d | 4d | 0d |  |  | 648h | 80,720 | 80,720 |
| 100 | 10.1 | Collect business requirements documents |  | 1d | 2019-01-25 | 2019-01-25 |  | 2019-01-25 | 2019-01-25 | 1d | 4d | 0d | start no earlier than 2018-01-25 | Database Analyst 1; Software Developer 4 | 16h | 1,840 | 1,840 |
| 101 | 10.2 | Collect requirements specification documents |  | 1d | 2019-01-28 | 2019-01-28 | 100 | 2019-01-28 | 2019-01-28 | 1d | 4d | 0d |  | Software Developer 4; Database Analyst 1 | 16h | 1,840 | 1,840 |
| 102 | 10.3 | Collect design documents |  | 2d | 2019-01-29 | 2019-01-30 | 101 | 2019-01-29 | 2019-01-30 | 2d | 4d | 0d |  | Software Developer 4; Database Analyst 2 | 32h | 3,680 | 3,680 |
| 103 | 10.4 | Collect design specifications |  | 1d | 2019-01-31 | 2019-01-31 | 102 | 2019-01-31 | 2019-01-31 | 1d | 4d | 0d |  | Software Developer 4 | 8h | 1,040 | 1,040 |
| 104 | 10.5 | Generate code for user interface |  | 9d | 2019-02-01 | 2019-02-13 | 103 | 2019-02-01 | 2019-02-13 | 9d | 4d | 0d |  | Subcontractor 1; Software Developer 1; Software Developer 2; Software Developer 3 | 288h | 37,440 | 37,440 |
| 105 | 10.6 | Integrate graphics |  | 7d | 2019-02-14 | 2019-02-22 | 104 | 2019-02-14 | 2019-02-22 | 7d | 4d | 0d |  | Software Developer 1; Software Developer 2 | 112h | 14,560 | 14,560 |
| 106 | 10.7 | Construct database tables |  | 1d | 2019-02-25 | 2019-02-25 | 105 | 2019-02-25 | 2019-02-25 | 1d | 4d | 0d |  | Database Analyst 3; Database Analyst 4 | 16h | 1,600 | 1,600 |
| 107 | 10.8 | Establish table relationships |  | 1d | 2019-02-26 | 2019-02-26 | 106 | 2019-02-26 | 2019-02-26 | 1d | 4d | 0d |  | Database Analyst 3; Database Analyst 4 | 16h | 1,600 | 1,600 |
| 108 | 10.9 | Generate code for reports (SQL) |  | 8d | 2019-02-27 | 2019-03-08 | 107, 92 | 2019-02-27 | 2019-03-08 | 8d | 4d |  |  | Database Analyst 2; Software Developer 3 | 128h | 14,720 | 14,720 |
| 109 | 10.10 | Review product |  | 1d | 2019-01-25 | 2019-01-25 |  | 2019-01-25 | 2019-01-25 | 1d | 33d | 0d |  | Software Developer Lead | 8h | 1,200 | 1,200 |
| 110 | 10.11 | Approve product |  | 1d | 2019-01-28 | 2019-01-28 | 109 | 2019-01-28 | 2019-01-28 | 1d | 33d | 0d |  | Software Developer Lead | 8h | 1,200 | 1,200 |
| 111 | 10.12 | Software developed | milestone | 0d | 2019-01-28 | 2019-01-28 | 110 | 2018-03-05 | 2018-03-05 | 0d | 33d | 29d | start no earlier than 2019-01-24 |  |  |  |  |
| 112 | 11 | **Develop System Documentation** |  | 95d | 2019-03-11 | 2019-07-19 | 99 | 2019-03-11 | 2019-07-19 | 95d | 47d |  | start no earlier than 2019-03-06 |  | 208h | 25,840 | 25,840 |
| 113 | 11.1 | Write document overview of system |  | 2d | 2019-03-11 | 2019-03-12 |  | 2019-03-11 | 2019-03-12 | 2d | 78d | 0d | start no earlier than 2019-03-06 | Technical Writer | 16h | 1,440 | 1,440 |
| 114 | 11.2 | Write document disaster recovery backups |  | 2d | 2019-03-13 | 2019-03-14 | 113 | 2019-03-13 | 2019-03-14 | 2d | 78d | 0d |  | Database Administrator | 16h | 1,920 | 1,920 |
| 115 | 11.3 | Write document troubleshooting material |  | 2d | 2019-03-15 | 2019-03-18 | 114 | 2019-03-15 | 2019-03-18 | 2d | 78d | 0d |  | Database Administrator | 16h | 1,920 | 1,920 |
| 116 | 11.4 | Write document hardware configuration |  | 1d | 2019-03-19 | 2019-03-19 | 115 | 2019-03-19 | 2019-03-19 | 1d | 78d | 0d | start no earlier than 2019-03-12 | Network Engineer | 8h | 960 | 960 |
| 117 | 11.5 | Write document process flows |  | 1d | 2019-03-20 | 2019-03-20 | 116 | 2019-03-20 | 2019-03-20 | 1d | 78d | 0d | start no earlier than 2019-03-13 | Database Analyst 1; Database Analyst 2 | 16h | 1,600 | 1,600 |
| 118 | 11.6 | Write document technical software specification |  | 4d | 2019-03-21 | 2019-03-26 | 117 | 2019-03-21 | 2019-03-26 | 4d | 78d |  | start no earlier than 2019-03-14 | Software Developer 1; Software Developer 2 | 32h | 4,160 | 4,160 |
| 119 | 11.7 | Write Network documentation |  | 2d | 2019-07-15 | 2019-07-16 | 204, 118 | 2019-07-15 | 2019-07-16 | 2d | -30d | 0d | must start on 2019-07-15 | Network Administrator | 16h | 1,920 | 1,920 |
| 120 | 11.8 | Write user/system help files |  | 4d | 2019-03-28 | 2019-04-02 |  | 2019-03-28 | 2019-04-02 | 4d | 123d | 0d | start no earlier than 2019-03-27 | Software Developer 3; Software Developer 4 | 32h | 4,160 | 4,160 |
| 121 | 11.9 | Write user techninal training manual |  | 2d | 2019-04-03 | 2019-04-04 | 120 | 2019-04-03 | 2019-04-04 | 2d | 123d |  | start no earlier than 2019-04-01 | Software Developer 1; Software Developer 2 | 32h | 4,160 | 4,160 |
| 122 | 11.10 | Review system documentation |  | 2d | 2019-07-17 | 2019-07-18 | 119 | 2019-07-17 | 2019-07-18 | 2d | 48d |  |  | Software Developer Lead | 16h | 2,400 | 2,400 |
| 123 | 11.11 | Approve system documentation |  | 1d | 2019-07-19 | 2019-07-19 |  | 2019-07-19 | 2019-07-19 | 1d | -30d | 0d | start no earlier than 2019-07-19 | Software Developer Lead | 8h | 1,200 | 1,200 |
| 124 | 11.12 | System documentation created | milestone | 0d | 2019-07-19 | 2019-07-19 | 123 | 2019-07-19 | 2019-07-19 | 0d | -30d | 0d |  |  |  |  |  |

| ID | WBS | Task | Type | Duration | Start | Finish | Predecessors | Baseline start | Baseline finish | Baseline duration | Total slack | Free slack | Constraint | Resources | Work | Cost | Baseline cost |
| --- | --- | --- | --- | --- | --- | --- | --- | --- | --- | --- | --- | --- | --- | --- | --- | --- | --- |
| 125 | 12 | **Design Software Test Plans** |  | 12d | 2019-03-11 | 2019-03-26 | 99 | 2019-03-11 | 2019-03-26 | 12d | 4d | 0d | start no earlier than 2019-03-11 |  | 192h | 24,000 | 24,000 |
| 126 | 12.1 | Design test scenarios |  | 2d | 2019-03-11 | 2019-03-12 | 111 | 2019-03-11 | 2019-03-12 | 2d | 4d | 0d |  | Software Developer 3; Software Developer 4 | 32h | 4,160 | 4,160 |
| 127 | 12.2 | Design use cases |  | 2d | 2019-03-13 | 2019-03-14 | 126 | 2019-03-13 | 2019-03-14 | 2d | 4d | 0d |  | Software Developer 3; Software Developer 4 | 32h | 4,160 | 4,160 |
| 128 | 12.3 | Design test scripts |  | 4d | 2019-03-15 | 2019-03-20 | 127 | 2019-03-15 | 2019-03-20 | 4d | 4d | 0d |  | Software Developer 1; Software Developer 2; Technical Writer | 96h | 11,200 | 11,200 |
| 129 | 12.4 | Design results document |  | 2d | 2019-03-21 | 2019-03-22 | 128 | 2019-03-21 | 2019-03-22 | 2d | 4d | 0d |  | Software Developer 2 | 16h | 2,080 | 2,080 |
| 130 | 12.5 | Review test plan designs |  | 1d | 2019-03-25 | 2019-03-25 | 129 | 2019-03-25 | 2019-03-25 | 1d | 4d | 0d |  | Software Developer Lead | 8h | 1,200 | 1,200 |
| 131 | 12.6 | Approve test plan designs |  | 1d | 2019-03-26 | 2019-03-26 | 130 | 2019-03-26 | 2019-03-26 | 1d | 4d | 0d |  | Software Developer Lead | 8h | 1,200 | 1,200 |
| 132 | 12.7 | Software test plans designed | milestone | 0d | 2019-03-26 | 2019-03-26 | 131 | 2019-03-26 | 2019-03-26 | 0d | 4d |  |  |  |  |  |  |
| 133 | 13 | **Develop Software Test Plans** |  | 7d | 2019-03-27 | 2019-04-04 | 125 | 2019-03-27 | 2019-04-04 | 7d | 0d |  |  |  | 136h | 18,480 | 18,480 |
| 134 | 13.1 | Create test scenario/cases |  | 2d | 2019-03-27 | 2019-03-28 | 130 | 2019-03-27 | 2019-03-28 | 2d | 5d |  |  | Software Developer 1; Software Developer 2 | 32h | 4,160 | 4,160 |
| 135 | 13.2 | Create user test scripts |  | 2d | 2019-03-29 | 2019-04-01 | 131 | 2019-03-29 | 2019-04-01 | 2d | 3d |  | start no earlier than 2019-03-29 | Software Developer 1; Software Developer 2 | 32h | 4,160 | 4,160 |
| 136 | 13.3 | Create results document |  | 2d | 2019-03-27 | 2019-03-28 | 129 | 2019-03-27 | 2019-03-28 | 2d | 5d |  |  | Software Developer 3 | 16h | 2,080 | 2,080 |
| 137 | 13.4 | Write System Test procedures |  | 2d | 2019-03-27 | 2019-03-29 |  | 2019-03-27 | 2019-03-29 | 2d | 4d |  |  | Software Developer 3; Software Developer 4 | 16h | 2,080 | 2,080 |
| 138 | 13.5 | Verify system test procedures |  | 1d | 2019-03-27 | 2019-03-27 |  | 2019-03-27 | 2019-03-27 | 1d | 6d |  |  | Software Developer Lead | 8h | 1,200 | 1,200 |
| 139 | 13.6 | Establish the System Testing environment |  | 1d | 2019-03-28 | 2019-03-28 |  | 2019-03-28 | 2019-03-28 | 1d | 5d |  |  | Software Developer Lead | 8h | 1,200 | 1,200 |
| 140 | 13.7 | Write User acceptance test procedures |  | 1d | 2019-04-02 | 2019-04-02 |  | 2019-04-02 | 2019-04-02 | 1d | 0d |  | start no earlier than 2019-04-02 | Software Developer Lead | 8h | 1,200 | 1,200 |
| 141 | 13.8 | Verify user acceptance test procedures |  | 1d | 2019-04-03 | 2019-04-03 | 140 | 2019-04-03 | 2019-04-03 | 1d | 0d |  |  | Software Developer Lead | 8h | 1,200 | 1,200 |
| 142 | 13.9 | Approve test plans and procedures |  | 1d | 2019-04-04 | 2019-04-04 | 141 | 2019-04-04 | 2019-04-04 | 1d | 0d |  |  | Software Developer Lead | 8h | 1,200 | 1,200 |
| 143 | 13.10 | Software test plans developed | milestone | 0d | 2019-04-04 | 2019-04-04 | 142 | 2019-04-04 | 2019-04-04 | 0d | 0d |  |  |  |  |  |  |
| 144 | 14 | **Q&A Testing** |  | 29d | 2019-04-05 | 2019-05-15 | 133 | 2019-04-05 | 2019-05-15 | 29d | 0d |  |  |  | 560h | 62,400 | 62,400 |
| 145 | 14.1 | Conduct system testing |  | 5d | 2019-04-05 | 2019-04-11 | 143 | 2019-04-05 | 2019-04-11 | 5d | 0d |  |  | Software Developer 4; Software Developer 3 | 80h | 10,400 | 10,400 |
| 146 | 14.2 | Generate requirements matrix |  | 1d | 2019-04-12 | 2019-04-12 | 63, 145 | 2019-04-12 | 2019-04-12 | 1d | 0d |  |  | Quality Assurance Manager | 8h | 960 | 960 |
| 147 | 14.3 | Verify/Validate functionality |  | 3d | 2019-04-15 | 2019-04-17 | 104, 106, 146 | 2019-04-15 | 2019-04-17 | 3d | 0d |  |  | Software Tester 1; Software Tester 2; Software Tester 3 | 72h | 7,200 | 7,200 |
| 148 | 14.4 | Verify/Validate table relationships |  | 3d | 2019-04-18 | 2019-04-22 | 106, 107, 147 | 2019-04-18 | 2019-04-22 | 3d | 0d |  |  | Software Tester 1; Software Tester 2; Software Tester 3 | 72h | 7,200 | 7,200 |
| 149 | 14.5 | Verify/Validate data elements |  | 3d | 2019-04-23 | 2019-04-25 | 104, 106, 107, 148 | 2019-04-23 | 2019-04-25 | 3d | 0d |  | start no earlier than 2019-04-18 | Software Tester 1; Software Tester 2; Software Tester 3 | 72h | 7,200 | 7,200 |
| 150 | 14.6 | Verify results match results documents |  | 3d | 2019-04-26 | 2019-04-30 | 140, 149 | 2019-04-26 | 2019-04-30 | 3d | 0d |  | start no earlier than 2019-04-23 | Software Tester 1; Software Tester 2; Software Tester 3 | 72h | 7,200 | 7,200 |
| 151 | 14.7 | Document defects reported |  | 2d | 2019-05-01 | 2019-05-02 | 150 | 2019-05-01 | 2019-05-02 | 2d | 0d |  |  | Software Developer 1 | 16h | 2,080 | 2,080 |
| 152 | 14.8 | Fix defects |  | 4d | 2019-05-03 | 2019-05-08 | 151 | 2019-05-03 | 2019-05-08 | 4d | 0d |  |  | Software Developer 2; Software Developer 3; Subcontractor 1 | 96h | 12,480 | 12,480 |
| 153 | 14.9 | Retest |  | 2d | 2019-05-09 | 2019-05-10 | 152 | 2019-05-09 | 2019-05-10 | 2d | 0d |  |  | Software Tester 1; Software Tester 2; Software Tester 3 | 48h | 4,800 | 4,800 |
| 154 | 14.10 | Complete software readiness review |  | 2d | 2019-05-13 | 2019-05-14 | 153 | 2019-05-13 | 2019-05-14 | 2d | 0d |  |  | Quality Assurance Manager | 16h | 1,920 | 1,920 |
| 155 | 14.11 | Approve software readiness review |  | 1d | 2019-05-15 | 2019-05-15 | 154 | 2019-05-15 | 2019-05-15 | 1d | 0d |  |  | Quality Assurance Manager | 8h | 960 | 960 |
| 156 | 14.12 | Test plan tested | milestone | 0d | 2019-05-15 | 2019-05-15 | 155 | 2019-05-15 | 2019-05-15 | 0d | 0d |  |  |  |  |  |  |

| ID | WBS | Task | Type | Duration | Start | Finish | Predecessors | Baseline start | Baseline finish | Baseline duration | Total slack | Free slack | Constraint | Resources | Work | Cost | Baseline cost |
| --- | --- | --- | --- | --- | --- | --- | --- | --- | --- | --- | --- | --- | --- | --- | --- | --- | --- |
| 157 | 15 | **User Acceptance Testing** |  | 10d | 2019-05-16 | 2019-05-29 | 144 | 2019-05-16 | 2019-05-29 | 10d | 0d |  | start no earlier than 2019-05-16 |  | 80h | 10,880 | 10,880 |
| 158 | 15.1 | Produce final deliverable |  | 1d | 2019-05-16 | 2019-05-16 |  | 2019-05-16 | 2019-05-16 | 1d | 0d |  | start no earlier than 2019-05-16 | Software Developer Lead | 8h | 1,200 | 1,200 |
| 159 | 15.2 | Draft user acceptance test document |  | 1d | 2019-05-17 | 2019-05-17 | 158 | 2019-05-17 | 2019-05-17 | 1d | 0d |  | start no earlier than 2019-05-16 | Software Developer Lead | 8h | 1,200 | 1,200 |
| 160 | 15.3 | Provide user acceptance criteria check off sheet |  | 1d | 2019-05-20 | 2019-05-20 | 159 | 2019-05-20 | 2019-05-20 | 1d | 0d |  | start no earlier than 2019-05-20 | Software Developer Lead | 8h | 1,200 | 1,200 |
| 161 | 15.4 | Conduct user acceptance testing |  | 2d | 2019-05-21 | 2019-05-22 | 160 | 2019-05-21 | 2019-05-22 | 2d | 0d |  |  | Software Developer Lead | 16h | 2,400 | 2,400 |
| 162 | 15.5 | Document findings |  | 1d | 2019-05-23 | 2019-05-23 | 161 | 2019-05-23 | 2019-05-23 | 1d | 0d |  |  | Software Developer 1 | 8h | 1,040 | 1,040 |
| 163 | 15.6 | Review modifications |  | 1d | 2019-05-24 | 2019-05-24 | 162 | 2019-05-24 | 2019-05-24 | 1d | 0d |  |  | Software Developer Lead | 8h | 1,200 | 1,200 |
| 164 | 15.7 | Make adjustments |  | 1d | 2019-05-27 | 2019-05-27 | 163 | 2019-05-27 | 2019-05-27 | 1d | 0d |  |  | Software Developer 2 | 8h | 1,040 | 1,040 |
| 165 | 15.8 | User approval sign-off |  | 1d | 2019-05-28 | 2019-05-28 | 164 | 2019-05-28 | 2019-05-28 | 1d | 0d |  |  | Project Sponsor | 8h |  |  |
| 166 | 15.9 | Project Manager approval sign-off |  | 1d | 2019-05-29 | 2019-05-29 | 165 | 2019-05-29 | 2019-05-29 | 1d | 0d |  |  | Project Manager | 8h | 1,600 | 1,600 |
| 167 | 15.10 | User acceptance testing completed | milestone | 0d | 2019-05-29 | 2019-05-29 | 166 | 2019-05-29 | 2019-05-29 | 0d | 0d |  |  |  |  |  |  |
| 168 | 16 | **Environment Readiness** |  | 3d | 2019-05-30 | 2019-06-03 | 157 | 2019-05-30 | 2019-06-03 | 3d | 0d |  |  |  | 24h | 3,680 | 3,680 |
| 169 | 16.1 | Establish delivery of final product |  | 1d | 2019-05-30 | 2019-05-30 |  | 2019-05-30 | 2019-05-30 | 1d | 0d |  |  | Project Manager | 8h | 1,600 | 1,600 |
| 170 | 16.2 | Installation of product |  | 1d | 2019-05-31 | 2019-05-31 | 169 | 2019-05-31 | 2019-05-31 | 1d | 0d |  |  | Software Developer 1 | 8h | 1,040 | 1,040 |
| 171 | 16.3 | Environment readiness testing |  | 1d | 2019-06-03 | 2019-06-03 | 170 | 2019-06-03 | 2019-06-03 | 1d | 0d |  | start no earlier than 2019-05-31 | Software Developer 2 | 8h | 1,040 | 1,040 |
| 172 | 16.4 | Environment ready | milestone | 0d | 2019-06-03 | 2019-06-03 | 171 | 2019-06-03 | 2019-06-03 | 0d | 0d |  |  |  |  |  |  |
| 173 | 17 | **Deploy Software** |  | 36d | 2019-06-04 | 2019-07-23 | 168 | 2019-06-04 | 2019-07-23 | 36d | -30d | 0d |  |  | 72h | 9,680 | 9,680 |
| 174 | 17.1 | Setup cloud server |  | 2d | 2019-06-04 | 2019-06-05 |  | 2019-06-04 | 2019-06-05 | 2d | 0d |  |  | Software Developer 1 | 16h | 2,080 | 2,080 |
| 175 | 17.2 | Transfer files to cloud server |  | 1d | 2019-06-06 | 2019-06-06 | 174 | 2019-06-06 | 2019-06-06 | 1d | 0d |  |  | Software Developer 1 | 8h | 1,040 | 1,040 |
| 176 | 17.3 | Transfer software to cloud server |  | 1d | 2019-06-07 | 2019-06-07 | 175 | 2019-06-07 | 2019-06-07 | 1d | 0d |  |  | Software Developer 2 | 8h | 1,040 | 1,040 |
| 177 | 17.4 | Migrate data |  | 1d | 2019-07-22 | 2019-07-22 | 176, 124 | 2019-07-22 | 2019-07-22 | 1d | -30d | 0d |  | Software Developer 1; Software Developer 2 | 16h | 2,080 | 2,080 |
| 178 | 17.5 | Transfer system documentation |  | 1d | 2019-07-23 | 2019-07-23 | 177 | 2019-07-23 | 2019-07-23 | 1d | -30d | 0d |  | Software Developer 2 | 8h | 1,040 | 1,040 |
| 179 | 17.6 | Review migrated data, files, documentation |  | 1d | 2019-06-04 | 2019-06-04 |  | 2019-06-04 | 2019-06-04 | 1d | 4d | 0d |  | Software Developer Lead | 8h | 1,200 | 1,200 |
| 180 | 17.7 | Approve everything transferred sucessfully |  | 1d | 2019-06-05 | 2019-06-05 | 179 | 2019-06-05 | 2019-06-05 | 1d | 4d | 0d |  | Software Developer Lead | 8h | 1,200 | 1,200 |
| 181 | 17.8 | Software deployed | milestone | 0d | 2019-06-05 | 2019-06-05 | 180 | 2019-06-05 | 2019-06-05 | 0d | 4d |  |  |  |  |  |  |

| ID | WBS | Task | Type | Duration | Start | Finish | Predecessors | Baseline start | Baseline finish | Baseline duration | Total slack | Free slack | Resources | Work | Cost | Baseline cost |
| --- | --- | --- | --- | --- | --- | --- | --- | --- | --- | --- | --- | --- | --- | --- | --- | --- |
| 182 | 18 | **Database Security** |  | 10d | 2019-07-24 | 2019-08-06 | 173 | 2019-07-24 | 2019-08-06 | 10d | -30d | 0d |  | 80h | 9,600 | 9,600 |
| 183 | 18.1 | Identify sensitive data needing secured |  | 1d | 2019-07-24 | 2019-07-24 | 181 | 2019-07-24 | 2019-07-24 | 1d | -30d | 0d | Database Administrator | 8h | 960 | 960 |
| 184 | 18.2 | Eliminate any vulnerabilites to comprimising data |  | 1d | 2019-07-25 | 2019-07-25 | 183 | 2019-07-25 | 2019-07-25 | 1d | -30d | 0d | Database Administrator | 8h | 960 | 960 |
| 185 | 18.3 | Enforce user access and establish controls |  | 1d | 2019-07-26 | 2019-07-26 | 184 | 2019-07-26 | 2019-07-26 | 1d | -30d | 0d | Database Administrator | 8h | 960 | 960 |
| 186 | 18.4 | Establish limited data accessibility privilages |  | 1d | 2019-07-29 | 2019-07-29 | 185 | 2019-07-29 | 2019-07-29 | 1d | -30d | 0d | Database Administrator | 8h | 960 | 960 |
| 187 | 18.5 | Monitor activity deviations to ensure polices are being monitored and controlled |  | 1d | 2019-07-30 | 2019-07-30 | 186 | 2019-07-30 | 2019-07-30 | 1d | -30d | 0d | Database Administrator | 8h | 960 | 960 |
| 188 | 18.6 | Document suspecious behaviors |  | 1d | 2019-07-31 | 2019-07-31 | 187 | 2019-07-31 | 2019-07-31 | 1d | -30d | 0d | Database Administrator | 8h | 960 | 960 |
| 189 | 18.7 | Respond to suspicious behaviors |  | 2d | 2019-08-01 | 2019-08-02 | 188 | 2019-08-01 | 2019-08-02 | 2d | -30d | 0d | Database Administrator | 16h | 1,920 | 1,920 |
| 190 | 18.8 | Alert any suspicious activity, minimizes risk |  | 1d | 2019-08-05 | 2019-08-05 | 189 | 2019-08-05 | 2019-08-05 | 1d | -30d | 0d | Database Administrator | 8h | 960 | 960 |
| 191 | 18.9 | Reviewal of documented security breaches |  | 1d | 2019-08-06 | 2019-08-06 | 190 | 2019-08-06 | 2019-08-06 | 1d | -30d | 0d | Database Administrator | 8h | 960 | 960 |
| 192 | 18.10 | Database secured | milestone | 0d | 2019-08-06 | 2019-08-06 | 191 | 2019-08-06 | 2019-08-06 | 0d | -30d | 0d |  |  |  |  |
| 193 | 19 | **Network Security** |  | 13d | 2019-08-07 | 2019-08-23 | 182, 144 | 2019-08-07 | 2019-08-23 | 13d | -30d | 0d |  | 104h | 12,480 | 12,480 |
| 194 | 19.1 | Create multiple layers of defense |  | 2d | 2019-08-07 | 2019-08-08 |  | 2019-08-07 | 2019-08-08 | 2d | -30d | 0d | Network Administrator | 16h | 1,920 | 1,920 |
| 195 | 19.2 | Install anitvirus software |  | 1d | 2019-08-09 | 2019-08-09 | 194 | 2019-08-09 | 2019-08-09 | 1d | -30d | 0d | Network Engineer | 8h | 960 | 960 |
| 196 | 19.3 | Block resources that are threats to hardware/software |  | 2d | 2019-08-12 | 2019-08-13 | 195 | 2019-08-12 | 2019-08-13 | 2d | -30d | 0d | Network Administrator | 16h | 1,920 | 1,920 |
| 197 | 19.4 | Give only authorized user access |  | 1d | 2019-08-14 | 2019-08-14 | 196 | 2019-08-14 | 2019-08-14 | 1d | -30d | 0d | Network Administrator | 8h | 960 | 960 |
| 198 | 19.5 | Enforce security policies |  | 1d | 2019-08-15 | 2019-08-15 | 197 | 2019-08-15 | 2019-08-15 | 1d | -30d | 0d | Network Administrator | 8h | 960 | 960 |
| 199 | 19.6 | Generate analytical reports |  | 1d | 2019-08-16 | 2019-08-16 | 198 | 2019-08-16 | 2019-08-16 | 1d | -30d | 0d | Network Administrator | 8h | 960 | 960 |
| 200 | 19.7 | Analyze reports |  | 1d | 2019-08-19 | 2019-08-19 | 199 | 2019-08-19 | 2019-08-19 | 1d | -30d | 0d | Network Administrator | 8h | 960 | 960 |
| 201 | 19.8 | Document findings |  | 1d | 2019-08-20 | 2019-08-20 | 200 | 2019-08-20 | 2019-08-20 | 1d | -30d | 0d | Network Engineer | 8h | 960 | 960 |
| 202 | 19.9 | Provide resolution |  | 1d | 2019-08-21 | 2019-08-21 | 201 | 2019-08-21 | 2019-08-21 | 1d | -30d | 0d | Network Engineer | 8h | 960 | 960 |
| 203 | 19.10 | Review network parameters |  | 1d | 2019-08-22 | 2019-08-22 | 202 | 2019-08-22 | 2019-08-22 | 1d | -30d | 0d | Network Administrator | 8h | 960 | 960 |
| 204 | 19.11 | Approve Network parameters |  | 1d | 2019-08-23 | 2019-08-23 | 203 | 2019-08-23 | 2019-08-23 | 1d | -30d | 0d | Network Administrator | 8h | 960 | 960 |
| 205 | 19.12 | Network secured | milestone | 0d | 2019-08-23 | 2019-08-23 | 204 | 2019-08-23 | 2019-08-23 | 0d | 0d |  |  |  |  |  |

| ID | WBS | Task | Type | Duration | Start | Finish | Predecessors | Baseline start | Baseline finish | Baseline duration | Total slack | Constraint | Resources | Work | Cost | Baseline cost |
| --- | --- | --- | --- | --- | --- | --- | --- | --- | --- | --- | --- | --- | --- | --- | --- | --- |
| 206 | 20 | **Train End Users** |  | 5d | 2019-08-26 | 2019-08-30 | 193 | 2019-08-26 | 2019-08-30 | 5d | 0d |  |  | 40h | 5,200 | 5,200 |
| 207 | 20.1 | DevelopTraining materials |  | 2d | 2019-08-26 | 2019-08-27 |  | 2019-08-26 | 2019-08-27 | 2d | 0d |  | Software Developer 1 | 16h | 2,080 | 2,080 |
| 208 | 20.2 | Use case scripts utilized |  | 1d | 2019-08-28 | 2019-08-28 | 207 | 2019-08-28 | 2019-08-28 | 1d | 0d |  | Software Developer 1 | 8h | 1,040 | 1,040 |
| 209 | 20.3 | End user training Internal |  | 1d | 2019-08-29 | 2019-08-29 | 208 | 2019-08-29 | 2019-08-29 | 1d | 0d |  | Software Developer 1 | 8h | 1,040 | 1,040 |
| 210 | 20.4 | End user training External |  | 1d | 2019-08-30 | 2019-08-30 | 209 | 2019-08-30 | 2019-08-30 | 1d | 0d |  | Software Developer 1 | 8h | 1,040 | 1,040 |
| 211 | 20.5 | Training completed | milestone | 0d | 2019-08-30 | 2019-08-30 | 210 | 2019-08-30 | 2019-08-30 | 0d | 0d |  | Software Developer 1 |  |  |  |
| 212 | 21 | **Technical Support** |  | 5d | 2019-09-02 | 2019-09-06 | 206 | 2019-09-02 | 2019-09-06 | 5d | 0d |  |  | 80h | 4,000 | 4,000 |
| 213 | 21.1 | Log issues |  | 1d | 2019-09-02 | 2019-09-02 |  | 2019-09-02 | 2019-09-02 | 1d | 0d |  | Technical Support 1; Technical Support 2 | 16h | 800 | 800 |
| 214 | 21.2 | Review technical issues |  | 1d | 2019-09-03 | 2019-09-03 | 213 | 2019-09-03 | 2019-09-03 | 1d | 0d |  | Technical Support 1; Technical Support 2 | 16h | 800 | 800 |
| 215 | 21.3 | Provide resolution |  | 2d | 2019-09-04 | 2019-09-05 | 214 | 2019-09-04 | 2019-09-05 | 2d | 0d |  | Technical Support 1; Technical Support 2 | 32h | 1,600 | 1,600 |
| 216 | 21.4 | Monitor satisfaction |  | 1d | 2019-09-06 | 2019-09-06 | 215 | 2019-09-06 | 2019-09-06 | 1d | 0d |  | Technical Support 1; Technical Support 2 | 16h | 800 | 800 |
| 217 | 21.5 | Technical support completed | milestone | 0d | 2019-09-06 | 2019-09-06 | 216 | 2019-09-06 | 2019-09-06 | 0d | 0d |  |  |  |  |  |
| 218 | 22 | **E-Learning Educational Software Closure** |  | 8d | 2019-09-06 | 2019-09-18 | 212 | 2019-09-06 | 2019-09-18 | 8d | 0d | start no earlier than 2019-07-29 |  | 64h | 12,800 | 12,800 |
| 219 | 22.1 | Close contract |  | 1d | 2019-09-09 | 2019-09-09 | 217 | 2019-09-09 | 2019-09-09 | 1d | 0d |  | Project Manager | 8h | 1,600 | 1,600 |
| 220 | 22.2 | Asses satisfaction |  | 1d | 2019-09-10 | 2019-09-10 | 219 | 2019-09-10 | 2019-09-10 | 1d | 0d |  | Project Manager | 8h | 1,600 | 1,600 |
| 221 | 22.3 | Review team performance |  | 1d | 2019-09-11 | 2019-09-11 | 220 | 2019-09-11 | 2019-09-11 | 1d | 0d |  | Project Manager | 8h | 1,600 | 1,600 |
| 222 | 22.4 | Review financial performance |  | 1d | 2019-09-12 | 2019-09-12 | 221 | 2019-09-12 | 2019-09-12 | 1d | 0d |  | Project Manager | 8h | 1,600 | 1,600 |
| 223 | 22.5 | Close project records |  | 1d | 2019-09-13 | 2019-09-13 | 222 | 2019-09-13 | 2019-09-13 | 1d | 0d |  | Project Manager | 8h | 1,600 | 1,600 |
| 224 | 22.6 | Summarize project results |  | 2d | 2019-09-16 | 2019-09-17 | 223 | 2019-09-16 | 2019-09-17 | 2d | 0d |  | Project Manager | 16h | 3,200 | 3,200 |
| 225 | 22.7 | Release resources |  | 1d | 2019-09-18 | 2019-09-18 | 224 | 2019-09-18 | 2019-09-18 | 1d | 0d |  | Project Manager | 8h | 1,600 | 1,600 |
| 226 | 22.8 | Software completed | milestone | 0d | 2019-09-06 | 2019-09-06 |  | 2019-09-06 | 2019-09-06 | 0d | 8d | start no earlier than 2019-08-07 | Project Manager |  |  |  |
| 227 | 23 | **Contract Closure** |  | 4d | 2019-09-19 | 2019-09-24 | 218 | 2019-09-19 | 2019-09-24 | 4d | 0d | start no earlier than 2019-08-08 |  | 32h | 6,400 | 6,400 |
| 228 | 23.1 | Close contract |  | 1d | 2019-09-19 | 2019-09-19 | 226 | 2019-09-19 | 2019-09-19 | 1d | 0d |  | Project Manager | 8h | 1,600 | 1,600 |
| 229 | 23.2 | Close contract with subcontractor |  | 1d | 2019-09-20 | 2019-09-20 | 225, 228 | 2019-09-20 | 2019-09-20 | 1d | 0d |  | Project Manager | 8h | 1,600 | 1,600 |
| 230 | 23.3 | Gather project files and file away |  | 1d | 2019-09-23 | 2019-09-23 | 229 | 2019-09-23 | 2019-09-23 | 1d | 0d |  | Project Manager | 8h | 1,600 | 1,600 |
| 231 | 23.4 | Document lessons learned |  | 1d | 2019-09-24 | 2019-09-24 | 230 | 2019-09-24 | 2019-09-24 | 1d | 0d |  | Project Manager | 8h | 1,600 | 1,600 |
| 232 | 23.5 | Contract closed | milestone | 0d | 2019-09-24 | 2019-09-24 | 231 | 2019-09-24 | 2019-09-24 | 0d | 0d |  |  |  |  |  |
| 233 | 24 | End Project | milestone | 0d | 2019-09-24 | 2019-09-24 | 232 | 2019-09-24 | 2019-09-24 | 0d | 0d |  |  |  |  |  |
